# 5-1 A2

Schedule from MS Project, 2019-04-18 to 2019-04-18.

## Calendars

- Standard: Mon-Fri 08:00-12:00, 13:00-17:00; Sat-Sun off.

## Resources

| Resource |
| --- |
| AFM 1 |
| AFM2 |
| ENG |
| ENG 2 |
| AVI |
| ELC |
| OXY |
| NDI |

## Schedule

| ID | WBS | Task | Type | Duration | Start | Finish | Resources | Work |
| --- | --- | --- | --- | --- | --- | --- | --- | --- |
| 1 | 1 | GENERAL VISUAL INSPECTION OF CARGO COMPARTMENT UNDERFLOOR (FRAME 7 TO FRAME 29) | manual | 173min | 2019-04-18 08:00 | 2019-04-18 10:53 | AFM 1 | 2.88h |
| 2 | 2 | GENERAL VISUAL INSPECTION OF COCKPIT (FRAME 1 TO FRAME 7) | manual | 50.2min | 2019-04-18 08:00 | 2019-04-18 08:50 | AFM 1 | 0.84h |
| 3 | 3 | GENERAL VISUAL INSPECTION OF (LH) ENGINE NACELLES AFT SECTION | manual | 108min | 2019-04-18 08:00 | 2019-04-18 09:48 | AFM 1 | 1.8h |
| 4 | 4 | GENERAL VISUAL INSPECTION OF (RH) ENGINE NACELLES AFT SECTION | manual | 108min | 2019-04-18 08:00 | 2019-04-18 09:48 | AFM 1 | 1.8h |
| 5 | 5 | GENERAL VISUAL INSPECTION OF CREW DOOR, HINGE, SEAL AND COMPENSATION DEVICE ASSY | manual | 47min | 2019-04-18 08:00 | 2019-04-18 08:47 | AFM 1 | 0.78h |
| 6 | 6 | GENERAL VISUAL INSPECTION OF EMERGENCY EXIT DOOR, SEAL | manual | 15min | 2019-04-18 08:00 | 2019-04-18 08:15 | AFM 1 | 0.25h |
| 7 | 7 | GENERAL VISUAL INSPECTION OF (LH) PARATROOPS DOOR, SEAL, INTERNAL STRUCTURE AND COMPONENTS | manual | 30min | 2019-04-18 08:00 | 2019-04-18 08:30 | AFM 1 | 0.5h |
| 8 | 8 | GENERAL VISUAL INSPECTION OF (RH) PARATROOPS DOOR, SEAL, INTERNAL STRUCTURE AND COMPONENTS | manual | 30min | 2019-04-18 08:00 | 2019-04-18 08:30 | AFM 1 | 0.5h |
| 9 | 9 | GENERAL VISUAL INSPECTION OF CARGO RAMP, SEAL | manual | 95min | 2019-04-18 08:00 | 2019-04-18 09:35 | AFM 1 | 1.58h |
| 10 | 10 | GENERAL VISUAL INSPECTION OF EMERGENCY EXIT, SEAL (UPPER FUSELAGE) | manual | 15min | 2019-04-18 08:00 | 2019-04-18 08:15 | AFM 1 | 0.25h |
| 11 | 11 | GENERAL VISUAL INSPECTION OF CARGO COMPARTMENT EMERGENCY EXIT, SEAL (UPPER FUSELAGE-FWD EXIT) | manual | 15min | 2019-04-18 08:00 | 2019-04-18 08:15 | AFM 1 | 0.25h |
| 12 | 12 | GENERAL VISUAL INSPECTION OF CARGO COMPARTMENT EMERGENCY EXIT, SEAL (UPPER FUSELAGE-AFT EXIT) | manual | 15min | 2019-04-18 08:00 | 2019-04-18 08:15 | AFM 1 | 0.25h |
| 13 | 13 | GENERAL VISUAL INSPECTION OF CONDITIONING COMPARTMENT | manual | 155min | 2019-04-18 08:00 | 2019-04-18 10:35 | AFM 1 | 2.58h |
| 14 | 14 | DETAILED VISUAL INSPECTION FOR CONDITION OF DOOR HINGE AND BAY EMERGENCY LIFERAFT | manual | 29min | 2019-04-18 08:00 | 2019-04-18 08:29 | AFM 1 | 0.48h |
| 15 | 15 | DETAILED VISUAL INSPECTION FOR CONDITION OF BATTERY COMPARTMENT ACCESS HINGE AND BATTERY SUPPORT | manual | 11min | 2019-04-18 08:00 | 2019-04-18 08:11 | AFM 1 | 0.18h |
| 16 | 16 | DETAILED VISUAL INSPECTION OF CREW ENTRY DOOR FOR CONDITION OF THE A.CREW DOOR DEVICES B.BRACING CABLES C.HINGE AND COMPENSATION MECHANISM | manual | 139min | 2019-04-18 08:00 | 2019-04-18 10:19 | AFM 1 | 2.32h |
| 17 | 17 | DETAILED VISUAL INSPECTION OF CREW ENTRY DOOR FOR CONDITION OF THE A.CREW DOOR DEVICES B.BRACING CABLES C.HINGE AND COMPENSATION MECHANISM | manual | 1min | 2019-04-18 08:00 | 2019-04-18 08:01 | AFM 1 | 0.02h |
| 18 | 18 | DETAILED VISUAL INSPECTION OF EMERGENCY EXIT DOOR MECHANISM FOR CONDITION | manual | 27min | 2019-04-18 08:00 | 2019-04-18 08:27 | AFM 1 | 0.45h |
| 19 | 19 | OPERATIONAL CHECK OF EMERGENCY EXIT DOOR | manual | 2min | 2019-04-18 08:00 | 2019-04-18 08:02 | AFM 1 | 0.03h |
| 20 | 20 | DETAILED VISUAL INSPECTION FOR CONDITION OF EMERGENCY EXIT HATCHES MECHANISM | manual | 66min | 2019-04-18 08:00 | 2019-04-18 09:06 | AFM 1 | 1.1h |
| 21 | 21 | OPERATIONAL CHECK OF EMERGENCY EXIT HATCHES | manual | 6min | 2019-04-18 08:00 | 2019-04-18 08:06 | AFM 1 | 0.1h |
| 22 | 22 | DETAILED VISUAL INSPECTION OF CARGO DOOR, DOWNLOCKING HOOKS, PIN AND FIXED HOOKS FOR CONDITION | manual | 75min | 2019-04-18 08:00 | 2019-04-18 09:15 | AFM 1 | 1.25h |
| 23 | 23 | DETAILED VISUAL INSPECTION OF LOCKING HOOKS AND TORQUE TUBE OF RAMP DOOR FOR CONDITION | manual | 154min | 2019-04-18 08:00 | 2019-04-18 10:34 | AFM 1 | 2.57h |
| 24 | 24 | DETAILED VISUAL INSPECTION OF RETAINING RODS AND SLIDERS OF RAMP DOOR FOR CONDITION | manual | 105min | 2019-04-18 08:00 | 2019-04-18 09:45 | AFM 1 | 1.75h |
| 25 | 25 | FUNCTIONAL CHECK OF REAR LATERAL DOORS OPERATION | manual | 10min | 2019-04-18 08:00 | 2019-04-18 08:10 | AFM 1 | 0.17h |
| 26 | 26 | DETAILED VISUAL INSPECTION FOR GENERAL CONDITION OF NOSE GEAR STEERING SYSTEM | manual | 12.2min | 2019-04-18 08:00 | 2019-04-18 08:12 | AFM 1 | 0.2h |
| 27 | 27 | FUNCTIONAL CHECK OF ELEVATOR CONTROL TO VERIFY THE CORRECT ARTIFICIAL FORCE IN THE TOTAL OPERATIVE ENVELOP | manual | 34min | 2019-04-18 08:00 | 2019-04-18 08:34 | AFM 1 | 0.57h |
| 28 | 28 | SERVICING FOR ELEVATOR HYDRAULIC ACCUMULATOR CHARGE | manual | 5min | 2019-04-18 08:00 | 2019-04-18 08:05 | AFM 1 | 0.08h |
| 29 | 29 | FUNCTIONAL CHECK OF FLAP FROM HYDRAULIC SYSTEM No1 & No2 | manual | 40min | 2019-04-18 08:00 | 2019-04-18 08:40 | AFM 1 | 0.67h |
| 30 | 30 | FUNCTIONAL CHECK TO VERIFY THE STOP FUNCTION AT THE END OF FLAP TRAVEL | manual | 10min | 2019-04-18 08:00 | 2019-04-18 08:10 | AFM 1 | 0.17h |
| 31 | 31 | FUNCTIONAL CHECK OF SPOILERS FOR CORRECT EXTENSION | manual | 20min | 2019-04-18 08:00 | 2019-04-18 08:20 | AFM 1 | 0.33h |
| 32 | 32 | CHECK OF SYSTEM SPOILER FOR: A.BY-PASS CORRECT FUNCTION B.BUNGEE AND MIXER BOX MOVEMENT FOR CORRECT OPERATION | manual | 30min | 2019-04-18 08:00 | 2019-04-18 08:30 | AFM 1 | 0.5h |

| ID | WBS | Task | Type | Duration | Start | Finish | Total slack | Resources | Work |
| --- | --- | --- | --- | --- | --- | --- | --- | --- | --- |
| 33 | 33 | **DETAILED VISUAL INSPECTION OF GROUNDING STRAPS** |  | 0.31d | 2019-04-18 08:00 | 2019-04-18 10:28 | 0d |  | 3.47h |
| 34 | 33.1 | ACCESS BY AFM | manual | 148min | 2019-04-18 08:00 | 2019-04-18 10:28 |  | AFM 1 | 2.47h |
| 35 | 33.2 | GENERAL VISUAL INSPECTION BY ENG | manual | 60min | 2019-04-18 08:00 | 2019-04-18 09:00 |  | ENG | 1h |
| 36 | 34 | **DETAILED VISUAL INSPECTION OF INLET GUIDE VANES AND COMPRESSOR BLADES** |  | 0.13d | 2019-04-18 08:00 | 2019-04-18 09:04 | 0d |  | 1.2h |
| 37 | 34.1 | ACCESS BY AFM | manual | 8min | 2019-04-18 08:00 | 2019-04-18 08:08 |  | AFM 1 | 0.13h |
| 38 | 34.2 | GENERAL VISUAL INSPECTION BY ENG | manual | 64min | 2019-04-18 08:00 | 2019-04-18 09:04 |  | ENG | 1.07h |
| 39 | 35 | **DETAILED VISUAL INSPECTION OF COMBUSTION LINER AND DIFFUSER CASE** |  | 0.13d | 2019-04-18 08:00 | 2019-04-18 09:04 | 0d |  | 1.2h |
| 40 | 35.1 | ACCESS BY AFM | manual | 8min | 2019-04-18 08:00 | 2019-04-18 08:08 |  | AFM 1 | 0.13h |
| 41 | 35.2 | GENERAL VISUAL INSPECTION BY ENG | manual | 64min | 2019-04-18 08:00 | 2019-04-18 09:04 |  | ENG | 1.07h |
| 42 | 36 | **DETAILED VISUAL INSPECTION OF EXTERNAL PORTION OF REAR TURBINE BEARING SUPPORT FOR SECURITY AND GENERAL CONDITION** |  | 0.1d | 2019-04-18 08:00 | 2019-04-18 08:48 | 0d |  | 1.3h |
| 43 | 36.1 | ACCESS BY AFM | manual | 48min | 2019-04-18 08:00 | 2019-04-18 08:48 |  | AFM 1 | 0.8h |
| 44 | 36.2 | GENERAL VISUAL INSPECTION BY ENG | manual | 30min | 2019-04-18 08:00 | 2019-04-18 08:30 |  | ENG | 0.5h |
| 45 | 37 | **DETAILED VISUAL INSPECTION OF REAR TURBINE BEARING OIL SCAVENGE TUBE FOR ANY SIGN OF OIL LEAKAGE** |  | 0.09d | 2019-04-18 08:00 | 2019-04-18 08:42 | 0d |  | 1.2h |
| 46 | 37.1 | ACCESS BY AFM | manual | 42min | 2019-04-18 08:00 | 2019-04-18 08:42 |  | AFM 1 | 0.7h |
| 47 | 37.2 | GENERAL VISUAL INSPECTION BY ENG | manual | 30min | 2019-04-18 08:00 | 2019-04-18 08:30 |  | ENG | 0.5h |
| 48 | 38 | **GENERAL VISUAL INSPECTION OF TUBES AND HOSES ASSEMBLY FOR SECURITY AND CONDITION** |  | 0.1d | 2019-04-18 08:00 | 2019-04-18 08:47 | 0d |  | 1.45h |
| 49 | 38.1 | ACCESS BY AFM | manual | 40min | 2019-04-18 08:00 | 2019-04-18 08:40 |  | AFM 1 | 0.67h |
| 50 | 38.2 | GENERAL VISUAL INSPECTION BY ENG |  | 47min | 2019-04-18 08:00 | 2019-04-18 08:47 | 0.26d | ENG | 0.78h |
| 51 | 39 | **DETAILED VISUAL INSPECTION OF OIL SYSTEM FOR LEAKS** |  | 68min | 2019-04-18 08:00 | 2019-04-18 09:08 |  |  | 1.3h |
| 52 | 39.1 | ACCESS BY AFM | manual | 68min | 2019-04-18 08:00 | 2019-04-18 09:08 |  | AFM 1 | 1.13h |
| 53 | 39.2 | GENERAL VISUAL INSPECTION BY ENG | manual | 10min | 2019-04-18 08:00 | 2019-04-18 08:10 |  | ENG | 0.17h |
| 54 | 40 | DETAILED VISUAL INSPECTION OF OIL SYSTEM FOR LEAKS | manual | 10min | 2019-04-18 08:00 | 2019-04-18 08:10 |  | AFM 1 | 0.17h |
| 55 | 41 | FUNCTIONAL CHECK OF PRESSURIZATION SYSTEM FOR: A.OVERPRESSURE B.NEGATIVE PRESSURE | manual | 63min | 2019-04-18 08:00 | 2019-04-18 09:03 |  | AFM 1 | 1.05h |
| 56 | 42 | FUNCTIONAL CHECK OF OVERBOARD VALVE | manual | 6min | 2019-04-18 08:00 | 2019-04-18 08:06 |  | AFM 1 | 0.1h |
| 57 | 43 | OPERATIONAL CHECK TO VERIFY AUTOMATIC DRAIN VALVES (ADV) FAILURE | manual | 72min | 2019-04-18 08:00 | 2019-04-18 09:12 |  | AFM 1 | 1.2h |
| 58 | 44 | FUNCTIONAL CHECK OF VISUAL ICE DETECTOR | manual | 5min | 2019-04-18 08:00 | 2019-04-18 08:05 |  | AFM 1 | 0.08h |
| 59 | 45 | FUNCTIONAL CHECK OF ENGINE AND PROPELLER ANTI-ICE SYSTEMS | manual | 10min | 2019-04-18 08:00 | 2019-04-18 08:10 |  | AFM 1 | 0.17h |
| 60 | 46 | OPERATIONAL CHECK OF POSITION LIGHT SYSTEM | manual | 1min | 2019-04-18 08:00 | 2019-04-18 08:01 |  | AFM 1 | 0.02h |
| 61 | 47 | OPERATIONAL CHECK OF FUEL PUMP WORKING | manual | 15min | 2019-04-18 08:00 | 2019-04-18 08:15 |  | AFM 1 | 0.25h |
| 62 | 48 | OPERATIONAL CHECK TO VERIFY TANK FULL AUTOMATIC REFUEL CUT-OFF | manual | 16min | 2019-04-18 08:00 | 2019-04-18 08:16 |  | AFM 1 | 0.27h |
| 63 | 49 | DETAILED VISUAL INSPECTION OF VENT LINE FOR DAMAGE, CRACKS AND OBSTRUCTION | manual | 7.2min | 2019-04-18 08:00 | 2019-04-18 08:07 |  | AFM 1 | 0.12h |
| 64 | 50 | DETAILED VISUAL INSPECTION OF DISTRIBUTION DUCT FOR CORROSION, DAMAGE AND CRACKS. | manual | 7.2min | 2019-04-18 08:00 | 2019-04-18 08:07 |  | AFM 1 | 0.12h |
| 65 | 51 | DETAILED VISUAL INSPECTION OF MASK AND RELATED HOSE FOR CORROSION, DAMAGE AND CRACKS | manual | 5min | 2019-04-18 08:00 | 2019-04-18 08:05 |  | AFM 1 | 0.08h |
| 66 | 52 | DETAILED VISUAL INSPECTION OF SMOKE GOGGLES FOR CORROSION AND GENERAL DAMAGE | manual | 5min | 2019-04-18 08:00 | 2019-04-18 08:05 |  | AFM 1 | 0.08h |
| 67 | 53 | DETAILED VISUAL INSPECTION OF DUCT CONNECTED TO THE CONVERTER FOR CORROSION, DAMAGE AND CRACKS | manual | 7.3min | 2019-04-18 08:00 | 2019-04-18 08:07 |  | AFM 1 | 0.12h |
| 68 | 54 | DETAILED VISUAL INSPECTION OF SERVOMOTORS DRUM AND BRACKETS FOR PRESENCE OF CORROSION, CRACKS, DETERIORATION AND GENERAL CONDITIONS | manual | 48min | 2019-04-18 08:00 | 2019-04-18 08:48 |  | AFM 1 | 0.8h |
| 69 | 55 | FUNCTIONAL CHECK OF CARGO SMOKE DETECTORS FOR PROPER FUNCTION | manual | 10min | 2019-04-18 08:00 | 2019-04-18 08:10 |  | AFM 1 | 0.17h |
| 70 | 56 | FUNCTIONAL CHECK OF LAVATORY SMOKE DETECTOR FOR PROPER FUNCTION | manual | 1min | 2019-04-18 08:00 | 2019-04-18 08:01 |  | AFM 1 | 0.02h |
| 71 | 57 | CLEANING OF SMOKE DETECTORS | manual | 60min | 2019-04-18 08:00 | 2019-04-18 09:00 |  | AFM 1 | 1h |
| 72 | 58 | OPERATIONAL CHECK OF APU REMOTE FIRE EXTINGUISH SWITCH AND ASSOCIATED CIRCUIT | manual | 42min | 2019-04-18 08:00 | 2019-04-18 08:42 |  | AFM 1 | 0.7h |
| 73 | 59 | OPERATIONAL CHECK OF APU T-HANDLE AND FIRE EXTINGUISHER CIRCUIT FOR PROPER FUNCTION | manual | 41min | 2019-04-18 08:00 | 2019-04-18 08:41 |  | AFM 1 | 0.68h |
