# 5-10 HS2

Schedule from MS Project, 2019-04-18 to 2019-04-19, 7 hours a day.

## Calendars

- Standard: Mon-Fri 08:00-12:00, 13:00-17:00; Sat-Sun off.

## Resources

| Resource |
| --- |
| AFM 1 |
| AFM 2 |
| OXY |
| ELC |

## Schedule

| ID | Task | Type | Duration | Start | Finish | Predecessors | Total slack | Resources | Work |
| --- | --- | --- | --- | --- | --- | --- | --- | --- | --- |
| 1 | GENERAL VISUAL INSPECTION OF COCKPIT (FR1 TO FR 7) A.AVIONICS DAMPING SUPPORT B.CREW SEAT BELT/OBSERVER SEAT BELTS AND ASSOCIATED MECHANISM C.PARKING/EMERGENCY BRAKE SYSTEM | manual | 71.2min | 2019-04-18 08:00 | 2019-04-18 09:11 |  |  | AFM 1 | 1.19h |
| 2 | GENERAL VISUAL INSPECTION OF CREW ENTRANCE (FR 7 TO FR 98) | manual | 60min | 2019-04-18 09:11 | 2019-04-18 10:11 | 1 |  | AFM 1 | 1h |
| 3 | GENERAL VISUAL INSPECTION OF CARGO COMPT. (FR 9B TO FR 16) | manual | 105min | 2019-04-18 10:11 | 2019-04-18 11:56 | 2 |  | AFM 1 | 1.75h |
| 4 | GENERAL VISUAL INSPECTION OF CARGO COMPT. (FR 16 TO FR 23) | manual | 80min | 2019-04-18 11:56 | 2019-04-18 14:16 | 3 |  | AFM 1 | 1.33h |
| 5 | GENERAL VISUAL INSPECTION OF CARGO COMPT. (FR 23 TO FR 26) | manual | 73min | 2019-04-18 14:16 | 2019-04-18 15:29 | 4 |  | AFM 1 | 1.22h |
| 6 | GENERAL VISUAL INSPECTION OF AFT FUSELAGE SECTION (FR 29 TO FR 47) | manual | 100min | 2019-04-18 15:29 | 2019-04-19 08:09 | 5 |  | AFM 1 | 1.67h |
| 7 | DETAILED VISUAL INSPECTION OF ELEVATOR JAM OVERRIDE MECHANISM (JOM) FOR CONDITION | manual | 5min | 2019-04-19 08:09 | 2019-04-19 08:14 | 6 |  | AFM 1 | 0.08h |
| 8 | GENERAL VISUAL INSPECTION OF STATIC SYSTEM NORMAL BREAKING FOR CORRECT OIL LEVEL AND LEAKAGE | manual | 18min | 2019-04-19 08:14 | 2019-04-19 08:32 | 7 |  | AFM 1 | 0.3h |
| 9 | CHECK OF AILERONS CABLE FOR CORRECT TENSION INCLUDED THE AUTOPILOT ACTUATOR CABLE | manual | 109min | 2019-04-19 08:32 | 2019-04-19 10:21 | 8 |  | AFM 1 | 1.82h |
| 10 | CHECK OF TRIM-TAB AILERON TRAVEL | manual | 9min | 2019-04-19 10:21 | 2019-04-19 10:30 | 9, 35 |  | AFM 1 | 0.15h |
| 11 | FUNCTIONAL CHECK OF RUDDER CENTERING SPRING IN ORDER TO VERIFY THE RETURN TO "0" POSITION WITHOUT PILOT LINK | manual | 9min | 2019-04-19 10:30 | 2019-04-19 10:39 | 10 |  | AFM 1 | 0.15h |
| 12 | FUNCTIONAL CHECK OF RUDDER TRAVEL LIMITATION UNIT (RTLU) SYSTEM, RELATIVE WARNING AND OVERRIDE SWITCH FOR CORRECT OPERATION | manual | 41min | 2019-04-19 10:39 | 2019-04-19 11:20 | 11 |  | AFM 1 | 0.68h |
| 13 | OPERATIONAL CHECK OF TRIM-RUDDER EMERGENCY FUNCTION | manual | 13min | 2019-04-19 11:20 | 2019-04-19 11:33 | 12 |  | AFM 1 | 0.22h |
| 14 | FUNCTIONAL CHECK OF FLAP ASYMMETRY CONTROL SYSTEM | manual | 24.3min | 2019-04-19 11:33 | 2019-04-19 11:57 | 13 |  | AFM 1 | 0.41h |
| 15 | FUNCTIONAL CHECK OF FLAP FROM HYDRAULIC SYSTEM No1 & No2 | manual | 7min | 2019-04-19 11:57 | 2019-04-19 13:04 | 14 |  | AFM 1 | 0.12h |
| 16 | FUNCTIONAL CHECK OF FLAP POSITION INDICATOR | manual | 41min | 2019-04-19 13:04 | 2019-04-19 13:45 | 15 |  | AFM 1 | 0.68h |
| 17 | OPERATIONAL CHECK OF COCKPIT PRIORITY VALVE | manual | 8min | 2019-04-19 13:45 | 2019-04-19 13:53 | 16 |  | AFM 1 | 0.13h |
| 18 | OPERATIONAL CHECK OF RAM AIR EMERGENCY VENTILATION VALVE | manual | 4min | 2019-04-19 13:53 | 2019-04-19 13:57 | 17 |  | AFM 1 | 0.07h |
| 19 | FUNCTIONAL CHECK OF HEATING ELEMENT OF PROBE TOTAL AIR TEMPERATURE (TAT) | manual | 6min | 2019-04-19 13:57 | 2019-04-19 14:03 | 18 |  | AFM 1 | 0.1h |
| 20 | OPERATIONAL CHECK OF TRIANGULAR WINDOWS AND SLIDING WINDOW HEATING | manual | 9min | 2019-04-19 14:03 | 2019-04-19 14:12 | 19 |  | AFM 1 | 0.15h |
| 21 | OPERATIONAL CHECK OF HYDRAULIC SYSTEM No1 & No2 SHUT-OFF VALVE | manual | 14min | 2019-04-19 14:12 | 2019-04-19 14:26 | 20 |  | AFM 1 | 0.23h |
| 22 | FUNCTIONAL CHECK OF JETTISON SYSTEM | manual | 16min | 2019-04-19 14:26 | 2019-04-19 14:42 | 21 |  | AFM 1 | 0.27h |
| 23 | OPERATIONAL CHECK OF STALL WARNING STICK SHACKER (SWS) SYSTEM FOR CORRECT FUNCTION | manual | 5min | 2019-04-19 14:42 | 2019-04-19 14:47 | 22 |  | AFM 1 | 0.08h |
| 24 | FUNCTIONAL CHECK OF: A.GND / AIR RELAY OF PITOT PROBES B.CURRENT SENSOR INDICATING (PITOT, AOA) | manual | 7min | 2019-04-19 14:47 | 2019-04-19 14:54 | 23 |  | AFM 1 | 0.12h |
| 25 | GENERAL VISUAL INSPECTION OF ENGINE NACELLES FWD SECTION | manual | 83min | 2019-04-18 08:00 | 2019-04-18 09:23 |  |  | AFM 2 | 1.38h |
| 26 | DRAINING OF HYDRAULIC FLUID FOR SAMPLING PROSEDURE (SOAP) | manual | 188min | 2019-04-18 09:23 | 2019-04-18 13:31 | 25 |  | AFM 2 | 3.13h |
| 27 | DETAILED VISUAL INSPECTION OF FIREWALL SEAL FOR CONDITION AND SECURITY | manual | 55min | 2019-04-18 13:31 | 2019-04-18 14:26 | 26 |  | AFM 2 | 0.92h |
| 28 | FUNCTIONAL CHECK OF V-BAND CLAMP BOLT TORQUE | manual | 32min | 2019-04-18 14:26 | 2019-04-18 14:58 | 27 |  | AFM 2 | 0.53h |
| 29 | DETAILED VISUAL INSPECTION FOR CORRECT PRE-CHARGE VALUE OF EMERGENCY BRAKE ACCUMULATOR | manual | 6min | 2019-04-18 14:58 | 2019-04-18 15:04 | 28 |  | AFM 2 | 0.1h |
| 30 | A DETAILED VISUAL INSPECTION OF APU MOUNT FOR CORROSION AND WEAR B.AP.U. SHOCK ABSORBER DIMENSIONAL CHECK. | manual | 103min | 2019-04-18 15:04 | 2019-04-18 16:47 | 29 |  | AFM 2 | 1.72h |
| 31 | DETAILED VISUAL INSPECTION OF APU INLET DOOR | manual | 47min | 2019-04-18 16:47 | 2019-04-19 08:34 | 30 |  | AFM 2 | 0.78h |
| 32 | DETAILED VISUAL INSPECTION OF AIR INLET SCREEN FOR OBSTRUCTION AND DAMAGE | manual | 1min | 2019-04-19 08:34 | 2019-04-19 08:35 | 31 |  | AFM 2 | 0.02h |
| 33 | DETAILED VISUAL INSPECTION OF APU FILTER DISASSEMBLED FOR CONDITION AND OBSTRUCTION | manual | 31min | 2019-04-19 08:35 | 2019-04-19 09:06 | 32 |  | AFM 2 | 0.52h |
| 34 | CHECK OF ELEVATOR HYDRAULIC ACCUMULATOR SHUT-OFF VALVE | manual | 7min | 2019-04-19 09:06 | 2019-04-19 09:13 | 33 |  | AFM 2 | 0.12h |
| 35 | FUNCTIONAL TEST OF ELEVATOR JAM OVERRIDE MECHANISM (JAM) FOR PROPER FUNCTION | manual | 11.3min | 2019-04-19 09:13 | 2019-04-19 09:24 | 34 |  | AFM 2 | 0.19h |
| 36 | FUNCTIONAL CHECK OF CARGO OXYGEN SYSTEM FOR PROPER FUNCTION | manual | 32.2min | 2019-04-19 14:54 | 2019-04-19 15:26 | 24 |  | OXY | 0.54h |
| 37 | FUNCTIONAL TEST OF STBY TRANSFORMER RECTIFIER UNITS (TRU) SUPPLY CHECK |  | 5min | 2019-04-19 15:26 | 2019-04-19 15:31 | 36 | 0d | ELC | 0.08h |
| 38 | OPERATIONAL CHECK OF OVRD FUNCTION |  | 1min | 2019-04-19 15:31 | 2019-04-19 15:32 | 37 | 0d | ELC | 0.02h |
| 39 | OPERATIONAL CHECK OF BUS TIE CONTACTOR (BTC) |  | 1min | 2019-04-19 15:32 | 2019-04-19 15:33 | 38 | 0d | ELC | 0.02h |
