# 5-13 A1

Schedule from MS Project, 2019-04-18 to 2019-04-24, 7 hours a day.

## Calendars

- Standard: Mon-Fri 08:00-12:00, 13:00-17:00; Sat-Sun off.

## Resources

| Resource |
| --- |
| AFM 1 |
| AFM 2 |
| ENG 1 |
| AVI |

## Schedule

| ID | Task | Type | Duration | Start | Finish | Predecessors | Resources | Work |
| --- | --- | --- | --- | --- | --- | --- | --- | --- |
| 1 | GENERAL VISUAL INSPECTION OF CARGO COMPARTMENT UNDERFLOOR (FRAME 7 TO FRAME 29) | manual | 65min | 2019-04-18 08:00 | 2019-04-18 09:05 |  | AFM 1 | 1.08h |
| 2 | DETAILED VISUAL INSPECTION FOR DELAMINATION, CRACK AND CRAZING OF CARGO COMPARTMENT WINDOWS | manual | 15min | 2019-04-18 09:05 | 2019-04-18 09:20 | 1 | AFM 1 | 0.25h |
| 3 | DETAIL VISUAL INSPECTION OF CARGO COMPARTMENT EMERGENCY EQUIPMENT FOR CONDITION | manual | 7min | 2019-04-18 09:20 | 2019-04-18 09:27 | 2 | AFM 1 | 0.12h |
| 4 | DETAILED VISUAL INSPECTION FOR CORROSION AND CONDITION ON TELESCOPIC ROD OF THE FLAPS AIRFOIL UNDERSIDE DOORS AND RELATIVE ATTACHMENTS | manual | 2min | 2019-04-18 09:27 | 2019-04-18 09:29 | 3 | AFM 1 | 0.03h |
| 5 | DETAILED VISUAL INSPECTION OF WATER TANK FOR CRACKS/CUTS CHAFFING | manual | 30min | 2019-04-18 09:29 | 2019-04-18 09:59 | 4 | AFM 1 | 0.5h |
| 6 | DETAIL VISUAL INSPECTION OF CARGO COMPARTMENT EMERGENCY EQUIPMENT FOR CONDITION | manual | 5min | 2019-04-18 09:59 | 2019-04-18 10:04 | 5 | AFM 1 | 0.08h |
| 7 | LUBRICATION OF LIFE RAFT BAY DOOR HINGE | manual | 15min | 2019-04-18 10:04 | 2019-04-18 10:19 | 6 | AFM 1 | 0.25h |
| 8 | LUBRICATION HINGES, LATCHES AND COMPENSATION MECHANISM OF CREW DOOR | manual | 16min | 2019-04-18 10:19 | 2019-04-18 10:35 | 7 | AFM 1 | 0.27h |
| 9 | DETAILED VISUAL INSPECTION FOR DELAMINATION, CRACK AND CRAZING OF CARGO COMPARTMENT WINDOWS | manual | 6min | 2019-04-18 10:35 | 2019-04-18 10:41 | 8, 43 | AFM 1 | 0.1h |
| 10 | GENERAL VISUAL INSPECTION OF CARGO COMPARTMENT (FRAME 26 TO FRAME 29) | manual | 147min | 2019-04-18 10:41 | 2019-04-18 14:08 | 9 | AFM 1 | 2.45h |
| 11 | GENERAL VISUAL INSPECTION OF VERTICAL EMPENNAGE (RUDDER & FIN) | manual | 25min | 2019-04-18 14:08 | 2019-04-18 14:33 | 10 | AFM 1 | 0.42h |
| 12 | GENERAL VISUAL INSPECTION OF (LH) MAIN LANDING GEAR NACELLE COMPARTMENT AND HYDRAULIC SYSTEM COMPONENTS | manual | 15min | 2019-04-18 14:33 | 2019-04-18 14:48 | 11 | AFM 1 | 0.25h |
| 13 | GENERAL VISUAL INSPECTION OF (LH) HORIZONTAL EMPENNAGE (STABILIZER & ELEVATOR) | manual | 94min | 2019-04-18 14:48 | 2019-04-18 16:22 | 12 | AFM 1 | 1.57h |
| 14 | GENERAL VISUAL INSPECTION OF (RH) HORIZONTAL EMPENNAGE (STABILIZER & ELEVATOR) | manual | 85min | 2019-04-18 16:22 | 2019-04-19 08:47 | 13 | AFM 1 | 1.42h |
| 15 | GENERAL VISUAL INSPECTION OF (LH) WING LEADING EDGE | manual | 85min | 2019-04-19 08:47 | 2019-04-19 10:12 | 14 | AFM 1 | 1.42h |
| 16 | LUBRICATION OF SIDE EMERGENCY EXIT DOOR MECHANISM | manual | 81min | 2019-04-19 10:12 | 2019-04-19 11:33 | 15 | AFM 1 | 1.35h |
| 17 | LUBRICATION OF EMERGENCY EXIT HATCHES MECHANISM | manual | 34min | 2019-04-19 11:33 | 2019-04-19 13:07 | 16 | AFM 1 | 0.57h |
| 18 | LUBRICATION OF CARGO DOOR HINGES, DOWNLOCKING HOOKS, UPLOCKING HOOK AND FIXED HOOKS | manual | 72min | 2019-04-19 13:07 | 2019-04-19 14:19 | 17 | AFM 1 | 1.2h |
| 19 | DETAILED VISUAL INSPECTION FOR CORROSION OF FUSELAGE CENTER SECTION BEAM BETWEEN FRAMES 20-22 | manual | 105min | 2019-04-19 14:19 | 2019-04-19 16:04 | 18 | AFM 1 | 1.75h |
| 20 | LUBRICATION OF REAR LATERAL DOORS MECHANISM | manual | 30min | 2019-04-19 16:04 | 2019-04-19 16:34 | 19 | AFM 1 | 0.5h |
| 21 | LUBRICATION ARTICULATED JOINTS OF RAMP AND CARGO DOOR | manual | 229min | 2019-04-19 16:34 | 2019-04-22 11:23 | 20 | AFM 1 | 3.82h |
| 22 | LUBRICATION OF RAMP LOCKING HOOKS MECHANISM, HINGES, RETAINING RODS AND SLIDERS | manual | 20min | 2019-04-22 11:23 | 2019-04-22 11:43 | 21 | AFM 1 | 0.33h |
| 23 | GENERAL VISUAL INSPECTION OF CARGO DOOR, STORAGE FITTINGS, SEAL AND HINGES | manual | 11.3min | 2019-04-22 11:43 | 2019-04-22 11:54 | 22 | AFM 1 | 0.19h |
| 24 | GENERAL VISUAL INSPECTION OF (LH) WING BOX | manual | 217min | 2019-04-18 08:00 | 2019-04-18 11:37 |  | AFM 2 | 3.62h |
| 25 | GENERAL VISUAL INSPECTION OF (LH) TRAILING EDGE AND AFT SPAR | manual | 151min | 2019-04-18 11:37 | 2019-04-18 15:08 | 24 | AFM 2 | 2.52h |
| 26 | GENERAL VISUAL INSPECTION OF (LH) CENTER WING SECTION AND FAIRING | manual | 42min | 2019-04-18 15:08 | 2019-04-18 15:50 | 25 | AFM 2 | 0.7h |
| 27 | GENERAL VISUAL INSPECTION OF (LH) AILERON AND FLAPS (INTERNAL AND EXTERNAL SIDE) | manual | 24.3min | 2019-04-18 15:50 | 2019-04-18 16:14 | 26 | AFM 2 | 0.41h |
| 28 | GENERAL VISUAL INSPECTION OF (RH) AILERON AND FLAPS (INTERNAL AND EXTERNAL SIDE) | manual | 24.3min | 2019-04-18 16:14 | 2019-04-18 16:38 | 27 | AFM 2 | 0.41h |
| 29 | LUBRICATION OF SEAT TRACK | manual | 39min | 2019-04-18 16:38 | 2019-04-19 08:17 | 28 | AFM 2 | 0.65h |
| 30 | GENERAL VISUAL INSPECTION OF (RH) TRAILING EDGE AND AFT SPAR | manual | 151min | 2019-04-19 08:17 | 2019-04-19 10:48 | 29 | AFM 2 | 2.52h |
| 31 | GENERAL VISUAL INSPECTION OF NOSE LANDING GEAR | manual | 42min | 2019-04-19 10:48 | 2019-04-19 11:30 | 30 | AFM 2 | 0.7h |
| 32 | GENERAL VISUAL INSPECTION OF (RH) WING BOX | manual | 217min | 2019-04-19 11:30 | 2019-04-19 16:07 | 31 | AFM 2 | 3.62h |
| 33 | GENERAL VISUAL INSPECTION OF (RH) MAIN LANDING GEAR NACELLE COMPARTMENT AND HYDRAULIC SYSTEM COMPONENTS | manual | 134min | 2019-04-19 16:07 | 2019-04-22 09:21 | 32 | AFM 2 | 2.23h |
| 34 | LUBRICATION OF LAVATORY DOOR MECHANICAL GUIDE | manual | 114min | 2019-04-22 09:21 | 2019-04-22 11:15 | 33 | AFM 2 | 1.9h |
| 35 | FUNCTIONAL CHECK OF APU NOZZLE DUCT ALIGNMENT | manual | 82min | 2019-04-22 11:15 | 2019-04-22 13:37 | 34 | AFM 2 | 1.37h |
| 36 | DETAILED VISUAL INSPECTION OF EXHAUST DUCT FOR CORROSION, CRACK AND CONDITION | manual | 5min | 2019-04-22 13:37 | 2019-04-22 13:42 | 35 | AFM 2 | 0.08h |
| 37 | DETAILED VISUAL INSPECTION FOR CRAZING AND DELAMINATION OF CABIN WINDOWS | manual | 40min | 2019-04-22 13:42 | 2019-04-22 14:22 | 36 | AFM 2 | 0.67h |
| 38 | DETAILED VISUAL INSPECTION FOR CONDITION OF AILERON TAB CONTROL FAIL SAFE LINKAGE | manual | 10min | 2019-04-22 14:22 | 2019-04-22 14:32 | 37 | AFM 2 | 0.17h |
| 39 | GENERAL VISUAL INSPECTION OF (RH) WING LEADING EDGE | manual | 226min | 2019-04-22 14:32 | 2019-04-23 09:18 | 38, 23 | AFM 2 | 3.77h |
| 40 | LUBRICATION THE HINGE OF BATTERY COMPARTMENT ACCESS | manual | 29min | 2019-04-23 09:18 | 2019-04-23 09:47 | 39 | AFM 2 | 0.48h |
| 41 | FUNCTIONAL CHECK OF APU NOZZLE DUCT ALIGNMENT | manual | 15min | 2019-04-23 10:55 | 2019-04-23 11:10 | 40, 45 | ENG 1 | 0.25h |
| 42 | FUNCTIONAL CHECK OF IFF SYSTEM | manual | 15min | 2019-04-23 11:10 | 2019-04-23 11:25 | 41 | AVI | 0.25h |
| 43 | BONDING TEST OF HF ANTENNAS FOR THEIR CORRECT INSULATION | manual | 30min | 2019-04-18 08:00 | 2019-04-18 08:30 |  | AVI | 0.5h |
| 44 | CLEANING OF STAND-BY PITOT AND STATIC PLUMBING | manual | 60min | 2019-04-22 11:54 | 2019-04-22 13:54 | 23 | AVI | 1h |
| 45 | CLEANING OF PITOT AND STATIC PLUMBING | manual | 361min | 2019-04-22 13:54 | 2019-04-23 10:55 | 44 | AVI | 6.02h |
| 46 | FUNCTIONAL CHECK OF DISTRIBUTED AIR DATA SYSTEM (DADS) | manual | 120min | 2019-04-23 11:25 | 2019-04-23 14:25 | 42 | AVI | 2h |
| 47 | DETAILED VISUAL INSPECTION OF COCKPIT EMERGENCY EQUIPMENT FOR CONDITION | manual | 240min | 2019-04-23 14:25 | 2019-04-24 09:25 | 46 | AVI | 4h |
