# 5-15 A3

Schedule from MS Project, 2019-04-18 to 2019-05-01, 7 hours a day.

## Calendars

- Standard: Mon-Fri 08:00-12:00, 13:00-17:00; Sat-Sun off.

## Resources

| Resource |
| --- |
| AFM 1 |
| ENG |
| NDI |

## Schedule

| ID | WBS | Task | Type | Duration | Start | Finish | Total slack | Resources | Work |
| --- | --- | --- | --- | --- | --- | --- | --- | --- | --- |
| 1 | 1 | DETAILED VISUAL INSPECTION FOR CRACK OF CARGO RAMP-HOOKS THRESHOLD:3000FL | manual | 85min | 2019-04-18 08:00 | 2019-04-18 09:25 |  | AFM 1 | 1.42h |
| 2 | 2 | DETAILED VISUAL INSPECTION FOR CRACK OF FUSELAGE CENTER SECTION FRAME-29, UPPER AND LOWER ATTACH SPAR (LH/RH) THRESHOLD:750FL | manual | 20min | 2019-04-18 08:00 | 2019-04-18 08:20 |  | AFM 1 | 0.33h |
| 3 | 3 | DETAILED VISUAL INSPECTION FOR CRACK OF FUSELAGE REAR SECTION FRAME 42-44 ATTACHMENT TO HORIZONTAL STABILIZER (LH/RH) THRESHOLD:3000FL | manual | 200min | 2019-04-18 08:00 | 2019-04-18 11:20 |  | AFM 1 | 3.33h |
| 4 | 4 | **NON DESTRUCTIVE INSPECTION OF FWD FRAME ENGINE NACELLE (LH/RH) FOR CRACK THRESHOLD:7500FL** |  | 11d | 2019-04-18 08:00 | 2019-05-01 14:00 | 0d | AFM 1 | 163.42h |
| 5 | 4.1 | ACCESS: 413A, 413B, 413C, 413D, 413E, 413F, 413G, 413H, 413J, 413K, 414A, 414B, 414C, 414D, 414E, 414F, 414G, 414H, 414J, 423A,423B, 423C, 423D, 423E, 423F, 423G, 423H, 423J, 423K, 424A, 424B ,424C, 424D, 424E, 424F, 424G, 424H, 424J | manual | 520min | 2019-04-18 08:00 | 2019-04-19 08:40 |  | AFM 1 | 8.67h |
| 6 | 4.2 | REMOVE ENGINES AND PROPELLERS | manual | 4620min | 2019-04-18 08:00 | 2019-05-01 14:00 |  | ENG | 77h |
| 7 | 4.3 | NON DESTRUCTIVE INSPECTION | manual | 45min | 2019-04-18 08:00 | 2019-04-18 08:45 |  | NDI | 0.75h |
| 8 | 5 | NON DESTRUCTIVE INSPECTION FOR CRACK OF FWD FRAME, LOWER LEFT AND RIGHT, LUG-ENGINE NACELLE (LH/RH) THRESHOLD:7500FL | manual | 1d | 2019-04-18 08:00 | 2019-04-18 16:00 |  |  |  |
| 9 | 6 | ACCESS: 413A, 413B, 413C, 413D, 413K,, 423A,423B, 423C, 423D, 423K, | manual | 92min | 2019-04-18 08:00 | 2019-04-18 09:32 |  | AFM 1 | 1.53h |
| 10 | 7 | NON DESTRUCTIVE INSPECTION | manual | 20min | 2019-04-18 08:00 | 2019-04-18 08:20 |  | NDI | 0.33h |
| 11 | 8 | **NON DESTRUCTIVE INSPECTION FOR CRACKS OF STRUTS, FWD-MID FRAME ENGINE NACELLE (LH/RH) THRESHOLD:7500FL** |  | 11d | 2019-04-18 08:00 | 2019-05-01 14:00 | 0d |  | 86.42h |
| 12 | 8.1 | ACCESS: 413A, 413B, 413C, 413D, 413E, 413F, 413G, 413H, 413J, 413K, 414A, 414B, 414C, 414D, 414E, 414F, 414G, 414H, 414J, 423A,423B, 423C, 423D, 423E, 423F, 423G, 423H, 423J, 423K, 424A, 424B ,424C, 424D, 424E, 424F, 424G, 424H, 424J | manual | 520min | 2019-04-18 08:00 | 2019-04-19 08:40 |  | AFM 1 | 8.67h |
| 13 | 8.2 | REMOVE ENGINES AND PROPELLERS | manual | 4620min | 2019-04-18 08:00 | 2019-05-01 14:00 |  | ENG | 77h |
| 14 | 8.3 | NON DESTRUCTIVE INSPECTION | manual | 45min | 2019-04-18 08:00 | 2019-04-18 08:45 |  | NDI | 0.75h |
| 15 | 9 | **NON DESTRUCTIVE INSPECTION FOR CRACK OF STRUTS MID-AFT FRAMES THRESHOLD:7500FL** |  | 11d | 2019-04-18 08:00 | 2019-05-01 14:00 | 0d |  | 88.07h |
| 16 | 9.1 | ACCESS: 413A, 413B, 413C, 413D, 413E, 413F, 413G, 413H, 413J, 413K, 414A, 414B, 414C, 414D, 414E, 414F, 414G, 414H, 414J, 423A,423B, 423C, 423D, 423E, 423F, 423G, 423H, 423J, 423K, 424A, 424B ,424C, 424D, 424E, 424F, 424G, 424H, 424J | manual | 520min | 2019-04-18 08:00 | 2019-04-19 08:40 |  | AFM 1 | 8.67h |
| 17 | 9.2 | REMOVE ENGINES AND PROPELLERS | manual | 4620min | 2019-04-18 08:00 | 2019-05-01 14:00 |  | ENG | 77h |
| 18 | 9.3 | NON DESTRUCTIVE INSPECTION | manual | 144min | 2019-04-18 08:00 | 2019-04-18 10:24 |  | NDI | 2.4h |
| 19 | 10 | **NON DESTRUCTIVE INSPECTION FOR CRACK OF NACELLE LOWER COWL ASSEMBLY (LOWER COWL STRUT) THRESHOLD:7500FL** |  | 0.07d | 2019-04-18 08:00 | 2019-04-18 08:30 | 0d |  | 0.83h |
| 20 | 10.1 | ACCESS: 413K, 423K | manual | 20min | 2019-04-18 08:00 | 2019-04-18 08:20 |  | AFM 1 | 0.33h |
| 21 | 10.2 | NON DESTRUCTIVE INSPECTION | manual | 30min | 2019-04-18 08:00 | 2019-04-18 08:30 |  | NDI | 0.5h |
| 22 | 11 | **NON DESTRUCTIVE INSPECTION FOR CRACK OF AFT FRAME, ENGINE NACELLE (LH/RH) THRESHOLD:7500FL** |  | 0.1d | 2019-04-18 08:00 | 2019-04-18 08:40 | 0d |  | 1h |
| 23 | 11.1 | ACCESS: 413K, 423K | manual | 20min | 2019-04-18 08:00 | 2019-04-18 08:20 |  | AFM 1 | 0.33h |
| 24 | 11.2 | NON DESTRUCTIVE INSPECTION | manual | 40min | 2019-04-18 08:00 | 2019-04-18 08:40 |  | NDI | 0.67h |
| 25 | 12 | DETAILED VISUAL INSPECTION FOR CRACK OF MIDDLE FRAME AND STRUT, ENGINE NACELLE (LH/RH) THRESHOLD:7500FL | manual | 40min | 2019-04-18 08:00 | 2019-04-18 08:40 |  | AFM 1 | 0.67h |
| 26 | 13 | DETAILED VISUAL INSPECTION FOR CRACK OF FWD FRAME, ENGINE NACELLE (LH/RH) THRESHOLD:7500FL | manual | 40min | 2019-04-18 08:00 | 2019-04-18 08:40 |  | AFM 1 | 0.67h |

| ID | WBS | Task | Type | Duration | Start | Finish | Resources | Work |
| --- | --- | --- | --- | --- | --- | --- | --- | --- |
| 27 | 14 | **NON DESTRUCTIVE INSPECTION FOR CRACK OF NACELLE STRUTS (AFT FRAME TO WING) THRESHOLD:7500FL** |  | 30min | 2019-04-18 08:00 | 2019-04-18 08:30 |  | 86.47h |
| 28 | 14.1 | ACCESS: 413A, 413B, 413C, 413D, 413E, 413F, 413G, 413H, 413J, 413K, 414A, 414B, 414C, 414D, 414E, 414F, 414G, 414H, 414J, 423A,423B, 423C, 423D, 423E, 423F, 423G, 423H, 423J, 423K, 424A, 424B ,424C, 424D, 424E, 424F, 424G, 424H, 424J | manual | 520min | 2019-04-18 08:00 | 2019-04-19 08:40 | AFM 1 | 8.67h |
| 29 | 14.2 | REMOVE ENGINES AND PROPELLERS | manual | 4620min | 2019-04-18 08:00 | 2019-05-01 14:00 | ENG | 77h |
| 30 | 14.3 | NON DESTRUCTIVE INSPECTION | manual | 48min | 2019-04-18 08:00 | 2019-04-18 08:48 | NDI | 0.8h |
| 31 | 15 | DETAILED VISUAL INSPECTION FOR CRACK OF HORIZONTAL STABILIZER-FITTINGS HORIZONTAL STABILIZER / ELEVATOR (LH/RH) THRESHOLD:7500FL | manual | 158min | 2019-04-18 08:00 | 2019-04-18 10:38 | AFM 1 | 2.63h |
| 32 | 16 | DETAILED VISUAL INSPECTION FOR CRACK OF ELEVATOR-FITTINGS ELEVATOR / HORIZONTAL STABILIZER (LH/RH)THRESHOLD:7500FL | manual | 158min | 2019-04-18 08:00 | 2019-04-18 10:38 | AFM 1 | 2.63h |
| 33 | 17 | DETAILED VISUAL INSPECTION FOR CRACKS OF CENTER WING-WING / FUSELAGE ATTACHMENT FITTING AT RIB 2 (LH/RH) THRESHOLD:3000FL | manual | 182min | 2019-04-18 08:00 | 2019-04-18 11:02 | AFM 1 | 3.03h |
| 34 | 18 | DETAILED VISUAL INSPECTION FOR CRACK OF CENTER WING-WING / FUSELAGE ATTACHMENT FITTING AT RIB 3 (LH/RH) THRESHOLD:3000FL | manual | 182min | 2019-04-18 08:00 | 2019-04-18 11:02 | AFM 1 | 3.03h |
| 35 | 19 | DETAILED VISUAL INSPECTION FOR CRACK OF CENTER WING-NACELLE ATTACH AT RIB 13-FWD LOWER BACKUP FITTING (LH/RH) THRESHOLD:7500FL | manual | 210min | 2019-04-18 08:00 | 2019-04-18 11:30 | AFM 1 | 3.5h |
| 36 | 20 | DETAILED VISUAL INSPECTION FOR CRACK OF CENTER WING-UPPER SURFACE DOOR CUT-OUT THRESHOLD:3000FL | manual | 40min | 2019-04-18 08:00 | 2019-04-18 08:40 | AFM 1 | 0.67h |
| 37 | 21 | DETAILED VISUAL INSPECTION FOR CRACK OF OUTER WING-UPPER SKIN DOOR CUT-OUT (LH/RH) THRESHOLD:3000FL | manual | 60min | 2019-04-18 08:00 | 2019-04-18 09:00 | AFM 1 | 1h |
| 38 | 22 | DETAILED VISUAL INSPECTION FOR CRACK OF OUTER WING-FLAP TRACK (LH/RH) THRESHOLD:6000FL | manual | 26min | 2019-04-18 08:00 | 2019-04-18 08:26 | AFM 1 | 0.43h |
| 39 | 23 | DETAILED VISUAL INSPECTION FOR CRACK OF CENTER WING-FLAP TRACKS (LH/RH) THRESHOLD:6000FL | manual | 23min | 2019-04-18 08:00 | 2019-04-18 08:23 | AFM 1 | 0.38h |
| 40 | 24 | CHECK OF MAIN LANDING GEAR SHOCK ABSORBERS PRECHARGE WITH A/C ON JACK | manual | 25min | 2019-04-18 08:00 | 2019-04-18 08:25 | AFM 1 | 0.42h |
| 41 | 25 | CHECK OF NOSE LANDING GEAR SHOCK ABSORBERS PRECHARGE WITH A/C ON JACK | manual | 12min | 2019-04-18 08:00 | 2019-04-18 08:12 | AFM 1 | 0.2h |
| 42 | 26 | DETAILED VISUAL INSPECTION FOR CONDITION OF NOSE GEAR DOORS | manual | 12.2min | 2019-04-18 08:00 | 2019-04-18 08:12 | AFM 1 | 0.2h |
| 43 | 27 | DETAILED VISUAL INSPECTION OF NOSE LANDING GEAR DOWN LOCK DEVICE FOR CONDITION AND DAMAGE | manual | 3min | 2019-04-18 08:00 | 2019-04-18 08:03 | AFM 1 | 0.05h |
