# 5-19 A3

Schedule from MS Project, 2019-04-18 to 2019-04-26, 7 hours a day.

## Calendars

- Standard: Mon-Fri 08:00-12:00, 13:00-17:00; Sat-Sun off.

## Resources

| Resource |
| --- |
| AFM 1 |
| ENG |
| ENG 2 |
| NDI |

## Schedule

| ID | Task | Type | Duration | Start | Finish | Predecessors | Resources | Work |
| --- | --- | --- | --- | --- | --- | --- | --- | --- |
| 1 | (OPEN) ACCESS: 413A, 413B, 413C, 413D, 413E, 413F, 413G, 413H, 413J, 413K, 414A, 414B, 414C, 414D, 414E, 414F, 414G, 414H, 414J, | manual | 130min | 2019-04-18 08:00 | 2019-04-18 10:10 |  | AFM 1 | 2.17h |
| 2 | (OPEN) ACCESS:423A,423B, 423C, 423D, 423E, 423F, 423G, 423H, 423J, 423K, 424A, 424B ,424C, 424D, 424E, 424F, 424G, 424H, 424J | manual | 130min | 2019-04-18 10:10 | 2019-04-18 13:20 | 1 | AFM 1 | 2.17h |
| 3 | DETAILED VISUAL INSPECTION FOR CRACK OF CARGO RAMP-HOOKS THRESHOLD:3000FL | manual | 85min | 2019-04-18 13:20 | 2019-04-18 14:45 | 2 | AFM 1 | 1.42h |
| 4 | DETAILED VISUAL INSPECTION FOR CRACK OF FUSELAGE CENTER SECTION FRAME-29, UPPER AND LOWER ATTACH SPAR (LH/RH) THRESHOLD:750FL | manual | 20min | 2019-04-18 14:45 | 2019-04-18 15:05 | 3 | AFM 1 | 0.33h |
| 5 | DETAILED VISUAL INSPECTION FOR CRACK OF FUSELAGE REAR SECTION FRAME 42-44 ATTACHMENT TO HORIZONTAL STABILIZER (LH/RH) THRESHOLD:3000FL | manual | 200min | 2019-04-18 15:05 | 2019-04-19 09:25 | 4 | AFM 1 | 3.33h |
| 6 | DETAILED VISUAL INSPECTION FOR CRACK OF HORIZONTAL STABILIZER-FITTINGS HORIZONTAL STABILIZER / ELEVATOR (LH/RH) THRESHOLD:7500FL | manual | 158min | 2019-04-19 09:25 | 2019-04-19 13:03 | 5 | AFM 1 | 2.63h |
| 7 | DETAILED VISUAL INSPECTION FOR CRACK OF ELEVATOR-FITTINGS ELEVATOR / HORIZONTAL STABILIZER (LH/RH)THRESHOLD:7500FL | manual | 158min | 2019-04-19 13:03 | 2019-04-19 15:41 | 6 | AFM 1 | 2.63h |
| 8 | DETAILED VISUAL INSPECTION FOR CRACKS OF CENTER WING-WING / FUSELAGE ATTACHMENT FITTING AT RIB 2 (LH/RH) THRESHOLD:3000FL | manual | 182min | 2019-04-19 15:41 | 2019-04-22 09:43 | 7 | AFM 1 | 3.03h |
| 9 | DETAILED VISUAL INSPECTION FOR CRACK OF CENTER WING-WING / FUSELAGE ATTACHMENT FITTING AT RIB 3 (LH/RH) THRESHOLD:3000FL | manual | 182min | 2019-04-22 09:43 | 2019-04-22 13:45 | 8 | AFM 1 | 3.03h |
| 10 | DETAILED VISUAL INSPECTION FOR CRACK OF CENTER WING-NACELLE ATTACH AT RIB 13-FWD LOWER BACKUP FITTING (LH/RH) THRESHOLD:7500FL | manual | 210min | 2019-04-22 13:45 | 2019-04-23 08:15 | 9 | AFM 1 | 3.5h |
| 11 | DETAILED VISUAL INSPECTION FOR CRACK OF CENTER WING-UPPER SURFACE DOOR CUT-OUT THRESHOLD:3000FL | manual | 40min | 2019-04-23 08:15 | 2019-04-23 08:55 | 10 | AFM 1 | 0.67h |
| 12 | DETAILED VISUAL INSPECTION FOR CRACK OF OUTER WING-UPPER SKIN DOOR CUT-OUT (LH/RH) THRESHOLD:3000FL | manual | 60min | 2019-04-23 08:55 | 2019-04-23 09:55 | 11 | AFM 1 | 1h |
| 13 | CHECK OF MAIN LANDING GEAR SHOCK ABSORBERS PRECHARGE WITH A/C ON JACK | manual | 25min | 2019-04-23 09:55 | 2019-04-23 10:20 | 12 | AFM 1 | 0.42h |
| 14 | DETAILED VISUAL INSPECTION FOR CONDITION OF NOSE GEAR DOORS | manual | 12.2min | 2019-04-23 10:20 | 2019-04-23 10:32 | 13 | AFM 1 | 0.2h |
| 15 | DETAILED VISUAL INSPECTION OF NOSE LANDING GEAR DOWN LOCK DEVICE FOR CONDITION AND DAMAGE | manual | 3min | 2019-04-23 10:32 | 2019-04-23 10:35 | 14 | AFM 1 | 0.05h |
| 16 | DETAILED VISUAL INSPECTION FOR CRACK OF OUTER WING-FLAP TRACK (LH/RH) THRESHOLD:6000FL | manual | 26min | 2019-04-23 10:35 | 2019-04-23 11:01 | 15 | AFM 1 | 0.43h |
| 17 | DETAILED VISUAL INSPECTION FOR CRACK OF CENTER WING-FLAP TRACKS (LH/RH) THRESHOLD:6000FL | manual | 23min | 2019-04-23 11:01 | 2019-04-23 11:24 | 16 | AFM 1 | 0.38h |
| 18 | DETAILED VISUAL INSPECTION FOR CRACK OF MIDDLE FRAME AND STRUT, ENGINE NACELLE (LH) THRESHOLD:7500FL | manual | 20min | 2019-04-25 11:34 | 2019-04-25 11:54 | 27 | AFM 1 | 0.33h |
| 19 | DETAILED VISUAL INSPECTION FOR CRACK OF FWD FRAME, ENGINE NACELLE (LH) THRESHOLD:7500FL | manual | 20min | 2019-04-25 11:54 | 2019-04-25 13:14 | 18 | AFM 1 | 0.33h |
| 20 | (CLOSE) ACCESS: 413A, 413B, 413C, 413D, 413E, 413F, 413G, 413H, 413J, 413K, 414A, 414B, 414C, 414D, 414E, 414F, 414G, 414H, 414J, | manual | 130min | 2019-04-25 13:14 | 2019-04-25 15:24 | 19 | AFM 1 | 2.17h |
| 21 | DETAILED VISUAL INSPECTION FOR CRACK OF MIDDLE FRAME AND STRUT, ENGINE NACELLE (RH) THRESHOLD:7500FL | manual | 20min | 2019-04-26 09:01 | 2019-04-26 09:21 | 28 | AFM 1 | 0.33h |
| 22 | DETAILED VISUAL INSPECTION FOR CRACK OF FWD FRAME, ENGINE NACELLE (RH) THRESHOLD:7500FL | manual | 20min | 2019-04-26 09:21 | 2019-04-26 09:41 | 21 | AFM 1 | 0.33h |
| 23 | (CLOSE) ACCESS:423A,423B, 423C, 423D, 423E, 423F, 423G, 423H, 423J, 423K, 424A, 424B ,424C, 424D, 424E, 424F, 424G, 424H, 424J | manual | 130min | 2019-04-26 09:41 | 2019-04-26 11:51 | 22 | AFM 1 | 2.17h |
| 24 | CHECK OF NOSE LANDING GEAR SHOCK ABSORBERS PRECHARGE WITH A/C ON JACK | manual | 12min | 2019-04-26 11:51 | 2019-04-26 13:03 | 20, 23, 17 | AFM 1 | 0.2h |
| 25 | REMOVE LEFT ENGINE AND PROPELLER | manual | 1155min | 2019-04-18 08:00 | 2019-04-22 11:15 |  | ENG | 19.25h |
| 26 | REMOVE R ENGINE AND PROPELLER | manual | 1155min | 2019-04-18 13:20 | 2019-04-22 16:35 | 2 | ENG 2 | 19.25h |
| 27 | INSTALL LEFT ENGINE AND PROPELLER | manual | 1155min | 2019-04-23 08:19 | 2019-04-25 11:34 | 30 | ENG | 19.25h |
| 28 | INSTALL R ENGINE AND PROPELLER | manual | 1155min | 2019-04-23 14:46 | 2019-04-26 09:01 | 42 | ENG 2 | 19.25h |
| 29 | NON DESTRUCTIVE INSPECTION OF FWD FRAME ENGINE NACELLE (LH) FOR CRACK THRESHOLD:7500FL | manual | 22.3min | 2019-04-22 16:35 | 2019-04-22 16:57 | 26 | NDI | 0.37h |
| 30 | NON DESTRUCTIVE INSPECTION FOR CRACKS OF STRUTS, FWD-MID FRAME ENGINE NACELLE (LH) THRESHOLD:7500FL | manual | 22.3min | 2019-04-22 16:57 | 2019-04-23 08:19 | 29 | NDI | 0.37h |
| 31 | NON DESTRUCTIVE INSPECTION FOR CRACK OF STRUTS MID-AFT FRAMES (LH) THRESHOLD:7500FL | manual | 72min | 2019-04-23 08:19 | 2019-04-23 09:31 | 30 | NDI | 1.2h |
| 32 | NON DESTRUCTIVE INSPECTION FOR CRACK OF NACELLE STRUTS (AFT FRAME TO WING) (LH) THRESHOLD:7500FL | manual | 24min | 2019-04-23 09:31 | 2019-04-23 09:55 | 31 | NDI | 0.4h |
| 33 | NON DESTRUCTIVE INSPECTION FOR CRACK OF FWD FRAME, LOWER LEFT AND RIGHT, LUG-ENGINE NACELLE (LH) THRESHOLD:7500FL | manual | 10min | 2019-04-23 09:55 | 2019-04-23 10:05 | 32 | NDI | 0.17h |
| 34 | NON DESTRUCTIVE INSPECTION FOR CRACK OF NACELLE LOWER COWL ASSEMBLY (LOWER COWL STRUT) (LH) THRESHOLD:7500FL | manual | 15min | 2019-04-23 10:05 | 2019-04-23 10:20 | 33 | NDI | 0.25h |
| 35 | NON DESTRUCTIVE INSPECTION FOR CRACK OF AFT FRAME, ENGINE NACELLE (LH) THRESHOLD:7500FL | manual | 20min | 2019-04-23 10:20 | 2019-04-23 10:40 | 34 | NDI | 0.33h |
| 36 | NON DESTRUCTIVE INSPECTION OF FWD FRAME ENGINE NACELLE (RH) FOR CRACK THRESHOLD:7500FL | manual | 22.3min | 2019-04-23 10:40 | 2019-04-23 11:02 | 35, 25 | NDI | 0.37h |
| 37 | NON DESTRUCTIVE INSPECTION FOR CRACKS OF STRUTS, FWD-MID FRAME ENGINE NACELLE (RH) THRESHOLD:7500FL | manual | 22.3min | 2019-04-23 11:02 | 2019-04-23 11:25 | 36 | NDI | 0.37h |
| 38 | NON DESTRUCTIVE INSPECTION FOR CRACK OF STRUTS MID-AFT FRAMES (RH) THRESHOLD:7500FL | manual | 72min | 2019-04-23 11:25 | 2019-04-23 13:37 | 37 | NDI | 1.2h |
| 39 | NON DESTRUCTIVE INSPECTION FOR CRACK OF NACELLE STRUTS (AFT FRAME TO WING) (RH) THRESHOLD:7500FL | manual | 24min | 2019-04-23 13:37 | 2019-04-23 14:01 | 38 | NDI | 0.4h |
| 40 | NON DESTRUCTIVE INSPECTION FOR CRACK OF FWD FRAME, LOWER LEFT AND RIGHT, LUG-ENGINE NACELLE (RH) THRESHOLD:7500FL | manual | 10min | 2019-04-23 14:01 | 2019-04-23 14:11 | 39 | NDI | 0.17h |
| 41 | NON DESTRUCTIVE INSPECTION FOR CRACK OF NACELLE LOWER COWL ASSEMBLY (LOWER COWL STRUT) (RH) THRESHOLD:7500FL | manual | 15min | 2019-04-23 14:11 | 2019-04-23 14:26 | 40 | NDI | 0.25h |
| 42 | NON DESTRUCTIVE INSPECTION FOR CRACK OF AFT FRAME, ENGINE NACELLE (RH) THRESHOLD:7500FL | manual | 20min | 2019-04-23 14:26 | 2019-04-23 14:46 | 41 | NDI | 0.33h |
