# 5-2 A2

Schedule from MS Project, 2019-04-18 to 2019-04-23, 7 hours a day.
Grizli777

## Calendars

- Standard: Mon-Fri 08:00-12:00, 13:00-17:00; Sat-Sun off.

## Resources

| Resource |
| --- |
| AFM 1 |
| ENG |
| AFM 2 |
| ELC |

## Schedule

| ID | WBS | Task | Type | Duration | Start | Finish | Predecessors | Total slack | Resources | Work |
| --- | --- | --- | --- | --- | --- | --- | --- | --- | --- | --- |
| 1 | 1 | GENERAL VISUAL INSPECTION OF (LH) ENGINE NACELLES AFT SECTION | manual | 108min | 2019-04-18 08:00 | 2019-04-18 09:48 |  |  | AFM 1 | 1.8h |
| 2 | 2 | GENERAL VISUAL INSPECTION OF (RH) ENGINE NACELLES AFT SECTION | manual | 108min | 2019-04-18 09:48 | 2019-04-18 11:36 | 1 |  | AFM 1 | 1.8h |
| 3 | 3 | **DETAILED VISUAL INSPECTION OF GROUNDING STRAPS** |  | 0.5d | 2019-04-18 11:36 | 2019-04-18 16:04 |  | 0d |  | 3.47h |
| 4 | 3.1 | ACCESS BY AFM | manual | 148min | 2019-04-18 11:36 | 2019-04-18 15:04 | 2 |  | AFM 1 | 2.47h |
| 5 | 3.2 | GENERAL VISUAL INSPECTION BY ENG | manual | 60min | 2019-04-18 15:04 | 2019-04-18 16:04 | 4 |  | ENG | 1h |
| 6 | 4 | **DETAILED VISUAL INSPECTION OF REAR TURBINE BEARING OIL SCAVENGE TUBE FOR ANY SIGN OF OIL LEAKAGE** |  | 0.21d | 2019-04-18 15:04 | 2019-04-18 16:34 |  | 0d |  | 1.2h |
| 7 | 4.1 | ACCESS BY AFM | manual | 42min | 2019-04-18 15:04 | 2019-04-18 15:46 | 4 |  | AFM 1 | 0.7h |
| 8 | 4.2 | GENERAL VISUAL INSPECTION BY ENG | manual | 30min | 2019-04-18 16:04 | 2019-04-18 16:34 | 5 |  | ENG | 0.5h |
| 9 | 5 | **DETAILED VISUAL INSPECTION OF EXTERNAL PORTION OF REAR TURBINE BEARING SUPPORT FOR SECURITY AND GENERAL CONDITION** |  | 0.19d | 2019-04-18 15:46 | 2019-04-19 08:04 |  | 0d |  | 1.3h |
| 10 | 5.1 | ACCESS BY AFM | manual | 48min | 2019-04-18 15:46 | 2019-04-18 16:34 | 7 |  | AFM 1 | 0.8h |
| 11 | 5.2 | GENERAL VISUAL INSPECTION BY ENG | manual | 30min | 2019-04-18 16:34 | 2019-04-19 08:04 | 8 |  | ENG | 0.5h |
| 12 | 6 | **DETAILED VISUAL INSPECTION OF EXTERNAL PORTION OF THE REAR TURBINE BEARING SUPPORT FOR OIL LEAKAGE** |  | 0.14d | 2019-04-18 16:34 | 2019-04-19 08:34 |  | 0d |  | 1.17h |
| 13 | 6.1 | ACCESS BY AFM | manual | 40min | 2019-04-18 16:34 | 2019-04-19 08:14 | 10 |  | AFM 1 | 0.67h |
| 14 | 6.2 | GENERAL VISUAL INSPECTION BY ENG | manual | 30min | 2019-04-19 08:04 | 2019-04-19 08:34 | 11 |  | ENG | 0.5h |
| 15 | 7 | **GENERAL VISUAL INSPECTION OF TUBES AND HOSES ASSEMBLY FOR SECURITY AND CONDITION** |  | 0.16d | 2019-04-19 08:14 | 2019-04-19 09:21 |  | 0d |  | 1.45h |
| 16 | 7.1 | ACCESS BY AFM | manual | 40min | 2019-04-19 08:14 | 2019-04-19 08:54 | 13 |  | AFM 1 | 0.67h |
| 17 | 7.2 | GENERAL VISUAL INSPECTION BY ENG | manual | 47min | 2019-04-19 08:34 | 2019-04-19 09:21 | 14 |  | ENG | 0.78h |
| 18 | 8 | **DETAILED VISUAL INSPECTION OF INLET GUIDE VANES AND COMPRESSOR BLADES** |  | 0.22d | 2019-04-19 08:54 | 2019-04-19 10:25 |  | 0d |  | 1.2h |
| 19 | 8.1 | ACCESS BY AFM | manual | 8min | 2019-04-19 08:54 | 2019-04-19 09:02 | 16 |  | AFM 1 | 0.13h |
| 20 | 8.2 | GENERAL VISUAL INSPECTION BY ENG | manual | 64min | 2019-04-19 09:21 | 2019-04-19 10:25 | 17 |  | ENG | 1.07h |
| 21 | 9 | **DETAILED VISUAL INSPECTION OF COMBUSTION LINER AND DIFFUSER CASE** |  | 0.35d | 2019-04-19 09:02 | 2019-04-19 11:29 |  | 0d |  | 1.2h |
| 22 | 9.1 | ACCESS BY AFM | manual | 8min | 2019-04-19 09:02 | 2019-04-19 09:10 | 19 |  | AFM 1 | 0.13h |
| 23 | 9.2 | GENERAL VISUAL INSPECTION BY ENG | manual | 64min | 2019-04-19 10:25 | 2019-04-19 11:29 | 20 |  | ENG | 1.07h |
| 24 | 10 | GENERAL VISUAL INSPECTION OF CARGO RAMP, SEAL | manual | 95min | 2019-04-19 09:10 | 2019-04-19 10:45 | 22 |  | AFM 1 | 1.58h |
| 25 | 11 | DETAILED VISUAL INSPECTION OF RETAINING RODS AND SLIDERS OF RAMP DOOR FOR CONDITION | manual | 105min | 2019-04-19 10:45 | 2019-04-19 13:30 | 24 |  | AFM 1 | 1.75h |
| 26 | 12 | DETAILED VISUAL INSPECTION OF LOCKING HOOKS AND TORQUE TUBE OF RAMP DOOR FOR CONDITION | manual | 154min | 2019-04-19 13:30 | 2019-04-19 16:04 | 25 |  | AFM 1 | 2.57h |

| ID | WBS | Task | Type | Duration | Start | Finish | Predecessors | Total slack | Resources | Work |
| --- | --- | --- | --- | --- | --- | --- | --- | --- | --- | --- |
| 27 | 13 | **DETAILED VISUAL INSPECTION OF OIL SYSTEM FOR LEAKS** |  | 0.19d | 2019-04-19 16:04 | 2019-04-22 08:22 |  | 0d |  | 1.3h |
| 28 | 13.1 | ACCESS BY AFM | manual | 68min | 2019-04-19 16:04 | 2019-04-22 08:12 | 26 |  | AFM 1 | 1.13h |
| 29 | 13.2 | GENERAL VISUAL INSPECTION BY ENG | manual | 10min | 2019-04-22 08:12 | 2019-04-22 08:22 | 28 |  | ENG | 0.17h |
| 30 | 14 | GENERAL VISUAL INSPECTION OF CONDITIONING COMPARTMENT | manual | 155min | 2019-04-22 08:12 | 2019-04-22 10:47 | 28 |  | AFM 1 | 2.58h |
| 31 | 15 | DETAILED VISUAL INSPECTION OF VENT LINE FOR DAMAGE, CRACKS AND OBSTRUCTION | manual | 7.2min | 2019-04-22 10:47 | 2019-04-22 10:54 | 30 |  | AFM 1 | 0.12h |
| 32 | 16 | DETAILED VISUAL INSPECTION OF DISTRIBUTION DUCT FOR CORROSION, DAMAGE AND CRACKS. | manual | 7.2min | 2019-04-22 10:54 | 2019-04-22 11:01 | 31 |  | AFM 1 | 0.12h |
| 33 | 17 | DETAILED VISUAL INSPECTION OF DUCT CONNECTED TO THE CONVERTER FOR CORROSION, DAMAGE AND CRACKS | manual | 7.3min | 2019-04-22 11:01 | 2019-04-22 11:08 | 32 |  | AFM 1 | 0.12h |
| 34 | 18 | DETAILED VISUAL INSPECTION OF SERVOMOTORS DRUM AND BRACKETS FOR PRESENCE OF CORROSION, CRACKS, DETERIORATION AND GENERAL CONDITIONS | manual | 48min | 2019-04-22 11:08 | 2019-04-22 11:56 | 33 |  | AFM 1 | 0.8h |
| 35 | 19 | FUNCTIONAL CHECK OF PRESSURIZATION SYSTEM FOR: A.OVERPRESSURE B.NEGATIVE PRESSURE | manual | 63min | 2019-04-22 11:56 | 2019-04-22 13:59 | 34 |  | AFM 1 | 1.05h |
| 36 | 20 | DETAILED VISUAL INSPECTION OF OIL SYSTEM FOR LEAKS | manual | 10min | 2019-04-22 13:59 | 2019-04-22 14:09 | 35 |  | AFM 1 | 0.17h |
| 37 | 21 | OPERATIONAL CHECK TO VERIFY AUTOMATIC DRAIN VALVES (ADV) FAILURE | manual | 72min | 2019-04-22 14:09 | 2019-04-22 15:21 | 36 |  | AFM 1 | 1.2h |
| 38 | 22 | FUNCTIONAL CHECK OF FLAP FROM HYDRAULIC SYSTEM No1 & No2 | manual | 40min | 2019-04-22 15:21 | 2019-04-22 16:01 | 37 |  | AFM 1 | 0.67h |
| 39 | 23 | SERVICING FOR ELEVATOR HYDRAULIC ACCUMULATOR CHARGE | manual | 5min | 2019-04-22 16:01 | 2019-04-22 16:06 | 38 |  | AFM 1 | 0.08h |
| 40 | 24 | FUNCTIONAL CHECK OF ELEVATOR CONTROL TO VERIFY THE CORRECT ARTIFICIAL FORCE IN THE TOTAL OPERATIVE ENVELOP | manual | 34min | 2019-04-22 16:06 | 2019-04-22 16:40 | 39 |  | AFM 1 | 0.57h |
| 41 | 25 | FUNCTIONAL CHECK TO VERIFY THE STOP FUNCTION AT THE END OF FLAP TRAVEL | manual | 10min | 2019-04-22 16:40 | 2019-04-22 16:50 | 40 |  | AFM 1 | 0.17h |
| 42 | 26 | FUNCTIONAL CHECK OF SPOILERS FOR CORRECT EXTENSION | manual | 20min | 2019-04-22 16:50 | 2019-04-23 08:10 | 41 |  | AFM 1 | 0.33h |
| 43 | 27 | CHECK OF SYSTEM SPOILER FOR: A.BY-PASS CORRECT FUNCTION B.BUNGEE AND MIXER BOX MOVEMENT FOR CORRECT OPERATION | manual | 30min | 2019-04-23 08:10 | 2019-04-23 08:40 | 42 |  | AFM 1 | 0.5h |
| 44 | 28 | OPERATIONAL CHECK OF FUEL PUMP WORKING | manual | 15min | 2019-04-23 08:40 | 2019-04-23 08:55 | 43 |  | AFM 1 | 0.25h |
| 45 | 29 | OPERATIONAL CHECK TO VERIFY TANK FULL AUTOMATIC REFUEL CUT-OFF | manual | 16min | 2019-04-23 08:55 | 2019-04-23 09:11 | 44 |  | AFM 1 | 0.27h |
| 46 | 30 | DETAILED VISUAL INSPECTION OF CARGO DOOR, DOWNLOCKING HOOKS, PIN AND FIXED HOOKS FOR CONDITION | manual | 75min | 2019-04-18 08:00 | 2019-04-18 09:15 |  |  | AFM 2 | 1.25h |
| 47 | 31 | GENERAL VISUAL INSPECTION OF COCKPIT (FRAME 1 TO FRAME 7) | manual | 50min | 2019-04-18 09:15 | 2019-04-18 10:05 | 46 |  | AFM 2 | 0.83h |
| 48 | 32 | GENERAL VISUAL INSPECTION OF CREW DOOR, HINGE, SEAL AND COMPENSATION DEVICE ASSY | manual | 47min | 2019-04-18 10:05 | 2019-04-18 10:52 | 47 |  | AFM 2 | 0.78h |
| 49 | 33 | DETAILED VISUAL INSPECTION OF CREW ENTRY DOOR FOR CONDITION OF THE A.CREW DOOR DEVICES B.BRACING CABLES C.HINGE AND COMPENSATION MECHANISM | manual | 139min | 2019-04-18 10:52 | 2019-04-18 14:11 | 48 |  | AFM 2 | 2.32h |
| 50 | 34 | DETAILED VISUAL INSPECTION OF CREW ENTRY DOOR FOR CONDITION OF THE A.CREW DOOR DEVICES B.BRACING CABLES C.HINGE AND COMPENSATION MECHANISM | manual | 1min | 2019-04-18 14:11 | 2019-04-18 14:12 | 49 |  | AFM 2 | 0.02h |
| 51 | 35 | GENERAL VISUAL INSPECTION OF EMERGENCY EXIT DOOR, SEAL | manual | 15min | 2019-04-18 14:12 | 2019-04-18 14:27 | 50 |  | AFM 2 | 0.25h |
| 52 | 36 | DETAILED VISUAL INSPECTION OF EMERGENCY EXIT DOOR MECHANISM FOR CONDITION | manual | 27min | 2019-04-18 14:27 | 2019-04-18 14:54 | 51 |  | AFM 2 | 0.45h |
| 53 | 37 | OPERATIONAL CHECK OF EMERGENCY EXIT DOOR | manual | 2min | 2019-04-18 14:54 | 2019-04-18 14:56 | 52 |  | AFM 2 | 0.03h |
| 54 | 38 | GENERAL VISUAL INSPECTION OF (LH) PARATROOPS DOOR, SEAL, INTERNAL STRUCTURE AND COMPONENTS | manual | 30min | 2019-04-18 14:56 | 2019-04-18 15:26 | 53 |  | AFM 2 | 0.5h |
| 55 | 39 | GENERAL VISUAL INSPECTION OF (RH) PARATROOPS DOOR, SEAL, INTERNAL STRUCTURE AND COMPONENTS | manual | 30min | 2019-04-18 15:26 | 2019-04-18 15:56 | 54 |  | AFM 2 | 0.5h |
| 56 | 40 | FUNCTIONAL CHECK OF REAR LATERAL DOORS OPERATION | manual | 10min | 2019-04-18 15:56 | 2019-04-18 16:06 | 55 |  | AFM 2 | 0.17h |
| 57 | 41 | GENERAL VISUAL INSPECTION OF EMERGENCY EXIT, SEAL (UPPER FUSELAGE) | manual | 15min | 2019-04-18 16:06 | 2019-04-18 16:21 | 56 |  | AFM 2 | 0.25h |
| 58 | 42 | GENERAL VISUAL INSPECTION OF CARGO COMPARTMENT EMERGENCY EXIT, SEAL (UPPER FUSELAGE-FWD EXIT) | manual | 15min | 2019-04-18 16:21 | 2019-04-18 16:36 | 57 |  | AFM 2 | 0.25h |
| 59 | 43 | GENERAL VISUAL INSPECTION OF CARGO COMPARTMENT EMERGENCY EXIT, SEAL (UPPER FUSELAGE-AFT EXIT) | manual | 15min | 2019-04-18 16:36 | 2019-04-18 16:51 | 58 |  | AFM 2 | 0.25h |
| 60 | 44 | DETAILED VISUAL INSPECTION FOR CONDITION OF EMERGENCY EXIT HATCHES MECHANISM | manual | 66min | 2019-04-18 16:51 | 2019-04-19 08:57 | 59 |  | AFM 2 | 1.1h |
| 61 | 45 | OPERATIONAL CHECK OF EMERGENCY EXIT HATCHES | manual | 6min | 2019-04-19 08:57 | 2019-04-19 09:03 | 60 |  | AFM 2 | 0.1h |
| 62 | 46 | DETAILED VISUAL INSPECTION FOR CONDITION OF BATTERY COMPARTMENT ACCESS HINGE AND BATTERY SUPPORT | manual | 11min | 2019-04-19 09:03 | 2019-04-19 09:14 | 61 |  | AFM 2 | 0.18h |
| 63 | 47 | DETAILED VISUAL INSPECTION OF MASK AND RELATED HOSE FOR CORROSION, DAMAGE AND CRACKS | manual | 5min | 2019-04-19 09:14 | 2019-04-19 09:19 | 62 |  | AFM 2 | 0.08h |
| 64 | 48 | DETAILED VISUAL INSPECTION OF SMOKE GOGGLES FOR CORROSION AND GENERAL DAMAGE | manual | 5min | 2019-04-19 09:19 | 2019-04-19 09:24 | 63 |  | AFM 2 | 0.08h |
| 65 | 49 | DETAILED VISUAL INSPECTION FOR CONDITION OF DOOR HINGE AND BAY EMERGENCY LIFERAFT | manual | 29min | 2019-04-19 09:24 | 2019-04-19 09:53 | 64 |  | AFM 2 | 0.48h |
| 66 | 50 | GENERAL VISUAL INSPECTION OF CARGO COMPARTMENT UNDERFLOOR (FRAME 7 TO FRAME 29) | manual | 173min | 2019-04-19 09:53 | 2019-04-19 13:46 | 65 |  | AFM 2 | 2.88h |
| 67 | 51 | OPERATIONAL CHECK OF APU REMOTE FIRE EXTINGUISH SWITCH AND ASSOCIATED CIRCUIT | manual | 42min | 2019-04-19 13:46 | 2019-04-19 14:28 | 66 |  | AFM 2 | 0.7h |
| 68 | 52 | FUNCTIONAL CHECK OF ENGINE AND PROPELLER ANTI-ICE SYSTEMS | manual | 10min | 2019-04-23 09:11 | 2019-04-23 09:21 | 45 |  | ENG | 0.17h |
| 69 | 53 | FUNCTIONAL CHECK OF VISUAL ICE DETECTOR |  | 5min | 2019-04-23 09:21 | 2019-04-23 09:26 | 68 | 0d | ELC | 0.08h |
| 70 | 54 | OPERATIONAL CHECK OF POSITION LIGHT SYSTEM |  | 1min | 2019-04-23 09:26 | 2019-04-23 09:27 | 69 | 0d | ELC | 0.02h |
| 71 | 55 | FUNCTIONAL CHECK OF CARGO SMOKE DETECTORS FOR PROPER FUNCTION |  | 10min | 2019-04-23 09:27 | 2019-04-23 09:37 | 70 | 0d | ELC | 0.17h |
| 72 | 56 | FUNCTIONAL CHECK OF LAVATORY SMOKE DETECTOR FOR PROPER FUNCTION |  | 1min | 2019-04-23 09:37 | 2019-04-23 09:38 | 71 | 0d | ELC | 0.02h |
| 73 | 57 | OPERATIONAL CHECK OF APU REMOTE FIRE EXTINGUISH SWITCH AND ASSOCIATED CIRCUIT |  | 42min | 2019-04-23 09:38 | 2019-04-23 10:20 | 72 | 0d | ELC | 0.7h |
| 74 | 58 | OPERATIONAL CHECK OF APU T-HANDLE AND FIRE EXTINGUISHER CIRCUIT FOR PROPER FUNCTION |  | 41min | 2019-04-23 10:20 | 2019-04-23 11:01 | 73 | 0d | ELC | 0.68h |
| 75 | 59 | FUNCTIONAL CHECK OF OVERBOARD VALVE |  | 6min | 2019-04-23 11:01 | 2019-04-23 11:07 | 74 | 0d | ELC | 0.1h |
