# 5-21 B1

Schedule from MS Project, 2019-04-18 to 2019-04-23.

## Calendars

- Standard: Mon-Fri 08:00-12:00, 13:00-17:00; Sat-Sun off.

## Resources

| Resource |
| --- |
| AFM 1 |
| NDI |

## Schedule

| ID | Task | Type | Duration | Start | Finish | Resources | Work |
| --- | --- | --- | --- | --- | --- | --- | --- |
| 1 | GENERAL VISUAL INSPECTION OF CREW ENTRANCE (FRAME 7 TO FRAME 9B) | manual | 155min | 2019-04-18 08:00 | 2019-04-18 10:35 | AFM 1 | 2.58h |
| 2 | DETAILED VISUAL INSPECTION FOR CORROSION OF CREW DOOR-HINGE | manual | 5min | 2019-04-18 08:00 | 2019-04-18 08:05 | AFM 1 | 0.08h |
| 3 | DETAILED VISUAL INSPECTION FOR CORROSION OF CREW DOOR-SHOOT BOLT | manual | 6min | 2019-04-18 08:00 | 2019-04-18 08:06 | AFM 1 | 0.1h |
| 4 | DETAILED VISUAL INSPECTION FOR CORROSION OF EMERGENCY EXIT HATCH-HINGE | manual | 10min | 2019-04-18 08:00 | 2019-04-18 08:10 | AFM 1 | 0.17h |
| 5 | DETAILED VISUAL INSPECTION FOR CORROSION OF EMERGENCY EXIT DOOR-HINGE | manual | 5min | 2019-04-18 08:00 | 2019-04-18 08:05 | AFM 1 | 0.08h |
| 6 | DETAILED VISUAL INSPECTION FOR CORROSION OF CARGO DOOR-HINGE | manual | 10min | 2019-04-18 08:00 | 2019-04-18 08:10 | AFM 1 | 0.17h |
| 7 | DETAILED VISUAL INSPECTION FOR CORROSION OF CARGO DOOR-HOOK SUPPORTS | manual | 40min | 2019-04-18 08:00 | 2019-04-18 08:40 | AFM 1 | 0.67h |
| 8 | DETAILED VISUAL INSPECTION FOR CORROSION OF CARGO DOOR-INTERNAL SIDE | manual | 60min | 2019-04-18 08:00 | 2019-04-18 09:00 | AFM 1 | 1h |
| 9 | DETAILED VISUAL INSPECTION FOR CORROSION OF CARGO RAMP-HINGES | manual | 85min | 2019-04-18 08:00 | 2019-04-18 09:25 | AFM 1 | 1.42h |
| 10 | DETAILED VISUAL INSPECTION FOR CORROSION OF RAMP HOOK SUPPORTS (LH/RH) | manual | 30min | 2019-04-18 08:00 | 2019-04-18 08:30 | AFM 1 | 0.5h |
| 11 | DETAILED VISUAL INSPECTION FOR CORROSION OF CARGO RAMP-INTERNAL SIDE | manual | 486min | 2019-04-18 08:00 | 2019-04-19 08:06 | AFM 1 | 8.1h |
| 12 | DETAILED VISUAL INSPECTION FOR CORROSION OF FUSELAGE FWD SECTION-INTERNAL SIDE | manual | 807min | 2019-04-18 08:00 | 2019-04-19 14:27 | AFM 1 | 13.45h |
| 13 | DETAILED VISUAL INSPECTION FOR CORROSION OF FUSELAGE FWD SECTION-STRUCTURE UNDER TOILETTE | manual | 77min | 2019-04-18 08:00 | 2019-04-18 09:17 | AFM 1 | 1.28h |
| 14 | DETAILED VISUAL INSPECTION FOR CORROSION OF FUSELAGE FWD SECTION-RETAINER WINDOW | manual | 960min | 2019-04-18 08:00 | 2019-04-19 17:00 | AFM 1 | 16h |
| 15 | DETAILED VISUAL INSPECTION FOR CORROSION OF FUSELAGE FWD SECTION-HINGE SUPPORT (HATCH VANE) | manual | 10min | 2019-04-18 08:00 | 2019-04-18 08:10 | AFM 1 | 0.17h |
| 16 | DETAILED VISUAL INSPECTION FOR CORROSION OF FUSELAGE FWD SECTION-HINGE SUPPORT | manual | 5min | 2019-04-18 08:00 | 2019-04-18 08:05 | AFM 1 | 0.08h |
| 17 | DETAILED VISUAL INSPECTION FOR CORROSION OF FUSELAGE FWD SECTION-HINGE SUPPORT (EMERGENCY EXIT VANE) | manual | 5min | 2019-04-18 08:00 | 2019-04-18 08:05 | AFM 1 | 0.08h |
| 18 | DETAILED VISUAL INSPECTION FOR CORROSION OF FUSELAGE CENTER SECTION UPPER AND LATERAL INTERNAL SIDE | manual | 930min | 2019-04-18 08:00 | 2019-04-19 16:30 | AFM 1 | 15.5h |
| 19 | DETAILED VISUAL INSPECTION FOR CORROSION OF FUSELAGE CENTER SECTION-FRAMES 18, 20, 22 LUG ATTACH WING, INTERNAL SIDE | manual | 30min | 2019-04-18 08:00 | 2019-04-18 08:30 | AFM 1 | 0.5h |
| 20 | DETAILED VISUAL INSPECTION FOR CORROSION OF FUSELAGE CENTER SECTION-FRAMES 18, 20, 22 LUGS ATTACH WING, EXTERNAL SIDE | manual | 192min | 2019-04-18 08:00 | 2019-04-18 11:12 | AFM 1 | 3.2h |
| 21 | DETAILED VISUAL INSPECTION FOR CORROSION OF FUSELAGE CENTER SECTION-FRAMES 18, 21 LUGS ATTACH MLG | manual | 227min | 2019-04-18 08:00 | 2019-04-18 11:47 | AFM 1 | 3.78h |
| 22 | DETAILED VISUAL INSPECTION FOR CORROSION OF FUSELAGE CENTER SECTION, FWD AND REAR HATCH-HINGE | manual | 20min | 2019-04-18 08:00 | 2019-04-18 08:20 | AFM 1 | 0.33h |
| 23 | DETAILED VISUAL INSPECTION FOR CORROSION OF FUSELAGE CENTER SECTION-LOWER,INTERNAL SIDE | manual | 1614min | 2019-04-18 08:00 | 2019-04-23 10:54 | AFM 1 | 26.9h |
| 24 | DETAILED VISUAL INSPECTION FOR CORROSION OF RAMP HINGE SUPPORT | manual | 85min | 2019-04-18 08:00 | 2019-04-18 09:25 | AFM 1 | 1.42h |
| 25 | DETAILED VISUAL INSPECTION FOR CORROSION OF FUSELAGE CENTER SECTION-FRAME 29, UPPER AND LOWER, ATTACH SPAR (LH/RH) | manual | 30min | 2019-04-18 08:00 | 2019-04-18 08:30 | AFM 1 | 0.5h |
| 26 | DETAILED VISUAL INSPECTION FOR CORROSION OF FUSELAGE CENTER SECTION-LATCH SUPPORTS PARATROOP DOORS (LH/RH) | manual | 30min | 2019-04-18 08:00 | 2019-04-18 08:30 | AFM 1 | 0.5h |
| 27 | DETAILED VISUAL INSPECTION FOR CORROSION OF FUSELAGE REAR SECTION-INTERNAL SIDE (FRAMES 29-47). | manual | 370min | 2019-04-18 08:00 | 2019-04-18 15:10 | AFM 1 | 6.17h |
| 28 | DETAILED VISUAL INSPECTION FOR CORROSION OF FUSELAGE REAR SECTION CARGO RAMP-HOOK SUPPORTS (LH/RH) | manual | 20min | 2019-04-18 08:00 | 2019-04-18 08:20 | AFM 1 | 0.33h |
| 29 | DETAILED VISUAL INSPECTION FOR CORROSION OF FUSELAGE REAR SECTION CARGO DOOR-HOOK SUPPORTS | manual | 25min | 2019-04-18 08:00 | 2019-04-18 08:25 | AFM 1 | 0.42h |
| 30 | DETAILED VISUAL INSPECTION FOR CORROSION OF FUSELAGE REAR SECTION CARGO DOOR-HINGE | manual | 10min | 2019-04-18 08:00 | 2019-04-18 08:10 | AFM 1 | 0.17h |
| 31 | DETAILED VISUAL INSPECTION FOR CORROSION OF STRUT FITTING-TOP, LEFT, RIGHT (LH/RH) NACELLE | manual | 175min | 2019-04-18 08:00 | 2019-04-18 10:55 | AFM 1 | 2.92h |
| 32 | DETAILED VISUAL INSPECTION FOR CORROSION OF STRUTS, FWD-MID FRAME ENGINE NACELLE (LH/RH) | manual | 156min | 2019-04-18 08:00 | 2019-04-18 10:36 | AFM 1 | 2.6h |
| 33 | DETAILED VISUAL INSPECTION FOR CORROSION OF STRUT FITTING, FWD LEFT AND RIGHT, UPPER ENGINE NACELLE (LH/RH) | manual | 38min | 2019-04-18 08:00 | 2019-04-18 08:38 | AFM 1 | 0.63h |
| 34 | DETAILED VISUAL INSPECTION FOR CORROSION OF STRUT FITTING, AFT LEFT AND RIGHT, UPPER ENGINE NACELLE (LH/RH) | manual | 54min | 2019-04-18 08:00 | 2019-04-18 08:54 | AFM 1 | 0.9h |
| 35 | DETAILED VISUAL INSPECTION FOR CORROSION OF STRUT FITTING, LEFT AND RIGHT, LOWER ENGINE NACELLE (LH/RH | manual | 98min | 2019-04-18 08:00 | 2019-04-18 09:38 | AFM 1 | 1.63h |
| 36 | DETAILED VISUAL INSPECTION FOR CORROSION OF STRUTS MID-AFT FRAMES (LH/RH) | manual | 94min | 2019-04-18 08:00 | 2019-04-18 09:34 | AFM 1 | 1.57h |
| 37 | DETAILED VISUAL INSPECTION FOR CORROSION OF NACELLE LOWER COWL ASSEMBLY (LOWER COWL STRUT LH/RH) | manual | 40min | 2019-04-18 08:00 | 2019-04-18 08:40 | AFM 1 | 0.67h |
| 38 | DETAILED VISUAL INSPECTION FOR CORROSION OF NACELLE-SKIN, LOWER COWL (LH/RH) | manual | 40min | 2019-04-18 08:00 | 2019-04-18 08:40 | AFM 1 | 0.67h |
| 39 | DETAILED VISUAL INSPECTION FOR CORROSION OF NACELLE-STRUTS (AFT FRAME TO WING LH/RH) | manual | 128min | 2019-04-18 08:00 | 2019-04-18 10:08 | AFM 1 | 2.13h |
| 40 | DETAILED VISUAL INSPECTION FOR CORROSION OF HORIZONTAL STABILIZER-FRONT AND REAR SPAR (LH/RH), INTERNAL SIDE | manual | 350min | 2019-04-18 08:00 | 2019-04-18 14:50 | AFM 1 | 5.83h |
| 41 | DETAILED VISUAL INSPECTION FOR CORROSION OF HORIZONTAL STABILIZER-REAR SPAR (LH/RH), EXTERNAL SIDE | manual | 158min | 2019-04-18 08:00 | 2019-04-18 10:38 | AFM 1 | 2.63h |
| 42 | DETAILED VISUAL INSPECTION FOR CORROSION OF HORIZONTAL STABILIZER-FITTINGS HORIZONTAL STABILIZER / ELEVATOR (LH/RH) | manual | 158min | 2019-04-18 08:00 | 2019-04-18 10:38 | AFM 1 | 2.63h |
| 43 | NON DESTRUCTIVE INSPECTION OF (LH/RH) ELEVATOR -UPPER AND LOWER SURFACE FOR CORROSION / DEBONDING | manual | 80min | 2019-04-18 08:00 | 2019-04-18 09:20 | NDI | 1.33h |
| 44 | NON DESTRUCTIVE INSPECTION OF ELEVATOR-BALANCE TAB SURFACE (LH/RH) FOR CORROSION / DEBONDING | manual | 20min | 2019-04-18 08:00 | 2019-04-18 08:20 | NDI | 0.33h |
| 45 | DETAILED VISUAL INSPECTION FOR CORROSION OF ELEVATOR-FITTINGS BALANCE TAB (LH/RH) | manual | 10min | 2019-04-18 08:00 | 2019-04-18 08:10 | AFM 1 | 0.17h |
| 46 | NON DESTRUCTIVE INSPECTION OF ELEVATOR TRIM TAB SURFACE(LH/RH) FOR CORROSION/DEBONDING | manual | 20min | 2019-04-18 08:00 | 2019-04-18 08:20 | NDI | 0.33h |
| 47 | DETAILED VISUAL INSPECTION FOR CORROSION OF ELEVATOR-FITTINGS TRIM TAB (LH/RH) | manual | 10min | 2019-04-18 08:00 | 2019-04-18 08:10 | AFM 1 | 0.17h |
| 48 | DETAILED VISUAL INSPECTION FOR CORROSION OF ELEVATOR FITTINGS ELEVATOR HORIZONTAL STABILIZER (LH/RH) | manual | 10min | 2019-04-18 08:00 | 2019-04-18 08:10 | AFM 1 | 0.17h |
| 49 | DETAILED VISUAL INSPECTION FOR CORROSION OF FIN -INTERNAL SIDE | manual | 60min | 2019-04-18 08:00 | 2019-04-18 09:00 | AFM 1 | 1h |
| 50 | DETAILED VISUAL INSPECTION FOR CORROSION OF FIN -FITTINGS FIN /RUDDER | manual | 30min | 2019-04-18 08:00 | 2019-04-18 08:30 | AFM 1 | 0.5h |
| 51 | NON DESTRUCTIVE ISPECTION OF RUDDER-SURFACE(LH/RH) FOR CORROSION DEBONDING | manual | 120min | 2019-04-18 08:00 | 2019-04-18 10:00 | NDI | 2h |
| 52 | DETAILED VISUAL INSPECTION FOR CORROSION OF RUDDER-FITTINGS RUDDER / FIN | manual | 30min | 2019-04-18 08:00 | 2019-04-18 08:30 | AFM 1 | 0.5h |
| 53 | DETAILED VISUAL INSPECTION FOR CORROSION OF CENTER WING-WING/FUSELAGE ATTACHMENT FITTING AT RIB 2 (LH/RH) | manual | 192min | 2019-04-18 08:00 | 2019-04-18 11:12 | AFM 1 | 3.2h |
| 54 | DETAILED VISUAL INSPECTION FOR CORROSION OF WING-FUSELAGE ATTACHMENT FITTING AT RIB 3(LH/RH) | manual | 192min | 2019-04-18 08:00 | 2019-04-18 11:12 | AFM 1 | 3.2h |
| 55 | DETAILED VISUAL INSPECTION FOR CORROSION OF CENTER WING-COUPLING RODS AT RIB 3 (LH/RH) | manual | 202min | 2019-04-18 08:00 | 2019-04-18 11:22 | AFM 1 | 3.37h |
| 56 | DETAILED VISUAL INSPECTION FOR CORROSION OF OF CENTER WING-WING/NACELLE ATTACHMENT AT FITTING RIB 11/12/13 (LH/RH) | manual | 178min | 2019-04-18 08:00 | 2019-04-18 10:58 | AFM 1 | 2.97h |
| 57 | DETAILED VISUAL INSPECTION FOR CORROSION OF CENTER WING-FRONT, MIDDLE AND REAR SPAR (INTERNAL SIDE) | manual | 1188min | 2019-04-18 08:00 | 2019-04-22 11:48 | AFM 1 | 19.8h |
| 58 | DETAILED VISUAL INSPECTION FOR CORROSION OF CENTER WING-NACELLE ATTACHMENT AT RIB 13-FWD AND LWR BACK-UP FITTING | manual | 210min | 2019-04-18 08:00 | 2019-04-18 11:30 | AFM 1 | 3.5h |
| 59 | DETAILED VISUAL INSPECTION FOR CORROSION OF CENTER WING, UPPER AND LOWER, SURFACE - INTERNAL SIDE | manual | 1008min | 2019-04-18 08:00 | 2019-04-22 08:48 | AFM 1 | 16.8h |
| 60 | DETAILED VISUAL INSPECTION FOR CORROSION OF OUTER WING-FRONT MIDDLE AND REAR SPAR-INTERNAL SIDE(LH/RH) | manual | 1820min | 2019-04-18 08:00 | 2019-04-23 15:20 | AFM 1 | 30.33h |
| 61 | DETAILED VISUAL INSPECTION FOR CORROSION OF OUTER WING, UPPER AND LOWER, SURFACE (LH/RH) - INTERNAL SIDE | manual | 1820min | 2019-04-18 08:00 | 2019-04-23 15:20 | AFM 1 | 30.33h |
| 62 | NON DESTRUCTIVE INSPECTION OF AILERON, UPPER AND LOWER, SURFACE (LH/RH) FOR CORROSION / DEBONDING | manual | 50min | 2019-04-18 08:00 | 2019-04-18 08:50 | NDI | 0.83h |
| 63 | NON DESTRUCTIVE INSPECTION OF AILERON BALANCE TAB SURFACE (LH/RH) FOR CORROSION / DEBONDING | manual | 20min | 2019-04-18 08:00 | 2019-04-18 08:20 | NDI | 0.33h |
| 64 | NON DESTRUCTIVE INSPECTION OF AILERON TRIM TAB SURFACE (LH/RH) FOR CORROSION/DEBONDING | manual | 20min | 2019-04-18 08:00 | 2019-04-18 08:20 | NDI | 0.33h |
| 65 | DETAILED VISUAL INSPECTION FOR CORROSION OF AILERON-BALANCE TAB FITTINGS (LH/RH) | manual | 10min | 2019-04-18 08:00 | 2019-04-18 08:10 | AFM 1 | 0.17h |
| 66 | DETAILED VISUAL INSPECTION FOR CORROSION OF AILERON-TRIM TAB FITTINGS | manual | 10min | 2019-04-18 08:00 | 2019-04-18 08:10 | AFM 1 | 0.17h |
| 67 | NON DESTRUCTIVE INSPECTION OF INNER FLAP, UPPER AND LOWER SURFACE (LH/RH) FOR CORROSION / DEBONDING | manual | 80min | 2019-04-18 08:00 | 2019-04-18 09:20 | NDI | 1.33h |
| 68 | DETAILED VISUAL INSPECTION FOR CORROSION OF OUTER AND INNER FLAP-ROLLERS RIBS(LH/RH) | manual | 69min | 2019-04-18 08:00 | 2019-04-18 09:09 | AFM 1 | 1.15h |
| 69 | NON DESTRUCTIVE INSPECTION OF OUTER FLAP, UPPER AND LOWER, SURFACE (LH/RH) FOR CORROSION / DEBONDING | manual | 80min | 2019-04-18 08:00 | 2019-04-18 09:20 | NDI | 1.33h |
| 70 | DETAILED VISUAL INSPECTION FOR CORROSION OF AILERON -FITTINGS(LH/RH) | manual | 10min | 2019-04-18 08:00 | 2019-04-18 08:10 | AFM 1 | 0.17h |

| ID | Task | Type | Duration | Start | Finish | Resources | Work |
| --- | --- | --- | --- | --- | --- | --- | --- |
| 71 | NON DESTRUCTIVE INSPECTION ON OUTER WING-UPPER AND LOWER SURFACE SPOILER FOR CORROSION | manual | 30min | 2019-04-18 08:00 | 2019-04-18 08:30 | NDI | 0.5h |
| 72 | DETAILED VISUAL INSPECTION FOR CORROSION AND CRACKS OF AILERON INNER RODS | manual | 5min | 2019-04-18 08:00 | 2019-04-18 08:05 | AFM 1 | 0.08h |
| 73 | DETAILED VISUAL INSPECTION OF FUEL TANK FOR EXTERNAL LEAKAGE | manual | 40min | 2019-04-18 08:00 | 2019-04-18 08:40 | AFM 1 | 0.67h |
| 74 | FUNCTIONAL CHECK OF VENT FLOAT VALVE | manual | 227min | 2019-04-18 08:00 | 2019-04-18 11:47 | AFM 1 | 3.78h |
| 75 | FUNCTIONAL CHECK OF DRAINAGE FLOAT VALVE | manual | 71min | 2019-04-18 08:00 | 2019-04-18 09:11 | AFM 1 | 1.18h |
| 76 | DETAILED VISUAL INSPECTION OF EMERGENCY LIFERAFTS RELEASE SYSTEM LINKAGE FOR CONDITION AND DAMAGE | manual | 3min | 2019-04-18 08:00 | 2019-04-18 08:03 | AFM 1 | 0.05h |
