# 5-22 B1

Schedule from MS Project, 2019-04-18 to 2019-05-14, 7 hours a day.

## Calendars

- Standard: Mon-Fri 08:00-12:00, 13:00-17:00; Sat-Sun off.

## Resources

| Resource |
| --- |
| AFM 1 |
| NDI |
| AFM 2 |

## Schedule

| ID | Task | Type | Duration | Start | Finish | Predecessors | Resources | Work |
| --- | --- | --- | --- | --- | --- | --- | --- | --- |
| 1 | GENERAL VISUAL INSPECTION OF CREW ENTRANCE (FRAME 7 TO FRAME 9B) | manual | 155min | 2019-04-18 08:00 | 2019-04-18 10:35 |  | AFM 1 | 2.58h |
| 2 | DETAILED VISUAL INSPECTION FOR CORROSION OF FUSELAGE FWD SECTION-STRUCTURE UNDER TOILETTE | manual | 77min | 2019-04-18 10:35 | 2019-04-18 11:52 | 1 | AFM 1 | 1.28h |
| 3 | DETAILED VISUAL INSPECTION FOR CORROSION OF CREW DOOR-SHOOT BOLT | manual | 6min | 2019-04-18 11:52 | 2019-04-18 11:58 | 2 | AFM 1 | 0.1h |
| 4 | DETAILED VISUAL INSPECTION FOR CORROSION OF FUSELAGE FWD SECTION-HINGE SUPPORT | manual | 5min | 2019-04-18 11:58 | 2019-04-18 13:03 | 3 | AFM 1 | 0.08h |
| 5 | DETAILED VISUAL INSPECTION FOR CORROSION OF FUSELAGE FWD SECTION-HINGE SUPPORT (EMERGENCY EXIT VANE) | manual | 5min | 2019-04-18 13:03 | 2019-04-18 13:08 | 4 | AFM 1 | 0.08h |
| 6 | DETAILED VISUAL INSPECTION FOR CORROSION OF CREW DOOR-HINGE | manual | 5min | 2019-04-18 13:08 | 2019-04-18 13:13 | 5 | AFM 1 | 0.08h |
| 7 | DETAILED VISUAL INSPECTION FOR CORROSION OF FUSELAGE FWD SECTION-HINGE SUPPORT (HATCH VANE) | manual | 10min | 2019-04-18 13:13 | 2019-04-18 13:23 | 6 | AFM 1 | 0.17h |
| 8 | DETAILED VISUAL INSPECTION FOR CORROSION OF FUSELAGE CENTER SECTION, FWD AND REAR HATCH-HINGE | manual | 20min | 2019-04-18 13:23 | 2019-04-18 13:43 | 7 | AFM 1 | 0.33h |
| 9 | DETAILED VISUAL INSPECTION FOR CORROSION OF EMERGENCY EXIT HATCH-HINGE | manual | 10min | 2019-04-18 13:43 | 2019-04-18 13:53 | 8 | AFM 1 | 0.17h |
| 10 | DETAILED VISUAL INSPECTION FOR CORROSION OF EMERGENCY EXIT DOOR-HINGE | manual | 5min | 2019-04-18 13:53 | 2019-04-18 13:58 | 9 | AFM 1 | 0.08h |
| 11 | DETAILED VISUAL INSPECTION FOR CORROSION OF FUSELAGE CENTER SECTION-FRAMES 18, 20, 22 LUGS ATTACH WING, EXTERNAL SIDE | manual | 192min | 2019-04-18 13:58 | 2019-04-19 08:10 | 10 | AFM 1 | 3.2h |
| 12 | DETAILED VISUAL INSPECTION FOR CORROSION OF CENTER WING-WING/FUSELAGE ATTACHMENT FITTING AT RIB 2 (LH/RH) | manual | 192min | 2019-04-19 08:10 | 2019-04-19 11:22 | 11 | AFM 1 | 3.2h |
| 13 | DETAILED VISUAL INSPECTION FOR CORROSION OF WING-FUSELAGE ATTACHMENT FITTING AT RIB 3(LH/RH) | manual | 192min | 2019-04-19 11:22 | 2019-04-19 15:34 | 12 | AFM 1 | 3.2h |
| 14 | DETAILED VISUAL INSPECTION FOR CORROSION OF CENTER WING-COUPLING RODS AT RIB 3 (LH/RH) | manual | 202min | 2019-04-19 15:34 | 2019-04-22 09:56 | 13 | AFM 1 | 3.37h |
| 15 | DETAILED VISUAL INSPECTION FOR CORROSION OF OF CENTER WING-WING/NACELLE ATTACHMENT AT FITTING RIB 11/12/13 (LH/RH) | manual | 178min | 2019-04-22 09:56 | 2019-04-22 13:54 | 14 | AFM 1 | 2.97h |
| 16 | DETAILED VISUAL INSPECTION FOR CORROSION OF STRUT FITTING, AFT LEFT AND RIGHT, UPPER ENGINE NACELLE (LH/RH) | manual | 54min | 2019-04-22 13:54 | 2019-04-22 14:48 | 15 | AFM 1 | 0.9h |
| 17 | DETAILED VISUAL INSPECTION FOR CORROSION OF STRUT FITTING-TOP, LEFT, RIGHT (LH/RH) NACELLE | manual | 175min | 2019-04-22 14:48 | 2019-04-23 08:43 | 16 | AFM 1 | 2.92h |
| 18 | DETAILED VISUAL INSPECTION FOR CORROSION OF STRUTS, FWD-MID FRAME ENGINE NACELLE (LH/RH) | manual | 156min | 2019-04-23 08:43 | 2019-04-23 11:19 | 17 | AFM 1 | 2.6h |
| 19 | DETAILED VISUAL INSPECTION FOR CORROSION OF STRUT FITTING, FWD LEFT AND RIGHT, UPPER ENGINE NACELLE (LH/RH) | manual | 38min | 2019-04-23 11:19 | 2019-04-23 11:57 | 18 | AFM 1 | 0.63h |
| 20 | DETAILED VISUAL INSPECTION FOR CORROSION OF STRUT FITTING, LEFT AND RIGHT, LOWER ENGINE NACELLE (LH/RH | manual | 98min | 2019-04-23 11:57 | 2019-04-23 14:35 | 19 | AFM 1 | 1.63h |
| 21 | DETAILED VISUAL INSPECTION FOR CORROSION OF NACELLE LOWER COWL ASSEMBLY (LOWER COWL STRUT LH/RH) | manual | 40min | 2019-04-23 14:35 | 2019-04-23 15:15 | 20 | AFM 1 | 0.67h |
| 22 | DETAILED VISUAL INSPECTION FOR CORROSION OF NACELLE-SKIN, LOWER COWL (LH/RH) | manual | 40min | 2019-04-23 15:15 | 2019-04-23 15:55 | 21 | AFM 1 | 0.67h |
| 23 | DETAILED VISUAL INSPECTION FOR CORROSION OF STRUTS MID-AFT FRAMES (LH/RH) | manual | 94min | 2019-04-23 15:55 | 2019-04-24 08:29 | 22 | AFM 1 | 1.57h |
| 24 | DETAILED VISUAL INSPECTION FOR CORROSION OF NACELLE-STRUTS (AFT FRAME TO WING LH/RH) | manual | 128min | 2019-04-24 08:29 | 2019-04-24 10:37 | 23 | AFM 1 | 2.13h |
| 25 | DETAILED VISUAL INSPECTION FOR CORROSION OF CENTER WING-NACELLE ATTACHMENT AT RIB 13-FWD AND LWR BACK-UP FITTING | manual | 210min | 2019-04-24 10:37 | 2019-04-24 15:07 | 24 | AFM 1 | 3.5h |
| 26 | DETAILED VISUAL INSPECTION FOR CORROSION OF AILERON-BALANCE TAB FITTINGS (LH/RH) | manual | 10min | 2019-04-24 15:07 | 2019-04-24 15:17 | 25 | AFM 1 | 0.17h |
| 27 | DETAILED VISUAL INSPECTION FOR CORROSION OF AILERON-TRIM TAB FITTINGS | manual | 10min | 2019-04-24 15:17 | 2019-04-24 15:27 | 26 | AFM 1 | 0.17h |
| 28 | DETAILED VISUAL INSPECTION FOR CORROSION OF FUSELAGE FWD SECTION-RETAINER WINDOW | manual | 960min | 2019-04-24 15:27 | 2019-04-26 15:27 | 27 | AFM 1 | 16h |
| 29 | DETAILED VISUAL INSPECTION FOR CORROSION OF AILERON -FITTINGS(LH/RH) | manual | 10min | 2019-04-26 15:27 | 2019-04-26 15:37 | 28, 60 | AFM 1 | 0.17h |
| 30 | DETAILED VISUAL INSPECTION FOR CORROSION AND CRACKS OF AILERON INNER RODS | manual | 5min | 2019-04-26 15:37 | 2019-04-26 15:42 | 29 | AFM 1 | 0.08h |
| 31 | DETAILED VISUAL INSPECTION FOR CORROSION OF OUTER AND INNER FLAP-ROLLERS RIBS(LH/RH) | manual | 69min | 2019-04-26 15:42 | 2019-04-26 16:51 | 30 | AFM 1 | 1.15h |
| 32 | DETAILED VISUAL INSPECTION FOR CORROSION OF CARGO RAMP-HINGES | manual | 85min | 2019-04-26 16:51 | 2019-04-29 09:16 | 31 | AFM 1 | 1.42h |
| 33 | DETAILED VISUAL INSPECTION FOR CORROSION OF RAMP HINGE SUPPORT | manual | 85min | 2019-04-29 09:16 | 2019-04-29 10:41 | 32 | AFM 1 | 1.42h |
| 34 | DETAILED VISUAL INSPECTION FOR CORROSION OF RAMP HOOK SUPPORTS (LH/RH) | manual | 30min | 2019-04-29 10:41 | 2019-04-29 11:11 | 33 | AFM 1 | 0.5h |
| 35 | DETAILED VISUAL INSPECTION FOR CORROSION OF FUSELAGE CENTER SECTION-FRAMES 18, 21 LUGS ATTACH MLG | manual | 227min | 2019-04-29 11:11 | 2019-04-29 15:58 | 34 | AFM 1 | 3.78h |
| 36 | DETAILED VISUAL INSPECTION FOR CORROSION OF FUSELAGE CENTER SECTION-FRAME 29, UPPER AND LOWER, ATTACH SPAR (LH/RH) | manual | 30min | 2019-04-29 15:58 | 2019-04-29 16:28 | 35 | AFM 1 | 0.5h |
| 37 | DETAILED VISUAL INSPECTION FOR CORROSION OF FUSELAGE CENTER SECTION-LATCH SUPPORTS PARATROOP DOORS (LH/RH) | manual | 30min | 2019-04-29 16:28 | 2019-04-29 16:58 | 36 | AFM 1 | 0.5h |
| 38 | DETAILED VISUAL INSPECTION FOR CORROSION OF FUSELAGE REAR SECTION CARGO RAMP-HOOK SUPPORTS (LH/RH) | manual | 20min | 2019-04-29 16:58 | 2019-04-30 08:18 | 37 | AFM 1 | 0.33h |
| 39 | DETAILED VISUAL INSPECTION FOR CORROSION OF FUSELAGE REAR SECTION CARGO DOOR-HOOK SUPPORTS | manual | 25min | 2019-04-30 08:18 | 2019-04-30 08:43 | 38 | AFM 1 | 0.42h |
| 40 | DETAILED VISUAL INSPECTION FOR CORROSION OF FUSELAGE REAR SECTION CARGO DOOR-HINGE | manual | 10min | 2019-04-30 08:43 | 2019-04-30 08:53 | 39 | AFM 1 | 0.17h |
| 41 | DETAILED VISUAL INSPECTION FOR CORROSION OF HORIZONTAL STABILIZER-REAR SPAR (LH/RH), EXTERNAL SIDE | manual | 158min | 2019-04-30 08:53 | 2019-04-30 11:31 | 40 | AFM 1 | 2.63h |
| 42 | DETAILED VISUAL INSPECTION FOR CORROSION OF HORIZONTAL STABILIZER-FITTINGS HORIZONTAL STABILIZER / ELEVATOR (LH/RH) | manual | 158min | 2019-04-30 11:31 | 2019-04-30 15:09 | 41 | AFM 1 | 2.63h |
| 43 | DETAILED VISUAL INSPECTION FOR CORROSION OF ELEVATOR-FITTINGS BALANCE TAB (LH/RH) | manual | 10min | 2019-04-30 15:09 | 2019-04-30 15:19 | 42 | AFM 1 | 0.17h |
| 44 | DETAILED VISUAL INSPECTION FOR CORROSION OF ELEVATOR-FITTINGS TRIM TAB (LH/RH) | manual | 10min | 2019-04-30 15:19 | 2019-04-30 15:29 | 43 | AFM 1 | 0.17h |
| 45 | DETAILED VISUAL INSPECTION FOR CORROSION OF ELEVATOR FITTINGS ELEVATOR HORIZONTAL STABILIZER (LH/RH) | manual | 10min | 2019-04-30 15:29 | 2019-04-30 15:39 | 44 | AFM 1 | 0.17h |
| 46 | DETAILED VISUAL INSPECTION FOR CORROSION OF FIN -FITTINGS FIN /RUDDER | manual | 30min | 2019-04-30 15:39 | 2019-04-30 16:09 | 45 | AFM 1 | 0.5h |
| 47 | DETAILED VISUAL INSPECTION FOR CORROSION OF RUDDER-FITTINGS RUDDER / FIN | manual | 30min | 2019-04-30 16:09 | 2019-04-30 16:39 | 46 | AFM 1 | 0.5h |
| 48 | NON DESTRUCTIVE INSPECTION OF (LH/RH) ELEVATOR -UPPER AND LOWER SURFACE FOR CORROSION / DEBONDING | manual | 80min | 2019-04-30 16:39 | 2019-05-01 08:59 | 47 | NDI | 1.33h |
| 49 | NON DESTRUCTIVE INSPECTION OF ELEVATOR-BALANCE TAB SURFACE (LH/RH) FOR CORROSION / DEBONDING | manual | 20min | 2019-05-01 08:59 | 2019-05-01 09:19 | 48 | NDI | 0.33h |
| 50 | NON DESTRUCTIVE INSPECTION OF ELEVATOR TRIM TAB SURFACE(LH/RH) FOR CORROSION/DEBONDING | manual | 20min | 2019-05-01 09:19 | 2019-05-01 09:39 | 49 | NDI | 0.33h |
| 51 | NON DESTRUCTIVE ISPECTION OF RUDDER-SURFACE(LH/RH) FOR CORROSION DEBONDING | manual | 120min | 2019-05-01 09:39 | 2019-05-01 11:39 | 50 | NDI | 2h |
| 52 | DETAILED VISUAL INSPECTION FOR CORROSION OF FIN -INTERNAL SIDE | manual | 60min | 2019-05-01 11:39 | 2019-05-01 13:39 | 51, 66 | AFM 1 | 1h |
| 53 | DETAILED VISUAL INSPECTION FOR CORROSION OF OUTER WING-FRONT MIDDLE AND REAR SPAR-INTERNAL SIDE(LH/RH) | manual | 1820min | 2019-05-01 13:39 | 2019-05-07 10:59 | 52 | AFM 1 | 30.33h |
| 54 | DETAILED VISUAL INSPECTION FOR CORROSION OF OUTER WING, UPPER AND LOWER, SURFACE (LH/RH) - INTERNAL SIDE | manual | 1820min | 2019-05-07 10:59 | 2019-05-13 09:19 | 53 | AFM 1 | 30.33h |
| 55 | DETAILED VISUAL INSPECTION FOR CORROSION OF FUSELAGE REAR SECTION-INTERNAL SIDE (FRAMES 29-47). | manual | 370min | 2019-05-13 09:19 | 2019-05-13 16:29 | 54 | AFM 1 | 6.17h |
| 56 | FUNCTIONAL CHECK OF VENT FLOAT VALVE | manual | 227min | 2019-05-13 16:29 | 2019-05-14 11:16 | 55, 76 | AFM 1 | 3.78h |
| 57 | FUNCTIONAL CHECK OF DRAINAGE FLOAT VALVE | manual | 71min | 2019-05-14 11:16 | 2019-05-14 13:27 | 56 | AFM 1 | 1.18h |
| 58 | NON DESTRUCTIVE INSPECTION OF AILERON, UPPER AND LOWER, SURFACE (LH/RH) FOR CORROSION / DEBONDING | manual | 50min | 2019-04-24 15:27 | 2019-04-24 16:17 | 27 | NDI | 0.83h |
| 59 | NON DESTRUCTIVE INSPECTION OF AILERON TRIM TAB SURFACE (LH/RH) FOR CORROSION/DEBONDING | manual | 20min | 2019-04-24 16:17 | 2019-04-24 16:37 | 58 | NDI | 0.33h |
| 60 | NON DESTRUCTIVE INSPECTION OF AILERON BALANCE TAB SURFACE (LH/RH) FOR CORROSION / DEBONDING | manual | 20min | 2019-04-24 16:37 | 2019-04-24 16:57 | 59 | NDI | 0.33h |
| 61 | NON DESTRUCTIVE INSPECTION OF INNER FLAP, UPPER AND LOWER SURFACE (LH/RH) FOR CORROSION / DEBONDING | manual | 80min | 2019-04-26 16:51 | 2019-04-29 09:11 | 31 | NDI | 1.33h |
| 62 | NON DESTRUCTIVE INSPECTION OF OUTER FLAP, UPPER AND LOWER, SURFACE (LH/RH) FOR CORROSION / DEBONDING | manual | 80min | 2019-04-29 09:11 | 2019-04-29 10:31 | 61 | NDI | 1.33h |
| 63 | NON DESTRUCTIVE INSPECTION ON OUTER WING-UPPER AND LOWER SURFACE SPOILER FOR CORROSION | manual | 30min | 2019-04-29 10:31 | 2019-04-29 11:01 | 62 | NDI | 0.5h |
| 64 | DETAILED VISUAL INSPECTION FOR CORROSION OF CARGO DOOR-HOOK SUPPORTS | manual | 40min | 2019-04-30 16:39 | 2019-05-01 08:19 | 47 | AFM 1 | 0.67h |
| 65 | DETAILED VISUAL INSPECTION OF FUEL TANK FOR EXTERNAL LEAKAGE | manual | 40min | 2019-05-01 08:19 | 2019-05-01 08:59 | 64 | AFM 1 | 0.67h |
| 66 | DETAILED VISUAL INSPECTION OF EMERGENCY LIFERAFTS RELEASE SYSTEM LINKAGE FOR CONDITION AND DAMAGE | manual | 3min | 2019-05-01 08:59 | 2019-05-01 09:02 | 65 | AFM 1 | 0.05h |
| 67 | DETAILED VISUAL INSPECTION FOR CORROSION OF CARGO DOOR-INTERNAL SIDE | manual | 60min | 2019-04-18 08:00 | 2019-04-18 09:00 |  | AFM 2 | 1h |
| 68 | DETAILED VISUAL INSPECTION FOR CORROSION OF CARGO DOOR-HINGE | manual | 10min | 2019-04-18 09:00 | 2019-04-18 09:10 | 67 | AFM 2 | 0.17h |
| 69 | DETAILED VISUAL INSPECTION FOR CORROSION OF FUSELAGE CENTER SECTION UPPER AND LATERAL INTERNAL SIDE | manual | 930min | 2019-04-18 09:10 | 2019-04-22 08:40 | 68 | AFM 2 | 15.5h |
| 70 | DETAILED VISUAL INSPECTION FOR CORROSION OF FUSELAGE CENTER SECTION-FRAMES 18, 20, 22 LUG ATTACH WING, INTERNAL SIDE | manual | 30min | 2019-04-22 08:40 | 2019-04-22 09:10 | 69 | AFM 2 | 0.5h |

| ID | Task | Type | Duration | Start | Finish | Predecessors | Resources | Work |
| --- | --- | --- | --- | --- | --- | --- | --- | --- |
| 71 | DETAILED VISUAL INSPECTION FOR CORROSION OF CENTER WING-FRONT, MIDDLE AND REAR SPAR (INTERNAL SIDE) | manual | 1188min | 2019-04-22 09:10 | 2019-04-24 13:58 | 70 | AFM 2 | 19.8h |
| 72 | DETAILED VISUAL INSPECTION FOR CORROSION OF CENTER WING, UPPER AND LOWER, SURFACE - INTERNAL SIDE | manual | 1008min | 2019-04-24 13:58 | 2019-04-26 14:46 | 71 | AFM 2 | 16.8h |
| 73 | DETAILED VISUAL INSPECTION FOR CORROSION OF CARGO RAMP-INTERNAL SIDE | manual | 486min | 2019-04-26 14:46 | 2019-04-29 14:52 | 72 | AFM 2 | 8.1h |
| 74 | DETAILED VISUAL INSPECTION FOR CORROSION OF FUSELAGE FWD SECTION-INTERNAL SIDE | manual | 807min | 2019-04-29 14:52 | 2019-05-01 11:19 | 73 | AFM 2 | 13.45h |
| 75 | DETAILED VISUAL INSPECTION FOR CORROSION OF FUSELAGE CENTER SECTION-LOWER,INTERNAL SIDE | manual | 1614min | 2019-05-01 11:19 | 2019-05-06 15:13 | 74 | AFM 2 | 26.9h |
| 76 | DETAILED VISUAL INSPECTION FOR CORROSION OF HORIZONTAL STABILIZER-FRONT AND REAR SPAR (LH/RH), INTERNAL SIDE | manual | 350min | 2019-05-06 15:13 | 2019-05-07 13:03 | 75 | AFM 2 | 5.83h |
