# 5-25 B2

Schedule from MS Project, 2019-04-18 to 2019-04-30, 7 hours a day.

## Calendars

- Standard: Mon-Fri 08:00-12:00, 13:00-17:00; Sat-Sun off.

## Resources

| Resource |
| --- |
| AFM 1 |
| AFM 2 |
| ENG |
| OXY |
| ELC |

## Schedule

| ID | WBS | Task | Type | Duration | Start | Finish | Predecessors | Resources | Work |
| --- | --- | --- | --- | --- | --- | --- | --- | --- | --- |
| 1 | 1 | GENERAL VISUAL INSPECTION OF CARGO COMPARTMENT UNDERFLOOR (FRAME 7 TO FRAME 29) | manual | 580min | 2019-04-18 08:00 | 2019-04-19 09:40 |  | AFM 1 | 9.67h |
| 2 | 2 | GENERAL VISUAL INSPECTION OF (LH) MLG NACELLE | manual | 83min | 2019-04-19 09:40 | 2019-04-19 11:03 | 1 | AFM 1 | 1.38h |
| 3 | 3 | DETAILED VISUAL INSPECTION OF EXHAUST DUCT DRAIN FOR CLOGGING AND CRACKS. | manual | 31min | 2019-04-19 11:03 | 2019-04-19 11:34 | 2 | AFM 1 | 0.52h |
| 4 | 4 | DETAILED VISUAL INSPECTION OF BLEDD SYSTEM FOR LEAKS | manual | 85min | 2019-04-19 11:34 | 2019-04-19 13:59 | 3 | AFM 1 | 1.42h |
| 5 | 5 | DETAILED VISUAL INSPECTION OF APU INLET DUCT FOR CONDITION AND CRACKS | manual | 54min | 2019-04-19 13:59 | 2019-04-19 14:53 | 4 | AFM 1 | 0.9h |
| 6 | 6 | DETAILED VISUAL INSPECTION OF APU DUCT FOR CORROSION, DAMAGE AND DISCONNECTION | manual | 46min | 2019-04-19 14:53 | 2019-04-19 15:39 | 5 | AFM 1 | 0.77h |
| 7 | 7 | DETAILED VISUAL INSPECTION OF APU DRAIN MAST FOR CLOGGING AND CRACKS | manual | 73min | 2019-04-19 15:39 | 2019-04-19 16:52 | 6 | AFM 1 | 1.22h |
| 8 | 8 | GENERAL VISUAL INSPECTION OF LH ENGINE FWD SECTION | manual | 86min | 2019-04-19 16:52 | 2019-04-22 09:18 | 7 | AFM 1 | 1.43h |
| 9 | 9 | GENERAL VISUAL INSPECTION OF LH ENGINE AFT SECTION | manual | 27min | 2019-04-22 09:18 | 2019-04-22 09:45 | 8 | AFM 1 | 0.45h |
| 10 | 10 | GENERAL VISUAL INSPECTION OF (LH) PROPELLER | manual | 101min | 2019-04-22 09:45 | 2019-04-22 11:26 | 9 | AFM 1 | 1.68h |
| 11 | 11 | GENERAL VISUAL INSPECTION OF (LH) TRAILING EDGE AND AFT SPAR | manual | 63min | 2019-04-22 11:26 | 2019-04-22 13:29 | 10 | AFM 1 | 1.05h |
| 12 | 12 | GENERAL VISUAL INSPECTION OF (LH) AILERON AND FLAPS (INTERNAL AND EXTERNAL SIDE) | manual | 256min | 2019-04-22 13:29 | 2019-04-23 08:45 | 11 | AFM 1 | 4.27h |
| 13 | 13 | DETAILED VISUAL INSPECTION OF FLAP MECHANICAL CONTROL FOR CONDITION, LEAKAGE AND WEAR | manual | 39min | 2019-04-23 08:45 | 2019-04-23 09:24 | 12 | AFM 1 | 0.65h |
| 14 | 14 | DETAILED VISUAL INSPECTION OF AILERON MECHANICAL LINKAGE ON WINGS (RODS BELLCRANKS LEVERS HINGES) FOR CONDITION, CORROSION AND CRACKS | manual | 39min | 2019-04-23 09:24 | 2019-04-23 10:03 | 13 | AFM 1 | 0.65h |
| 15 | 15 | DETAILED VISUAL INSPECTION OF FLAP | manual | 50min | 2019-04-23 10:03 | 2019-04-23 10:53 | 14 | AFM 1 | 0.83h |
| 16 | 16 | DETAILED VISUAL INSPECTION OF ENGINE AIRBLEED FOR CORROSION, DAMAGE OR DISCONNECTION | manual | 13min | 2019-04-23 10:53 | 2019-04-23 11:06 | 15 | AFM 1 | 0.22h |
| 17 | 17 | DETAILED VISUAL INSPECTION OF PRE-COOLER AND ASSOCIATED DUCT FOR CORROSION, DAMAGE AND DISCONNECTION | manual | 10min | 2019-04-23 11:06 | 2019-04-23 11:16 | 16 | AFM 1 | 0.17h |
| 18 | 18 | DETAILED VISUAL INSPECTION OF ENGINE START DUCT FOR CORROSION, DAMAGE OR DISCONNECTION | manual | 10min | 2019-04-23 11:16 | 2019-04-23 11:26 | 17 | AFM 1 | 0.17h |
| 19 | 19 | GENERAL VISUAL INSPECTION OF TWO WAY CHECK TEE AND DISTRIBUTION PIPE | manual | 44min | 2019-04-23 11:26 | 2019-04-23 13:10 | 18 | AFM 1 | 0.73h |
| 20 | 20 | DETAILED VISUAL INSPECTION OF AILERON LINKAGE FROM CONTROL WHEELS TO WINGS CONNECTION FOR CONDITION AND WEAR | manual | 466min | 2019-04-23 13:10 | 2019-04-24 11:56 | 19 | AFM 1 | 7.77h |
| 21 | 21 | DETAILED VISUAL INSPECTION OF PRESSURIZATION JET PUMP FOR OBSTRUCTION | manual | 5min | 2019-04-24 11:56 | 2019-04-24 13:01 | 20 | AFM 1 | 0.08h |
| 22 | 22 | DETAILED VISUAL INSPECTION OF PRESSURIZATION PIPING'S FOR DAMAGE OR DISCONNECTION | manual | 58min | 2019-04-24 13:01 | 2019-04-24 13:59 | 21 | AFM 1 | 0.97h |
| 23 | 23 | DETAILED VISUAL INSPECTION OF AIR COOLING DUCT FOR DAMAGE , CRACKS AND CORRECT COUPLING | manual | 78min | 2019-04-24 13:59 | 2019-04-24 15:17 | 22 | AFM 1 | 1.3h |
| 24 | 24 | DETAILED VISUAL INSPECTION OF WATER SEPARATOR AND PIPING FOR CONDITION AND OBSTRUCTION | manual | 63min | 2019-04-24 15:17 | 2019-04-24 16:20 | 23 | AFM 1 | 1.05h |
| 25 | 25 | DETAILED VISUAL INSPECTION OF E/E AIR EXTRACTION/VENTILATION DUCTING AND CLAMPS FOR CONDITIONS | manual | 47min | 2019-04-24 16:20 | 2019-04-25 08:07 | 24 | AFM 1 | 0.78h |
| 26 | 26 | DETAILED VISUAL INSPECTION OF REAR LATERAL DOORS MECHANISM FOR CONDITION | manual | 25min | 2019-04-25 08:07 | 2019-04-25 08:32 | 25 | AFM 1 | 0.42h |
| 27 | 27 | DETAILED VISUAL INSPECTION OF RUDDER CONTROL PEDALS FOR CONDITION | manual | 108min | 2019-04-25 08:32 | 2019-04-25 10:20 | 26 | AFM 1 | 1.8h |
| 28 | 28 | DETAILED VISUAL INSPECTION OF RUDDER INTERCONNECTION RODS FOR CONDITION | manual | 69min | 2019-04-25 10:20 | 2019-04-25 11:29 | 27 | AFM 1 | 1.15h |
| 29 | 29 | DETAILED VISUAL INSPECTION OF RUDDER CONTROL CABLE AND QUADRANT FOR CONDITION | manual | 30min | 2019-04-25 11:29 | 2019-04-25 11:59 | 28 | AFM 1 | 0.5h |
| 30 | 30 | DETAILED VISUAL INSPECTION OF LINKAGE FROM CONTROL PEDALS TO RUDDER FOR CONDITION ,CORROSION AND WEAR. | manual | 924min | 2019-04-25 11:59 | 2019-04-29 11:23 | 29 | AFM 1 | 15.4h |
| 31 | 31 | GENERAL VISUAL INSPECTION OF VERTICAL EMPENNAGE (RUDDER & FIN) | manual | 657min | 2019-04-18 08:00 | 2019-04-19 10:57 |  | AFM 2 | 10.95h |
| 32 | 32 | GENERAL VISUAL INSPECTION OF (RH) MLG NACELLE | manual | 83min | 2019-04-19 10:57 | 2019-04-19 13:20 | 31 | AFM 2 | 1.38h |
| 33 | 33 | GENERAL VISUAL INSPECTION OF RH ENGINE FWD SECTION | manual | 86min | 2019-04-19 13:20 | 2019-04-19 14:46 | 32 | AFM 2 | 1.43h |
| 34 | 34 | GENERAL VISUAL INSPECTION OF RH ENGINE AFT SECTION | manual | 27min | 2019-04-19 14:46 | 2019-04-19 15:13 | 33 | AFM 2 | 0.45h |
| 35 | 35 | GENERAL VISUAL INSPECTION OF (RH) PROPELLER | manual | 101min | 2019-04-19 15:13 | 2019-04-19 16:54 | 34 | AFM 2 | 1.68h |
| 36 | 36 | GENERAL VISUAL INSPECTION OF (RH) TRAILING EDGE AND AFT SPAR | manual | 63min | 2019-04-19 16:54 | 2019-04-22 08:57 | 35 | AFM 2 | 1.05h |
| 37 | 37 | GENERAL VISUAL INSPECTION OF (RH) AILERON AND FLAPS (INTERNAL AND EXTERNAL SIDE) | manual | 256min | 2019-04-22 08:57 | 2019-04-22 14:13 | 36 | AFM 2 | 4.27h |
| 38 | 38 | DETAILED VISUAL INSPECTION OF ELEVATOR FOR CONDITION OF MECHANICAL LINKAGE | manual | 30min | 2019-04-22 14:13 | 2019-04-22 14:43 | 37 | AFM 2 | 0.5h |
| 39 | 39 | DETAILED VISUAL INSPECTION OF THE FAIL SAFE PATH OF ELEVATOR MECHANICAL LINKAGE FOR CONDITIONS | manual | 40min | 2019-04-22 14:43 | 2019-04-22 15:23 | 38 | AFM 2 | 0.67h |
| 40 | 40 | DETAILED VISUAL INSPECTION OF ELEVATOR CONTROL CABLES FOR CONDITION AND PROTECTION | manual | 1138min | 2019-04-22 15:23 | 2019-04-25 09:21 | 39 | AFM 2 | 18.97h |
| 41 | 41 | DETAILED VISUAL INSPECTION OF PITCH TRIM ELEVATOR ACTUATORS ASSEMBLY FOR CONDITION AND WEAR | manual | 10min | 2019-04-25 09:21 | 2019-04-25 09:31 | 40 | AFM 2 | 0.17h |
| 42 | 42 | DETAILED VISUAL INSPECTION OF CREW SEAT AND SEAT TRACK FOR CONDITION | manual | 20min | 2019-04-25 09:31 | 2019-04-25 09:51 | 41 | AFM 2 | 0.33h |
| 43 | 43 | (OPEN) ACCESS: 413 A 413 B 413 C 413 D 413 H 413 J 423 A 423 B 423 C 423 D 423 H 423 J | manual | 56min | 2019-04-25 09:51 | 2019-04-25 10:47 | 42 | AFM 2 | 0.93h |
| 44 | 44 | FUNCTIONAL CHECK OF CREW DOOR DEVICES | manual | 20min | 2019-04-29 11:23 | 2019-04-29 11:43 | 30, 43 | AFM 2 | 0.33h |
| 45 | 45 | FUNCTIONAL CHECK OF ELEVATOR MECHANISM STATUS AND CORRECT FUNCTION | manual | 31.2min | 2019-04-29 11:43 | 2019-04-29 13:14 | 44 | AFM 2 | 0.52h |
| 46 | 46 | OPERATIONAL TEST OF ELEVATOR MANUAL MODE | manual | 21.2min | 2019-04-29 13:14 | 2019-04-29 13:35 | 45 | AFM 2 | 0.35h |
| 47 | 47 | FUNCTIONAL CHECK OF ELEVATOR CENTERING SPRING FAILURE TO VERIFY THE RETURN TO "0" POSITION WITHOUT PILOT LINK | manual | 5min | 2019-04-29 13:35 | 2019-04-29 13:40 | 46 | AFM 2 | 0.08h |
| 48 | 48 | FUNCTIONAL CHECK OF ELEVATOR TRIM FUNCTION (NORMAL/STAND-BY) IN THE OPERATIVE ENVELOP | manual | 10min | 2019-04-29 13:40 | 2019-04-29 13:50 | 47 | AFM 2 | 0.17h |
| 49 | 49 | FUNCTIONAL CHECK OF ELEVATOR EMERGENCY TRIM ACTUATOR SYSTEM | manual | 5min | 2019-04-29 13:50 | 2019-04-29 13:55 | 48 | AFM 2 | 0.08h |
| 50 | 50 | FUNCTIONAL CHECK OF THE RUDDER DUMPING FUNCTION OF HYDRAULIC ACTUATOR | manual | 5min | 2019-04-29 13:55 | 2019-04-29 14:00 | 49 | AFM 2 | 0.08h |
| 51 | 51 | FUNCTIONAL CHECK OF THE CORRECT MANEUVER EFFORT TO THE GUST LOCK LEVER | manual | 5min | 2019-04-29 14:00 | 2019-04-29 14:05 | 50 | AFM 2 | 0.08h |
| 52 | 52 | OPERATIONAL CHECK OF AIR CONDITIONING SHUT-OFF TO VERIFY THE CORRECT FLOW CONTROL VALVE OPERATION | manual | 27min | 2019-04-29 14:05 | 2019-04-29 14:32 | 51 | AFM 2 | 0.45h |
| 53 | 53 | OPERATIONAL CHECK OF PRESSURIZATION MANUAL MODE SELECTION | manual | 37min | 2019-04-29 14:32 | 2019-04-29 15:09 | 52 | AFM 2 | 0.62h |
| 54 | 54 | OPERATIONAL CHECK OF ECS DUMP MODE | manual | 27min | 2019-04-29 15:09 | 2019-04-29 15:36 | 53 | AFM 2 | 0.45h |
| 55 | 55 | OPERATIONAL CHECK OF ECS DITCHING MODE | manual | 27min | 2019-04-29 15:36 | 2019-04-29 16:03 | 54 | AFM 2 | 0.45h |
| 56 | 56 | FUNCTIONAL CHECK OF LOW LIMIT VALVE WITH STANDARD ECS DIGITAL CONTROLLER (SEDC) INOPERATIVE | manual | 5min | 2019-04-29 16:03 | 2019-04-29 16:08 | 55 | AFM 2 | 0.08h |
| 57 | 57 | OPERATIONAL CHECK OF DE-ICING SYSTEM TO VERIFY :A.SYSTEM LOW PRESSURE CONDITION INDICATION. B. LOCAL LOW PRESSURE CONDITION INDICATION | manual | 5min | 2019-04-29 16:08 | 2019-04-29 16:13 | 56 | AFM 2 | 0.08h |
| 58 | 58 | FUNCTIONAL CHECK THE OXYGEN SUPPLY LINE LEAKAGE CHECK | manual | 62.2min | 2019-04-29 16:13 | 2019-04-30 08:15 | 57 | AFM 2 | 1.04h |

| ID | WBS | Task | Type | Duration | Start | Finish | Predecessors | Total slack | Resources | Work |
| --- | --- | --- | --- | --- | --- | --- | --- | --- | --- | --- |
| 59 | 59 | **DETAILED VISUAL INSPECTION OF COMPRESSOR VANES FOR CONDITION AND DAMAGE** |  | 0.41d | 2019-04-30 08:15 | 2019-04-30 11:07 |  | 0d |  | 2.87h |
| 60 | 59.1 | ACCESS BY AFM | manual | 112min | 2019-04-30 08:15 | 2019-04-30 10:07 | 58 |  | AFM 2 | 1.87h |
| 61 | 59.2 | DETAILED VISUAL INSPECTION OF COMPRESSOR VANES FOR CONDITION AND DAMAGE | manual | 60min | 2019-04-30 10:07 | 2019-04-30 11:07 | 60 |  | ENG | 1h |
| 62 | 60 | **DETAILED VISUAL INSPECTION OF COMPRESSOR BLADES FOR CONDITION AND DAMAGE** |  | 0.16d | 2019-04-30 10:07 | 2019-04-30 11:15 |  | 0d |  | 1.13h |
| 63 | 60.1 | ACCESS BY AFM | manual | 8min | 2019-04-30 10:07 | 2019-04-30 10:15 | 60 |  | AFM 2 | 0.13h |
| 64 | 60.2 | DETAILED VISUAL INSPECTION OF COMPRESSOR BLADES FOR CONDITION AND DAMAGE | manual | 60min | 2019-04-30 10:15 | 2019-04-30 11:15 | 63 |  | ENG | 1h |
| 65 | 61 | **DETAILED VISUAL INSPECTION OF DIFFUSER FOR CRACK OR DISCREPANCIES** |  | 0.24d | 2019-04-30 10:15 | 2019-04-30 11:55 |  | 0d |  | 1.67h |
| 66 | 61.1 | ACCESS BY AFM | manual | 40min | 2019-04-30 10:15 | 2019-04-30 10:55 | 63 |  | AFM 2 | 0.67h |
| 67 | 61.2 | DETAILED VISUAL INSPECTION OF DIFFUSER FOR CRACK OR DISCREPANCIES | manual | 60min | 2019-04-30 10:55 | 2019-04-30 11:55 | 66 |  | ENG | 1h |
| 68 | 62 | **DETAILED VISUAL INSPECTION OF THE ENGINE MOUNTS FOR CRACKS OR DETERIORATION** |  | 0.09d | 2019-04-30 10:55 | 2019-04-30 11:33 |  | 0d |  | 0.63h |
| 69 | 62.1 | ACCESS BY AFM | manual | 8min | 2019-04-30 10:55 | 2019-04-30 11:03 | 66 |  | AFM 2 | 0.13h |
| 70 | 62.2 | DETAILED VISUAL INSPECTION OF THE ENGINE MOUNTS FOR CRACKS OR DETERIORATION | manual | 30min | 2019-04-30 11:03 | 2019-04-30 11:33 | 69 |  | ENG | 0.5h |
| 71 | 63 | **FUNCTIONAL CHECK OF OXYGEN SYSTEM FOR LEAKAGE** |  | 0.01d | 2019-04-30 11:03 | 2019-04-30 11:09 |  | 0d |  | 0.1h |
| 72 | 63.1 | ACCESS BY AFM | manual | 5min | 2019-04-30 11:03 | 2019-04-30 11:08 | 69 |  | AFM 2 | 0.08h |
| 73 | 63.2 | FUNCTIONAL CHECK OF OXYGEN SYSTEM FOR LEAKAGE | manual | 1.2min | 2019-04-30 11:08 | 2019-04-30 11:09 | 72 |  | OXY | 0.02h |
| 74 | 64 | **FUNCTIONAL CHECK THE OXYGEN SUPPLY DUCT LEAKAGE** |  | 0.02d | 2019-04-30 11:08 | 2019-04-30 11:16 |  | 0d |  | 0.14h |
| 75 | 64.1 | ACCESS BY AFM | manual | 6min | 2019-04-30 11:08 | 2019-04-30 11:14 | 72 |  | AFM 2 | 0.1h |
| 76 | 64.2 | FUNCTIONAL CHECK THE OXYGEN SUPPLY DUCT LEAKAGE | manual | 2.2min | 2019-04-30 11:14 | 2019-04-30 11:16 | 75 |  | OXY | 0.04h |
| 77 | 65 | FUNCTIONAL CHECK OF DE-ICING SYSTEM TO VERIFY OPERATION OF THERMAL SWITCH ASSOCIATED CIRCUITS | manual | 11min | 2019-04-30 11:16 | 2019-04-30 11:27 | 76 |  | ELC | 0.18h |
| 78 | 66 | OPERATIONAL CHECK OF PORTABLE EMERGENCY LAMP BY CARRYING OUT FROM IT'S BAY | manual | 1min | 2019-04-30 11:27 | 2019-04-30 11:28 | 77 |  | ELC | 0.02h |
| 79 | 67 | (CLOSE) ACCESS: 413 A 413 B 413 C 413 D 413 H 413 J 423 A 423 B 423 C 423 D 423 H 423 J | manual | 56min | 2019-04-30 11:16 | 2019-04-30 13:12 | 76 |  | AFM 2 | 0.93h |
