# 5-4 A2

Schedule from MS Project, 2019-05-14 to 2019-05-16.

## Calendars

- Standard: Mon-Fri 08:00-12:00, 13:00-17:00; Sat-Sun off.

## Resources

| Resource |
| --- |
| AFM 1 |
| ENG |
| AFM 2 |
| ELC |

## Schedule

| ID | WBS | Task | Type | Duration | Start | Finish | Predecessors | Resources | Work |
| --- | --- | --- | --- | --- | --- | --- | --- | --- | --- |
| 1 | 1 | (OPEN) ACCESS: 413C, 413D, 413E, 413H, 413J, 4134D, 423C, 423D, 423E, 423H, 423J, 424D | manual | 74min | 2019-05-14 08:00 | 2019-05-14 09:14 |  | AFM 1 | 1.23h |
| 2 | 2 | GENERAL VISUAL INSPECTION OF (LH) ENGINE NACELLES AFT SECTION | manual | 108min | 2019-05-14 09:14 | 2019-05-14 11:02 | 1 | AFM 1 | 1.8h |
| 3 | 3 | GENERAL VISUAL INSPECTION OF (RH) ENGINE NACELLES AFT SECTION | manual | 108min | 2019-05-14 11:02 | 2019-05-14 13:50 | 2 | AFM 1 | 1.8h |
| 4 | 4 | GENERAL VISUAL INSPECTION OF CARGO RAMP, SEAL | manual | 95min | 2019-05-14 13:50 | 2019-05-14 15:25 | 3 | AFM 1 | 1.58h |
| 5 | 5 | DETAILED VISUAL INSPECTION OF RETAINING RODS AND SLIDERS OF RAMP DOOR FOR CONDITION | manual | 105min | 2019-05-14 15:25 | 2019-05-15 08:10 | 4 | AFM 1 | 1.75h |
| 6 | 6 | DETAILED VISUAL INSPECTION OF LOCKING HOOKS AND TORQUE TUBE OF RAMP DOOR FOR CONDITION | manual | 154min | 2019-05-15 08:10 | 2019-05-15 10:44 | 5 | AFM 1 | 2.57h |
| 7 | 7 | (OPEN) ACCESS: 911D, 911F | manual | 34min | 2019-05-15 10:44 | 2019-05-15 11:18 | 6 | AFM 1 | 0.57h |
| 8 | 8 | GENERAL VISUAL INSPECTION OF CONDITIONING COMPARTMENT | manual | 155min | 2019-05-15 11:18 | 2019-05-15 14:53 | 7 | AFM 1 | 2.58h |
| 9 | 9 | DETAILED VISUAL INSPECTION OF VENT LINE FOR DAMAGE, CRACKS AND OBSTRUCTION | manual | 7.2min | 2019-05-15 14:53 | 2019-05-15 15:00 | 8 | AFM 1 | 0.12h |
| 10 | 10 | DETAILED VISUAL INSPECTION OF DISTRIBUTION DUCT FOR CORROSION, DAMAGE AND CRACKS. | manual | 7.2min | 2019-05-15 15:00 | 2019-05-15 15:07 | 9 | AFM 1 | 0.12h |
| 11 | 11 | DETAILED VISUAL INSPECTION OF DUCT CONNECTED TO THE CONVERTER FOR CORROSION, DAMAGE AND CRACKS | manual | 7.3min | 2019-05-15 15:07 | 2019-05-15 15:14 | 10 | AFM 1 | 0.12h |
| 12 | 12 | DETAILED VISUAL INSPECTION OF SERVOMOTORS DRUM AND BRACKETS FOR PRESENCE OF CORROSION, CRACKS, DETERIORATION AND GENERAL CONDITIONS | manual | 48min | 2019-05-15 15:14 | 2019-05-15 16:02 | 11 | AFM 1 | 0.8h |
| 13 | 13 | (CLOSE) ACCESS: 413C, 413D, 413E, 413H, 413J, 4134D, 423C, 423D, 423E, 423H, 423J, 424D | manual | 74min | 2019-05-15 16:02 | 2019-05-16 08:16 | 12, 40 | AFM 1 | 1.23h |
| 14 | 14 | (CLOSE) ACCESS: 911D, 911F | manual | 34min | 2019-05-16 08:16 | 2019-05-16 08:50 | 13 | AFM 1 | 0.57h |
| 15 | 15 | FUNCTIONAL CHECK OF PRESSURIZATION SYSTEM FOR: A.OVERPRESSURE B.NEGATIVE PRESSURE | manual | 63min | 2019-05-16 08:50 | 2019-05-16 09:53 | 14, 65, 64 | AFM 1 | 1.05h |
| 16 | 16 | DETAILED VISUAL INSPECTION OF OIL SYSTEM FOR LEAKS | manual | 10min | 2019-05-16 09:53 | 2019-05-16 10:03 | 15 | AFM 1 | 0.17h |
| 17 | 17 | OPERATIONAL CHECK TO VERIFY AUTOMATIC DRAIN VALVES (ADV) FAILURE | manual | 72min | 2019-05-16 10:03 | 2019-05-16 11:15 | 16 | AFM 1 | 1.2h |
| 18 | 18 | FUNCTIONAL CHECK OF FLAP FROM HYDRAULIC SYSTEM No1 & No2 | manual | 40min | 2019-05-16 11:15 | 2019-05-16 11:55 | 17 | AFM 1 | 0.67h |
| 19 | 19 | SERVICING FOR ELEVATOR HYDRAULIC ACCUMULATOR CHARGE | manual | 5min | 2019-05-16 11:55 | 2019-05-16 13:00 | 18 | AFM 1 | 0.08h |
| 20 | 20 | FUNCTIONAL CHECK OF ELEVATOR CONTROL TO VERIFY THE CORRECT ARTIFICIAL FORCE IN THE TOTAL OPERATIVE ENVELOP | manual | 34min | 2019-05-16 13:00 | 2019-05-16 13:34 | 19 | AFM 1 | 0.57h |
| 21 | 21 | FUNCTIONAL CHECK TO VERIFY THE STOP FUNCTION AT THE END OF FLAP TRAVEL | manual | 10min | 2019-05-16 13:34 | 2019-05-16 13:44 | 20 | AFM 1 | 0.17h |
| 22 | 22 | FUNCTIONAL CHECK OF SPOILERS FOR CORRECT EXTENSION | manual | 20min | 2019-05-16 13:44 | 2019-05-16 14:04 | 21 | AFM 1 | 0.33h |
| 23 | 23 | CHECK OF SYSTEM SPOILER FOR: A.BY-PASS CORRECT FUNCTION B.BUNGEE AND MIXER BOX MOVEMENT FOR CORRECT OPERATION | manual | 30min | 2019-05-16 14:04 | 2019-05-16 14:34 | 22 | AFM 1 | 0.5h |
| 24 | 24 | OPERATIONAL CHECK OF FUEL PUMP WORKING | manual | 15min | 2019-05-16 14:34 | 2019-05-16 14:49 | 23 | AFM 1 | 0.25h |
| 25 | 25 | OPERATIONAL CHECK TO VERIFY TANK FULL AUTOMATIC REFUEL CUT-OFF | manual | 16min | 2019-05-16 14:49 | 2019-05-16 15:05 | 24 | AFM 1 | 0.27h |

| ID | WBS | Task | Type | Duration | Start | Finish | Predecessors | Total slack | Resources | Work |
| --- | --- | --- | --- | --- | --- | --- | --- | --- | --- | --- |
| 26 | 26 | **DETAILED VISUAL INSPECTION OF GROUNDING STRAPS** |  | 0.12d | 2019-05-14 08:00 | 2019-05-14 09:00 | 3 | 0d | ENG | 2h |
| 27 | 26.1 | GENERAL VISUAL INSPECTION BY ENG | manual | 60min | 2019-05-14 08:00 | 2019-05-14 09:00 |  |  | ENG | 1h |
| 28 | 27 | **DETAILED VISUAL INSPECTION OF REAR TURBINE BEARING OIL SCAVENGE TUBE FOR ANY SIGN OF OIL LEAKAGE** |  | 42min | 2019-05-14 08:00 | 2019-05-14 08:42 | 26 |  | ENG | 1.2h |
| 29 | 27.1 | GENERAL VISUAL INSPECTION BY ENG | manual | 30min | 2019-05-14 08:00 | 2019-05-14 08:30 |  |  | ENG | 0.5h |
| 30 | 28 | **DETAILED VISUAL INSPECTION OF EXTERNAL PORTION OF REAR TURBINE BEARING SUPPORT FOR SECURITY AND GENERAL CONDITION** |  | 0.06d | 2019-05-14 08:00 | 2019-05-14 08:30 | 28 | 0d | ENG | 1h |
| 31 | 28.1 | GENERAL VISUAL INSPECTION BY ENG | manual | 30min | 2019-05-14 08:00 | 2019-05-14 08:30 |  |  | ENG | 0.5h |
| 32 | 29 | **DETAILED VISUAL INSPECTION OF EXTERNAL PORTION OF THE REAR TURBINE BEARING SUPPORT FOR OIL LEAKAGE** |  | 0.06d | 2019-05-14 08:00 | 2019-05-14 08:30 | 30 | 0d | ENG | 1h |
| 33 | 29.1 | GENERAL VISUAL INSPECTION BY ENG | manual | 30min | 2019-05-14 08:00 | 2019-05-14 08:30 |  |  | ENG | 0.5h |
| 34 | 30 | **GENERAL VISUAL INSPECTION OF TUBES AND HOSES ASSEMBLY FOR SECURITY AND CONDITION** |  | 0.1d | 2019-05-14 08:00 | 2019-05-14 08:47 | 32 | 0d | ENG | 1.57h |
| 35 | 30.1 | GENERAL VISUAL INSPECTION BY ENG | manual | 47min | 2019-05-14 08:00 | 2019-05-14 08:47 |  |  | ENG | 0.78h |
| 36 | 31 | **DETAILED VISUAL INSPECTION OF INLET GUIDE VANES AND COMPRESSOR BLADES** |  | 0.13d | 2019-05-14 08:00 | 2019-05-14 09:04 | 34 | 0d | ENG | 2.13h |
| 37 | 31.1 | GENERAL VISUAL INSPECTION BY ENG | manual | 64min | 2019-05-14 08:00 | 2019-05-14 09:04 |  |  | ENG | 1.07h |
| 38 | 32 | **DETAILED VISUAL INSPECTION OF COMBUSTION LINER AND DIFFUSER CASE** |  | 0.13d | 2019-05-14 08:00 | 2019-05-14 09:04 | 36 | 0d | ENG | 2.13h |
| 39 | 32.1 | GENERAL VISUAL INSPECTION BY ENG | manual | 64min | 2019-05-14 08:00 | 2019-05-14 09:04 |  |  | ENG | 1.07h |
| 40 | 33 | **DETAILED VISUAL INSPECTION OF OIL SYSTEM FOR LEAKS** |  | 0.02d | 2019-05-14 08:00 | 2019-05-14 08:10 | 38 | 0d | ENG | 0.33h |
| 41 | 33.1 | GENERAL VISUAL INSPECTION BY ENG | manual | 10min | 2019-05-14 08:00 | 2019-05-14 08:10 |  |  | ENG | 0.17h |
| 42 | 34 | FUNCTIONAL CHECK OF ENGINE AND PROPELLER ANTI-ICE SYSTEMS | manual | 10min | 2019-05-14 08:00 | 2019-05-14 08:10 |  |  | ENG | 0.17h |
| 43 | 35 | DETAILED VISUAL INSPECTION OF CARGO DOOR, DOWNLOCKING HOOKS, PIN AND FIXED HOOKS FOR CONDITION | manual | 75min | 2019-05-14 08:00 | 2019-05-14 09:15 |  |  | AFM 2 | 1.25h |
| 44 | 36 | GENERAL VISUAL INSPECTION OF COCKPIT (FRAME 1 TO FRAME 7) | manual | 50.2min | 2019-05-14 09:15 | 2019-05-14 10:05 | 43 |  | AFM 2 | 0.84h |
| 45 | 37 | GENERAL VISUAL INSPECTION OF CREW DOOR, HINGE, SEAL AND COMPENSATION DEVICE ASSY | manual | 47min | 2019-05-14 10:05 | 2019-05-14 10:52 | 44 |  | AFM 2 | 0.78h |
| 46 | 38 | DETAILED VISUAL INSPECTION OF CREW ENTRY DOOR FOR CONDITION OF THE A.CREW DOOR DEVICES B.BRACING CABLES C.HINGE AND COMPENSATION MECHANISM | manual | 139min | 2019-05-14 10:52 | 2019-05-14 14:11 | 45 |  | AFM 2 | 2.32h |
| 47 | 39 | DETAILED VISUAL INSPECTION OF CREW ENTRY DOOR FOR CONDITION OF THE A.CREW DOOR DEVICES B.BRACING CABLES C.HINGE AND COMPENSATION MECHANISM | manual | 1min | 2019-05-14 14:11 | 2019-05-14 14:12 | 46 |  | AFM 2 | 0.02h |
| 48 | 40 | GENERAL VISUAL INSPECTION OF EMERGENCY EXIT DOOR, SEAL | manual | 15min | 2019-05-14 14:12 | 2019-05-14 14:27 | 47 |  | AFM 2 | 0.25h |
| 49 | 41 | DETAILED VISUAL INSPECTION OF EMERGENCY EXIT DOOR MECHANISM FOR CONDITION | manual | 27min | 2019-05-14 14:27 | 2019-05-14 14:54 | 48 |  | AFM 2 | 0.45h |
| 50 | 42 | OPERATIONAL CHECK OF EMERGENCY EXIT DOOR | manual | 2min | 2019-05-14 14:54 | 2019-05-14 14:56 | 49 |  | AFM 2 | 0.03h |
| 51 | 43 | GENERAL VISUAL INSPECTION OF (LH) PARATROOPS DOOR, SEAL, INTERNAL STRUCTURE AND COMPONENTS | manual | 30min | 2019-05-14 14:56 | 2019-05-14 15:26 | 50 |  | AFM 2 | 0.5h |
| 52 | 44 | GENERAL VISUAL INSPECTION OF (RH) PARATROOPS DOOR, SEAL, INTERNAL STRUCTURE AND COMPONENTS | manual | 30min | 2019-05-14 15:26 | 2019-05-14 15:56 | 51 |  | AFM 2 | 0.5h |
| 53 | 45 | FUNCTIONAL CHECK OF REAR LATERAL DOORS OPERATION | manual | 10min | 2019-05-14 15:56 | 2019-05-14 16:06 | 52 |  | AFM 2 | 0.17h |
| 54 | 46 | GENERAL VISUAL INSPECTION OF EMERGENCY EXIT, SEAL (UPPER FUSELAGE) | manual | 15min | 2019-05-14 16:06 | 2019-05-14 16:21 | 53 |  | AFM 2 | 0.25h |
| 55 | 47 | GENERAL VISUAL INSPECTION OF CARGO COMPARTMENT EMERGENCY EXIT, SEAL (UPPER FUSELAGE-FWD EXIT) | manual | 15min | 2019-05-14 16:21 | 2019-05-14 16:36 | 54 |  | AFM 2 | 0.25h |
| 56 | 48 | GENERAL VISUAL INSPECTION OF CARGO COMPARTMENT EMERGENCY EXIT, SEAL (UPPER FUSELAGE-AFT EXIT) | manual | 15min | 2019-05-14 16:36 | 2019-05-14 16:51 | 55 |  | AFM 2 | 0.25h |
| 57 | 49 | DETAILED VISUAL INSPECTION FOR CONDITION OF EMERGENCY EXIT HATCHES MECHANISM | manual | 66min | 2019-05-14 16:51 | 2019-05-15 08:57 | 56 |  | AFM 2 | 1.1h |
| 58 | 50 | OPERATIONAL CHECK OF EMERGENCY EXIT HATCHES | manual | 6min | 2019-05-15 08:57 | 2019-05-15 09:03 | 57 |  | AFM 2 | 0.1h |
| 59 | 51 | DETAILED VISUAL INSPECTION FOR CONDITION OF BATTERY COMPARTMENT ACCESS HINGE AND BATTERY SUPPORT | manual | 11min | 2019-05-15 09:03 | 2019-05-15 09:14 | 58 |  | AFM 2 | 0.18h |
| 60 | 52 | DETAILED VISUAL INSPECTION OF MASK AND RELATED HOSE FOR CORROSION, DAMAGE AND CRACKS | manual | 5min | 2019-05-15 09:14 | 2019-05-15 09:19 | 59 |  | AFM 2 | 0.08h |
| 61 | 53 | DETAILED VISUAL INSPECTION OF SMOKE GOGGLES FOR CORROSION AND GENERAL DAMAGE | manual | 5min | 2019-05-15 09:19 | 2019-05-15 09:24 | 60 |  | AFM 2 | 0.08h |
| 62 | 54 | DETAILED VISUAL INSPECTION FOR CONDITION OF DOOR HINGE AND BAY EMERGENCY LIFERAFT | manual | 29min | 2019-05-15 09:24 | 2019-05-15 09:53 | 61 |  | AFM 2 | 0.48h |
| 63 | 55 | GENERAL VISUAL INSPECTION OF CARGO COMPARTMENT UNDERFLOOR (FRAME 7 TO FRAME 29) | manual | 173min | 2019-05-15 09:53 | 2019-05-15 13:46 | 62 |  | AFM 2 | 2.88h |
| 64 | 56 | DETAILED VISUAL INSPECTION FOR GENERAL CONDITION OF NOSE GEAR STEERING SYSTEM | manual | 12.2min | 2019-05-15 13:46 | 2019-05-15 13:58 | 63 |  | AFM 2 | 0.2h |
| 65 | 57 | CLEANING OF SMOKE DETECTORS | manual | 60min | 2019-05-15 13:46 | 2019-05-15 14:46 | 63 |  | ELC | 1h |
| 66 | 58 | FUNCTIONAL CHECK OF VISUAL ICE DETECTOR | manual | 5min | 2019-05-16 15:05 | 2019-05-16 15:10 | 25 |  | ELC | 0.08h |
| 67 | 59 | OPERATIONAL CHECK OF POSITION LIGHT SYSTEM | manual | 1min | 2019-05-16 15:10 | 2019-05-16 15:11 | 66 |  | ELC | 0.02h |
| 68 | 60 | FUNCTIONAL CHECK OF CARGO SMOKE DETECTORS FOR PROPER FUNCTION | manual | 10min | 2019-05-16 15:11 | 2019-05-16 15:21 | 67 |  | ELC | 0.17h |
| 69 | 61 | FUNCTIONAL CHECK OF LAVATORY SMOKE DETECTOR FOR PROPER FUNCTION | manual | 1min | 2019-05-16 15:21 | 2019-05-16 15:22 | 68 |  | ELC | 0.02h |
| 70 | 62 | OPERATIONAL CHECK OF APU REMOTE FIRE EXTINGUISH SWITCH AND ASSOCIATED CIRCUIT | manual | 42min | 2019-05-16 15:22 | 2019-05-16 16:04 | 69 |  | ELC | 0.7h |
| 71 | 63 | OPERATIONAL CHECK OF APU T-HANDLE AND FIRE EXTINGUISHER CIRCUIT FOR PROPER FUNCTION | manual | 41min | 2019-05-16 16:04 | 2019-05-16 16:45 | 70 |  | ELC | 0.68h |
| 72 | 64 | FUNCTIONAL CHECK OF OVERBOARD VALVE | manual | 6min | 2019-05-16 16:45 | 2019-05-16 16:51 | 71 |  | ELC | 0.1h |
