# 5-40 HS1-HS2

Schedule from MS Project, 2019-05-13 to 2019-05-16.

## Calendars

- Standard: Mon-Fri 08:00-12:00, 13:00-17:00; Sat-Sun off.

## Resources

| Resource |
| --- |
| AFM 1 |
| AFM 2 |
| OXY |
| ENG |
| ELC |
| AVI |

## Schedule

| ID | Task | Type | Duration | Start | Finish | Predecessors | Resources | Work |
| --- | --- | --- | --- | --- | --- | --- | --- | --- |
| 1 | GENERAL VISUAL INSPECTION OF COCKPIT (FR1 TO FR 7) A.AVIONICS DAMPING SUPPORT B.CREW SEAT BELT/OBSERVER SEAT BELTS AND ASSOCIATED MECHANISM C.PARKING/EMERGENCY BRAKE SYSTEM | manual | 71.2min | 2019-05-13 08:00 | 2019-05-13 09:11 |  | AFM 1 | 1.19h |
| 2 | GENERAL VISUAL INSPECTION OF EXTERNAL ZONE A.CREW,PARATROOP DOOR. B.EMERGENCY EXITS C.RAMP AND CARGO DOOR | manual | 3min | 2019-05-13 09:11 | 2019-05-13 09:14 | 1 | AFM 1 | 0.05h |
| 3 | GENERAL VISUAL INSPECTION OF CREW ENTRANCE (FR 7 TO FR 98) | manual | 60min | 2019-05-13 09:14 | 2019-05-13 10:14 | 2 | AFM 1 | 1h |
| 4 | GENERAL VISUAL INSPECTION OF CARGO COMPT. (FR 9B TO FR 16) | manual | 105min | 2019-05-13 10:14 | 2019-05-13 11:59 | 3 | AFM 1 | 1.75h |
| 5 | GENERAL VISUAL INSPECTION OF CARGO COMPT. (FR 16 TO FR 23) | manual | 80min | 2019-05-13 11:59 | 2019-05-13 14:19 | 4 | AFM 1 | 1.33h |
| 6 | GENERAL VISUAL INSPECTION OF CARGO COMPT. (FR 23 TO FR 26) | manual | 73min | 2019-05-13 14:19 | 2019-05-13 15:32 | 5 | AFM 1 | 1.22h |
| 7 | GENERAL VISUAL INSPECTION OF AFT FUSELAGE SECTION (FR 29 TO FR 47) | manual | 100min | 2019-05-13 15:32 | 2019-05-14 08:12 | 6 | AFM 1 | 1.67h |
| 8 | DETAILED VISUAL INSPECTION OF ELEVATOR JAM OVERRIDE MECHANISM (JOM) FOR CONDITION | manual | 5min | 2019-05-14 08:12 | 2019-05-14 08:17 | 7 | AFM 1 | 0.08h |
| 9 | GENERAL VISUAL INSPECTION OF STATIC SYSTEM NORMAL BREAKING FOR CORRECT OIL LEVEL AND LEAKAGE | manual | 18min | 2019-05-14 08:17 | 2019-05-14 08:35 | 8 | AFM 1 | 0.3h |
| 10 | LUBRICATION OF RUDDER INTERCONNECTION RODS. | manual | 118min | 2019-05-14 08:35 | 2019-05-14 10:33 | 9 | AFM 1 | 1.97h |
| 11 | LUBRICATION OF GUST LOCK MECHANICAL LINKAGE | manual | 43.2min | 2019-05-14 10:33 | 2019-05-14 11:16 | 10 | AFM 1 | 0.72h |
| 12 | CHECK OF AILERONS CABLE FOR CORRECT TENSION INCLUDED THE AUTOPILOT ACTUATOR CABLE | manual | 109min | 2019-05-14 11:16 | 2019-05-14 14:05 | 11 | AFM 1 | 1.82h |
| 13 | LUBRICATION OF ALL MECHANICAL LINKAGE AND CABLE | manual | 251min | 2019-05-14 14:05 | 2019-05-15 09:16 | 12 | AFM 1 | 4.18h |
| 14 | UBRICATION OF FLAPS MECHANICAL LINKAGE AND ROLLER /GUIDE | manual | 91min | 2019-05-15 09:16 | 2019-05-15 10:47 | 13 | AFM 1 | 1.52h |
| 15 | LUBRICATION OF AILERON MECHANICAL 10 LINKAGE IN WING (RODS, BELL CRANKS, LEVERS, HINGES) | manual | 58min | 2019-05-15 10:47 | 2019-05-15 11:45 | 14 | AFM 1 | 0.97h |
| 16 | DETAIL VISUAL INSPECTION OF LIFE RAFT ACCESS PANEL LOCKING FOR CONDITION, CORROSIO, CRACKS & WEAR | manual | 30min | 2019-05-15 11:45 | 2019-05-15 13:15 | 15 | AFM 1 | 0.5h |
| 17 | FUNCTIONAL CHECK OF LIFE-RAFT DOOR UNLOCKING | manual | 31min | 2019-05-15 13:15 | 2019-05-15 13:46 | 16 | AFM 1 | 0.52h |
| 18 | FUNCTIONAL CHECK OF EMERGENCY EXTENSION MECHANICAL LINKAGE | manual | 48min | 2019-05-15 13:46 | 2019-05-15 14:34 | 17 | AFM 1 | 0.8h |
| 19 | FUNCTIONAL CHECK OF FLAP ASYMMETRY CONTROL SYSTEM | manual | 24.3min | 2019-05-15 14:34 | 2019-05-15 14:58 | 18 | AFM 1 | 0.41h |
| 20 | OPERATIONAL CHECK OF HYDRAULIC SYSTEM No1 & No2 SHUT-OFF VALVE | manual | 14min | 2019-05-15 14:58 | 2019-05-15 15:12 | 19 | AFM 1 | 0.23h |
| 21 | FUNCTIONAL CHECK OF RUDDER CENTERING SPRING IN ORDER TO VERIFY THE RETURN TO "0" POSITION WITHOUT PILOT LINK | manual | 9min | 2019-05-15 15:12 | 2019-05-15 15:21 | 20 | AFM 1 | 0.15h |
| 22 | FUNCTIONAL CHECK OF RUDDER TRAVEL LIMITATION UNIT (RTLU) SYSTEM, RELATIVE WARNING AND OVERRIDE SWITCH FOR CORRECT OPERATION | manual | 41min | 2019-05-15 15:21 | 2019-05-15 16:02 | 21 | AFM 1 | 0.68h |
| 23 | OPERATIONAL CHECK OF TRIM-RUDDER EMERGENCY FUNCTION | manual | 13min | 2019-05-15 16:02 | 2019-05-15 16:15 | 22 | AFM 1 | 0.22h |
| 24 | FUNCTIONAL CHECK OF FLAP FROM HYDRAULIC SYSTEM No1 & No2 | manual | 7min | 2019-05-15 16:15 | 2019-05-15 16:22 | 23 | AFM 1 | 0.12h |
| 25 | OPERATIONAL CHECK OF COCKPIT PRIORITY VALVE | manual | 8min | 2019-05-15 16:22 | 2019-05-15 16:30 | 24 | AFM 1 | 0.13h |
| 26 | OPERATIONAL CHECK OF RAM AIR EMERGENCY VENTILATION VALVE | manual | 4min | 2019-05-15 16:30 | 2019-05-15 16:34 | 25 | AFM 1 | 0.07h |
| 27 | FUNCTIONAL CHECK OF HEATING ELEMENT OF PROBE TOTAL AIR TEMPERATURE (TAT) | manual | 6min | 2019-05-15 16:34 | 2019-05-15 16:40 | 26 | AFM 1 | 0.1h |
| 28 | OPERATIONAL CHECK OF TRIANGULAR WINDOWS AND SLIDING WINDOW HEATING | manual | 9min | 2019-05-15 16:40 | 2019-05-15 16:49 | 27 | AFM 1 | 0.15h |
| 29 | FUNCTIONAL CHECK OF JETTISON SYSTEM | manual | 16min | 2019-05-15 16:49 | 2019-05-16 08:05 | 28 | AFM 1 | 0.27h |
| 30 | CHECK OF TRIM-TAB AILERON TRAVEL | manual | 9min | 2019-05-16 08:05 | 2019-05-16 08:14 | 29 | AFM 1 | 0.15h |
| 31 | FUNCTIONAL CHECK OF FLAP POSITION INDICATOR | manual | 41min | 2019-05-16 08:14 | 2019-05-16 08:55 | 30 | AFM 1 | 0.68h |
| 32 | OPERATIONAL CHECK OF STALL WARNING STICK SHACKER (SWS) SYSTEM FOR CORRECT FUNCTION | manual | 5min | 2019-05-16 08:55 | 2019-05-16 09:00 | 31 | AFM 1 | 0.08h |
| 33 | FUNCTIONAL CHECK OF: A.GND / AIR RELAY OF PITOT PROBES B.CURRENT SENSOR INDICATING (PITOT, AOA) | manual | 7min | 2019-05-16 09:00 | 2019-05-16 09:07 | 32 | AFM 1 | 0.12h |
| 34 | GENERAL VISUAL INSPECTION OF ENGINE FWD SECTION. | manual | 83min | 2019-05-13 08:00 | 2019-05-13 09:23 |  | AFM 2 | 1.38h |
| 35 | GENERAL VISUAL INSPECTION OF ENGINE NACELLES FWD SECTION | manual | 83min | 2019-05-13 09:23 | 2019-05-13 10:46 | 34 | AFM 2 | 1.38h |
| 36 | DETAILED VISUAL INSPECTION OF FIREWALL SEAL FOR CONDITION AND SECURITY | manual | 55min | 2019-05-13 10:46 | 2019-05-13 11:41 | 35 | AFM 2 | 0.92h |
| 37 | DRAINING OF HYDRAULIC FLUID FOR SAMPLING PROSEDURE (SOAP) | manual | 188min | 2019-05-13 11:41 | 2019-05-13 15:49 | 36 | AFM 2 | 3.13h |
| 38 | FUNCTIONAL CHECK OF V-BAND CLAMP BOLT TORQUE | manual | 145min | 2019-05-13 15:49 | 2019-05-14 09:14 | 37 | AFM 2 | 2.42h |
| 39 | DETAILED VISUAL INSPECTION FOR CORRECT PRE-CHARGE VALUE OF EMERGENCY BRAKE ACCUMULATOR | manual | 6min | 2019-05-14 09:14 | 2019-05-14 09:20 | 38 | AFM 2 | 0.1h |
| 40 | GENERAL VISUAL INSPECTION OF A.P.U. COMPARTMENT. | manual | 2min | 2019-05-14 09:20 | 2019-05-14 09:22 | 39 | AFM 2 | 0.03h |
| 41 | A DETAILED VISUAL INSPECTION OF APU MOUNT FOR CORROSION AND WEAR B.AP.U. SHOCK ABSORBER DIMENSIONAL CHECK. | manual | 103min | 2019-05-14 09:22 | 2019-05-14 11:05 | 40 | AFM 2 | 1.72h |
| 42 | REPLACEMENT OIL OF A.P.U | manual | 95min | 2019-05-14 11:05 | 2019-05-14 13:40 | 41 | AFM 2 | 1.58h |
| 43 | DETAILED VISUAL INSPECTION OF APU INLET DOOR | manual | 47min | 2019-05-14 13:40 | 2019-05-14 14:27 | 42 | AFM 2 | 0.78h |
| 44 | DETAILED VISUAL INSPECTION OF AIR INLET SCREEN FOR OBSTRUCTION AND DAMAGE | manual | 1min | 2019-05-14 14:27 | 2019-05-14 14:28 | 43 | AFM 2 | 0.02h |
| 45 | DETAILED VISUAL INSPECTION OF APU FILTER DISASSEMBLED FOR CONDITION AND OBSTRUCTION | manual | 31min | 2019-05-14 14:28 | 2019-05-14 14:59 | 44 | AFM 2 | 0.52h |
| 46 | CHECK OF ELEVATOR HYDRAULIC ACCUMULATOR SHUT-OFF VALVE | manual | 7min | 2019-05-14 14:59 | 2019-05-14 15:06 | 45 | AFM 2 | 0.12h |
| 47 | FUNCTIONAL TEST OF ELEVATOR JAM OVERRIDE MECHANISM (JAM) FOR PROPER FUNCTION | manual | 11.3min | 2019-05-14 15:06 | 2019-05-14 15:17 | 46 | AFM 2 | 0.19h |
| 48 | LUBRICATION OF TRIM-RUDDER MECHANISM. | manual | 22min | 2019-05-14 15:17 | 2019-05-14 15:39 | 47 | AFM 2 | 0.37h |
| 49 | PERFORM THE LEAK TEST OF PORTABLE OXYGEN BOTTLES | manual | 5min | 2019-05-15 13:15 | 2019-05-15 13:20 | 16 | OXY | 0.08h |
| 50 | A.TEST THE DEMAND-FLOW OXYGEN REGULATOR AND MASKS B.TEST LIQUID OXYGEN QUANTITY INDICATOR | manual | 13.3min | 2019-05-15 13:20 | 2019-05-15 13:33 | 49 | OXY | 0.22h |
| 51 | FUNCTIONAL CHECK OF CARGO OXYGEN SYSTEM FOR PROPER FUNCTION | manual | 32.2min | 2019-05-15 13:33 | 2019-05-15 14:05 | 50 | OXY | 0.54h |
| 52 | GENERAL VISUAL INSPECTION OF (LH) ENGINE FWD SECTION | manual | 9min | 2019-05-14 09:14 | 2019-05-14 09:23 | 38 | ENG | 0.15h |
| 53 | GENERAL VISUAL INSPECTION OF (LH) PROPELLER | manual | 2min | 2019-05-14 09:23 | 2019-05-14 09:25 | 52 | ENG | 0.03h |
| 54 | GENERAL VISUAL INSPECTION OF (RH) ENGINE FWD SECTION | manual | 9min | 2019-05-14 09:25 | 2019-05-14 09:34 | 53 | ENG | 0.15h |
| 55 | GENERAL VISUAL INSPECTION OF (RH) PROPELLER | manual | 2min | 2019-05-14 09:34 | 2019-05-14 09:36 | 54 | ENG | 0.03h |
| 56 | FUNCTIONAL TEST OF A.P.U. TEMPERATURE COMPENSATED PRESSURE SWITCH (T.C.P.S.) | manual | 29min | 2019-05-16 09:07 | 2019-05-16 09:36 | 33, 51 | ELC | 0.48h |
| 57 | FUNCTIONAL CHECK OF EMERGENCY LOCATOR TRANSMITTER (E.L.T.) SYSTEM | manual | 87min | 2019-05-16 09:36 | 2019-05-16 11:03 | 56 | ELC | 1.45h |
| 58 | FUNCTIONAL TEST OF ENGINE TEMPERATURE COMPENSATED PRESSURE SWITCH (T.C.P.S.). | manual | 29min | 2019-05-16 11:03 | 2019-05-16 11:32 | 57 | ELC | 0.48h |
| 59 | OPERATION CHECK OF:1.GENERATOR CONTROL UNIT (G.C.U.)BITE TEST 2.BUS POWER CONTROL UNIT (B.P.C.U.) BITE TEST | manual | 2min | 2019-05-16 11:32 | 2019-05-16 11:34 | 58 | ELC | 0.03h |
| 60 | OPERATIONAL CHECK OF P.D.U (POWER DISTRIBUTION UNIT) BITE TEST | manual | 2min | 2019-05-16 11:34 | 2019-05-16 11:36 | 59 | ELC | 0.03h |
| 61 | OPERATIONAL CHECK OF OVRD FUNCTION | manual | 1min | 2019-05-16 11:36 | 2019-05-16 11:37 | 60 | ELC | 0.02h |
| 62 | OPERATIONAL CHECK OF BUS TIE CONTACTOR (BTC) | manual | 1min | 2019-05-16 11:37 | 2019-05-16 11:38 | 61 | ELC | 0.02h |
| 63 | FUNCTIONAL TEST OF STBY TRANSFORMER RECTIFIER UNITS (TRU) SUPPLY CHECK | manual | 5min | 2019-05-16 11:38 | 2019-05-16 11:43 | 62 | ELC | 0.08h |
| 64 | FUNCTIONAL CHECK OF EMERGENCY LOCATOR TRANSMITTER (E.L.T.) SYSTEM | manual | 2min | 2019-05-16 11:43 | 2019-05-16 11:45 | 63 | AVI | 0.03h |
