# 5-41 HS1-A1

Schedule from MS Project, 2019-05-13 to 2019-05-20.

## Calendars

- Standard: Mon-Fri 08:00-12:00, 13:00-17:00; Sat-Sun off.

## Resources

| Resource |
| --- |
| AFM 1 |
| AFM 2 |
| ENG |
| AVI |
| ELC |
| OXY |
| AFM1 |

## Schedule

| ID | Task | Type | Duration | Start | Finish | Predecessors | Resources | Work |
| --- | --- | --- | --- | --- | --- | --- | --- | --- |
| 1 | GENERAL VISUAL INSPECTION OF CARGO COMPARTMENT UNDERFLOOR (FRAME 7 TO FRAME 29) | manual | 147min | 2019-05-13 08:00 | 2019-05-13 10:27 |  | AFM 1 | 2.45h |
| 2 | LUBRICATION OF RUDDER INTERCONNECTION RODS. | manual | 118min | 2019-05-13 10:27 | 2019-05-13 13:25 | 1 | AFM 1 | 1.97h |
| 3 | DETAILED VISUAL INSPECTION FOR DELAMINATION, CRACK AND CRAZING OF CARGO COMPARTMENT WINDOWS | manual | 6min | 2019-05-13 13:25 | 2019-05-13 13:31 | 2 | AFM 1 | 0.1h |
| 4 | DETAIL VISUAL INSPECTION OF CARGO COMPARTMENT EMERGENCY EQUIPMENT FOR CONDITION | manual | 5min | 2019-05-13 13:31 | 2019-05-13 13:36 | 3 | AFM 1 | 0.08h |
| 5 | DETAILED VISUAL INSPECTION FOR CORROSION AND CONDITION ON TELESCOPIC ROD OF THE FLAPS AIRFOIL UNDERSIDE DOORS AND RELATIVE ATTACHMENTS | manual | 39min | 2019-05-13 13:36 | 2019-05-13 14:15 | 4 | AFM 1 | 0.65h |
| 6 | DETAILED VISUAL INSPECTION OF WATER TANK FOR CRACKS/CUTS CHAFFING | manual | 10min | 2019-05-13 14:15 | 2019-05-13 14:25 | 5 | AFM 1 | 0.17h |
| 7 | DETAIL VISUAL INSPECTION OF CARGO COMPARTMENT EMERGENCY EQUIPMENT FOR CONDITION | manual | 5min | 2019-05-13 14:25 | 2019-05-13 14:30 | 6 | AFM 1 | 0.08h |
| 8 | LUBRICATION OF LIFE RAFT BAY DOOR HINGE | manual | 29min | 2019-05-13 14:30 | 2019-05-13 14:59 | 7 | AFM 1 | 0.48h |
| 9 | LUBRICATION HINGES, LATCHES AND COMPENSATION MECHANISM OF CREW DOOR | manual | 81min | 2019-05-13 14:59 | 2019-05-13 16:20 | 8 | AFM 1 | 1.35h |
| 10 | GENERAL VISUAL INSPECTION OF EXTERNAL ZONE A.CREW,PARATROOP DOOR. B.EMERGENCY EXITS C.RAMP AND CARGO DOOR | manual | 3min | 2019-05-13 16:20 | 2019-05-13 16:23 | 9 | AFM 1 | 0.05h |
| 11 | OPERATIONAL TEST OF SLIDING WINDOWS UNLOCKING | manual | 2min | 2019-05-13 16:23 | 2019-05-13 16:25 | 10 | AFM 1 | 0.03h |
| 12 | GENERAL VISUAL INSPECTION OF CARGO COMPARTMENT (FRAME 26 TO FRAME 29) | manual | 25min | 2019-05-13 16:25 | 2019-05-13 16:50 | 11 | AFM 1 | 0.42h |
| 13 | GENERAL VISUAL INSPECTION OF VERTICAL EMPENNAGE (RUDDER & FIN) | manual | 94min | 2019-05-13 16:50 | 2019-05-14 09:24 | 12 | AFM 1 | 1.57h |
| 14 | GENERAL VISUAL INSPECTION OF (LH) MAIN LANDING GEAR NACELLE COMPARTMENT AND HYDRAULIC SYSTEM COMPONENTS | manual | 134min | 2019-05-14 09:24 | 2019-05-14 11:38 | 13 | AFM 1 | 2.23h |
| 15 | GENERAL VISUAL INSPECTION OF (LH) HORIZONTAL EMPENNAGE (STABILIZER & ELEVATOR) | manual | 85min | 2019-05-14 11:38 | 2019-05-14 14:03 | 14 | AFM 1 | 1.42h |
| 16 | LUBRICATION OF TRIM-RUDDER MECHANISM. | manual | 22min | 2019-05-14 14:03 | 2019-05-14 14:25 | 15 | AFM 1 | 0.37h |
| 17 | GENERAL VISUAL INSPECTION OF (RH) HORIZONTAL EMPENNAGE (STABILIZER & ELEVATOR) | manual | 85min | 2019-05-14 14:25 | 2019-05-14 15:50 | 16 | AFM 1 | 1.42h |
| 18 | GENERAL VISUAL INSPECTION OF (LH) WING LEADING EDGE | manual | 217min | 2019-05-14 15:50 | 2019-05-15 10:27 | 17 | AFM 1 | 3.62h |
| 19 | GENERAL VISUAL INSPECTION OF (RH) WING LEADING EDGE | manual | 217min | 2019-05-15 10:27 | 2019-05-15 15:04 | 18 | AFM1 | 3.62h |
| 20 | DETAIL VISUAL INSPECTION OF LIFE RAFT ACCESS PANEL LOCKING FOR CONDITION, CORROSIO, CRACKS & WEAR | manual | 30min | 2019-05-15 15:04 | 2019-05-15 15:34 | 19 | AFM 1 | 0.5h |
| 21 | FUNCTIONAL CHECK OF LIFE-RAFT DOOR UNLOCKING | manual | 31min | 2019-05-15 15:34 | 2019-05-15 16:05 | 20 | AFM 1 | 0.52h |
| 22 | LUBRICATION THE HINGE OF BATTERY COMPARTMENT ACCESS | manual | 16min | 2019-05-15 16:05 | 2019-05-15 16:21 | 21 | AFM 1 | 0.27h |
| 23 | GENERAL VISUAL INSPECTION OF CARGO DOOR, STORAGE FITTINGS, SEAL AND HINGES | manual | 15min | 2019-05-15 16:21 | 2019-05-15 16:36 | 22 | AFM 1 | 0.25h |
| 24 | LUBRICATION OF ALL MECHANICAL LINKAGE AND CABLE | manual | 251min | 2019-05-15 16:36 | 2019-05-16 11:47 | 23 | AFM 1 | 4.18h |
| 25 | LUBRICATION OF GUST LOCK MECHANICAL LINKAGE | manual | 43.2min | 2019-05-16 11:47 | 2019-05-16 13:30 | 24 | AFM 1 | 0.72h |
| 26 | LUBRICATION OF SIDE EMERGENCY EXIT DOOR MECHANISM | manual | 334min | 2019-05-16 13:30 | 2019-05-17 10:04 | 25 | AFM 1 | 5.57h |
| 27 | LUBRICATION OF EMERGENCY EXIT HATCHES MECHANISM | manual | 72min | 2019-05-17 10:04 | 2019-05-17 11:16 | 26 | AFM 1 | 1.2h |
| 28 | LUBRICATION OF CARGO DOOR HINGES, DOWNLOCKING HOOKS, UPLOCKING HOOK AND FIXED HOOKS | manual | 20min | 2019-05-17 11:16 | 2019-05-17 11:36 | 27 | AFM 1 | 0.33h |
| 29 | DETAILED VISUAL INSPECTION FOR CORROSION OF FUSELAGE CENTER SECTION BEAM BETWEEN FRAMES 20-22 | manual | 40min | 2019-05-17 11:36 | 2019-05-17 13:16 | 28 | AFM 1 | 0.67h |
| 30 | LUBRICATION OF REAR LATERAL DOORS MECHANISM | manual | 105min | 2019-05-17 13:16 | 2019-05-17 15:01 | 29 | AFM 1 | 1.75h |
| 31 | LUBRICATION ARTICULATED JOINTS OF RAMP AND CARGO DOOR | manual | 30min | 2019-05-17 15:01 | 2019-05-17 15:31 | 30 | AFM 1 | 0.5h |
| 32 | LUBRICATION OF RAMP LOCKING HOOKS MECHANISM, HINGES, RETAINING RODS AND SLIDERS | manual | 229min | 2019-05-17 15:31 | 2019-05-20 10:20 | 31 | AFM 1 | 3.82h |
| 33 | FUNCTIONAL CHECK OF EMERGENCY EXTENSION MECHANICAL LINKAGE | manual | 48min | 2019-05-20 10:20 | 2019-05-20 11:08 | 32 | AFM 1 | 0.8h |
| 34 | GENERAL VISUAL INSPECTION OF (LH) WING BOX | manual | 151min | 2019-05-13 08:00 | 2019-05-13 10:31 |  | AFM 2 | 2.52h |
| 35 | GENERAL VISUAL INSPECTION OF (LH) TRAILING EDGE AND AFT SPAR | manual | 24.3min | 2019-05-13 10:31 | 2019-05-13 10:55 | 34 | AFM 2 | 0.41h |
| 36 | GENERAL VISUAL INSPECTION OF (LH) CENTER WING SECTION AND FAIRING | manual | 226min | 2019-05-13 10:55 | 2019-05-13 15:41 | 35 | AFM 2 | 3.77h |
| 37 | GENERAL VISUAL INSPECTION OF (LH) AILERON AND FLAPS (INTERNAL AND EXTERNAL SIDE) | manual | 42min | 2019-05-13 15:41 | 2019-05-13 16:23 | 36 | AFM 2 | 0.7h |
| 38 | GENERAL VISUAL INSPECTION OF (RH) AILERON AND FLAPS (INTERNAL AND EXTERNAL SIDE) | manual | 42min | 2019-05-13 16:23 | 2019-05-14 08:05 | 37 | AFM 2 | 0.7h |
| 39 | LUBRICATION OF SEAT TRACK | manual | 30min | 2019-05-14 08:05 | 2019-05-14 08:35 | 38 | AFM 2 | 0.5h |
| 40 | LUBRICATION OF AILERON MECHANICAL 10 LINKAGE IN WING (RODS, BELL CRANKS, LEVERS, HINGES) | manual | 58min | 2019-05-14 08:35 | 2019-05-14 09:33 | 39 | AFM 2 | 0.97h |
| 41 | UBRICATION OF FLAPS MECHANICAL LINKAGE AND ROLLER /GUIDE | manual | 91min | 2019-05-14 09:33 | 2019-05-14 11:04 | 40 | AFM 2 | 1.52h |
| 42 | GENERAL VISUAL INSPECTION OF (RH) TRAILING EDGE AND AFT SPAR | manual | 24.3min | 2019-05-14 11:04 | 2019-05-14 11:28 | 41 | AFM 2 | 0.41h |
| 43 | GENERAL VISUAL INSPECTION OF NOSE LANDING GEAR | manual | 11.3min | 2019-05-14 11:28 | 2019-05-14 11:39 | 42 | AFM 2 | 0.19h |
| 44 | GENERAL VISUAL INSPECTION OF (RH) WING BOX | manual | 151min | 2019-05-14 11:39 | 2019-05-14 15:10 | 43 | AFM 2 | 2.52h |
| 45 | GENERAL VISUAL INSPECTION OF (RH) MAIN LANDING GEAR NACELLE COMPARTMENT AND HYDRAULIC SYSTEM COMPONENTS | manual | 114min | 2019-05-14 15:10 | 2019-05-15 08:04 | 44 | AFM 2 | 1.9h |
| 46 | LUBRICATION OF LAVATORY DOOR MECHANICAL GUIDE | manual | 15min | 2019-05-15 08:04 | 2019-05-15 08:19 | 45 | AFM 2 | 0.25h |
| 47 | FUNCTIONAL CHECK OF APU NOZZLE DUCT ALIGNMENT | manual | 15min | 2019-05-15 08:19 | 2019-05-15 08:34 | 46 | AFM 2 | 0.25h |
| 48 | GENERAL VISUAL INSPECTION OF A.P.U. COMPARTMENT. | manual | 2min | 2019-05-15 08:34 | 2019-05-15 08:36 | 47 | AFM 2 | 0.03h |
| 49 | REPLACEMENT OIL OF A.P.U | manual | 95min | 2019-05-15 08:36 | 2019-05-15 10:11 | 48 | AFM 2 | 1.58h |
| 50 | DETAILED VISUAL INSPECTION OF EXHAUST DUCT FOR CORROSION, CRACK AND CONDITION | manual | 82min | 2019-05-15 10:11 | 2019-05-15 11:33 | 49 | AFM 2 | 1.37h |
| 51 | DETAILED VISUAL INSPECTION FOR CRAZING AND DELAMINATION OF CABIN WINDOWS | manual | 15min | 2019-05-15 11:33 | 2019-05-15 11:48 | 50 | AFM 2 | 0.25h |
| 52 | DETAILED VISUAL INSPECTION FOR CONDITION OF AILERON TAB CONTROL FAIL SAFE LINKAGE | manual | 5min | 2019-05-15 11:48 | 2019-05-15 11:53 | 51 | AFM 2 | 0.08h |
| 53 | GENERAL VISUAL INSPECTION OF (LH) ENGINE FWD SECTION | manual | 9min | 2019-05-15 11:53 | 2019-05-15 13:02 | 52 | ENG | 0.15h |
| 54 | GENERAL VISUAL INSPECTION OF (LH) PROPELLER | manual | 2min | 2019-05-15 13:02 | 2019-05-15 13:04 | 53 | ENG | 0.03h |
| 55 | GENERAL VISUAL INSPECTION OF (RH) ENGINE FWD SECTION | manual | 9min | 2019-05-15 13:04 | 2019-05-15 13:13 | 54 | ENG | 0.15h |
| 56 | GENERAL VISUAL INSPECTION OF (RH) PROPELLER | manual | 2min | 2019-05-15 13:13 | 2019-05-15 13:15 | 55 | ENG | 0.03h |
| 57 | FUNCTIONAL CHECK OF STAND-BY INSTRUMENT | manual | 361min | 2019-05-15 13:15 | 2019-05-16 10:16 | 56 | ENG | 6.02h |
| 58 | FUNCTIONAL CHECK OF IFF SYSTEM | manual | 120min | 2019-05-16 10:16 | 2019-05-16 13:16 | 57 | AVI | 2h |
| 59 | BONDING TEST OF HF ANTENNAS FOR THEIR CORRECT INSULATION | manual | 15min | 2019-05-16 13:16 | 2019-05-16 13:31 | 58 | AVI | 0.25h |
| 60 | CLEANING OF STAND-BY PITOT AND STATIC PLUMBING | manual | 30min | 2019-05-16 13:31 | 2019-05-16 14:01 | 59 | AVI | 0.5h |
| 61 | CLEANING OF PITOT AND STATIC PLUMBING | manual | 60min | 2019-05-16 14:01 | 2019-05-16 15:01 | 60 | AVI | 1h |
| 62 | FUNCTIONAL CHECK OF DISTRIBUTED AIR DATA SYSTEM (DADS) | manual | 240min | 2019-05-16 15:01 | 2019-05-17 10:01 | 61 | AVI | 4h |
| 63 | DETAILED VISUAL INSPECTION OF COCKPIT EMERGENCY EQUIPMENT FOR CONDITION | manual | 7min | 2019-05-17 10:01 | 2019-05-17 10:08 | 62 | AVI | 0.12h |
| 64 | FUNCTIONAL CHECK OF EMERGENCY LOCATOR TRANSMITTER (E.L.T.) SYSTEM | manual | 2min | 2019-05-17 10:08 | 2019-05-17 10:10 | 63 | AVI | 0.03h |
| 65 | FUNCTIONAL CHECK OF ENGINE FIRE HANDLES AND ASSOSIATED CIRCUITS (PRIMARY AND SECONDARY FIREX) | manual | 87min | 2019-05-20 11:08 | 2019-05-20 13:35 | 33, 64 | ELC | 1.45h |
| 66 | FUNCTIONAL TEST OF ENGINE TEMPERATURE COMPENSATED PRESSURE SWITCH (T.C.P.S.). | manual | 29min | 2019-05-20 13:35 | 2019-05-20 14:04 | 65 | ELC | 0.48h |
| 67 | FUNCTIONAL TEST OF A.P.U. TEMPERATURE COMPENSATED PRESSURE SWITCH (T.C.P.S.) | manual | 29min | 2019-05-20 14:04 | 2019-05-20 14:33 | 66 | ELC | 0.48h |
| 68 | OPERATION CHECK OF:1.GENERATOR CONTROL UNIT (G.C.U.)BITE TEST 2.BUS POWER CONTROL UNIT (B.P.C.U.) BITE TEST | manual | 2min | 2019-05-20 14:33 | 2019-05-20 14:35 | 67 | ELC | 0.03h |
| 69 | OPERATIONAL CHECK OF P.D.U (POWER DISTRIBUTION UNIT) BITE TEST | manual | 2min | 2019-05-20 14:35 | 2019-05-20 14:37 | 68 | ELC | 0.03h |
| 70 | PERFORM THE LEAK TEST OF PORTABLE OXYGEN BOTTLES | manual | 5min | 2019-05-20 14:37 | 2019-05-20 14:42 | 69 | OXY | 0.08h |

| ID | Task | Type | Duration | Start | Finish | Predecessors | Resources | Work |
| --- | --- | --- | --- | --- | --- | --- | --- | --- |
| 71 | A.TEST THE DEMAND-FLOW OXYGEN REGULATOR AND MASKS B.TEST LIQUID OXYGEN QUANTITY INDICATOR | manual | 13.3min | 2019-05-20 14:42 | 2019-05-20 14:55 | 70 | OXY | 0.22h |
