# 5-42 HS2-A2

Schedule from MS Project, 2019-05-13 to 2019-05-20.

## Calendars

- Standard: Mon-Fri 08:00-12:00, 13:00-17:00; Sat-Sun off.

## Resources

| Resource |
| --- |
| AFM 1 |
| AFM 2 |
| ENG |
| ELC |
| OXY |

## Schedule

| ID | Task | Type | Duration | Start | Finish | Predecessors | Resources | Work |
| --- | --- | --- | --- | --- | --- | --- | --- | --- |
| 1 | (OPEN) ACCESS:413C, 413D, 413E 413H, 413J, 414D, 423C, 423D, 423E, 423H, 423J,424D | manual | 74min | 2019-05-13 08:00 | 2019-05-13 09:14 |  | AFM 1 | 1.23h |
| 2 | GENERAL VISUAL INSPECTION OF (LH) ENGINE NACELLES AFT SECTION | manual | 108min | 2019-05-13 09:14 | 2019-05-13 11:02 | 1 | AFM 1 | 1.8h |
| 3 | GENERAL VISUAL INSPECTION OF ENGINE FWD SECTION. | manual | 83min | 2019-05-13 11:02 | 2019-05-13 13:25 | 2 | AFM 1 | 1.38h |
| 4 | GENERAL VISUAL INSPECTION OF (RH) ENGINE NACELLES AFT SECTION | manual | 108min | 2019-05-13 13:25 | 2019-05-13 15:13 | 3 | AFM 1 | 1.8h |
| 5 | GENERAL VISUAL INSPECTION OF ENGINE NACELLES FWD SECTION | manual | 83min | 2019-05-13 15:13 | 2019-05-13 16:36 | 4 | AFM 1 | 1.38h |
| 6 | DRAINING OF HYDRAULIC FLUID FOR SAMPLING PROSEDURE (SOAP) | manual | 188min | 2019-05-13 16:36 | 2019-05-14 10:44 | 5 | AFM 1 | 3.13h |
| 7 | DETAILED VISUAL INSPECTION OF FIREWALL SEAL FOR CONDITION AND SECURITY | manual | 55min | 2019-05-15 08:19 | 2019-05-15 09:14 | 90 | AFM 1 | 0.92h |
| 8 | (CLOSE) ACCESS:413C, 413D, 413E 413H, 413J, 414D, 423C, 423D, 423E, 423H, 423J,424D | manual | 74min | 2019-05-15 09:14 | 2019-05-15 10:28 | 7 | AFM 1 | 1.23h |
| 9 | FUNCTIONAL CHECK OF V-BAND CLAMP BOLT TORQUE | manual | 32min | 2019-05-15 10:28 | 2019-05-15 11:00 | 8 | AFM 1 | 0.53h |
| 10 | GENERAL VISUAL INSPECTION OF CONDITIONING COMPARTMENT | manual | 155min | 2019-05-15 11:00 | 2019-05-15 14:35 | 9 | AFM 1 | 2.58h |
| 11 | DETAILED VISUAL INSPECTION OF VENT LINE FOR DAMAGE, CRACKS AND OBSTRUCTION | manual | 7.2min | 2019-05-15 14:35 | 2019-05-15 14:42 | 10 | AFM 1 | 0.12h |
| 12 | DETAILED VISUAL INSPECTION OF DISTRIBUTION DUCT FOR CORROSION, DAMAGE AND CRACKS. | manual | 7.2min | 2019-05-15 14:42 | 2019-05-15 14:49 | 11 | AFM 1 | 0.12h |
| 13 | DETAILED VISUAL INSPECTION OF DUCT CONNECTED TO THE CONVERTER FOR CORROSION, DAMAGE AND CRACKS | manual | 7.3min | 2019-05-15 14:49 | 2019-05-15 14:56 | 12 | AFM 1 | 0.12h |
| 14 | DETAILED VISUAL INSPECTION FOR CORRECT PRE-CHARGE VALUE OF EMERGENCY BRAKE ACCUMULATOR | manual | 6min | 2019-05-15 14:56 | 2019-05-15 15:02 | 13 | AFM 1 | 0.1h |
| 15 | CHECK OF ELEVATOR HYDRAULIC ACCUMULATOR SHUT-OFF VALVE | manual | 7min | 2019-05-15 15:02 | 2019-05-15 15:09 | 14 | AFM 1 | 0.12h |
| 16 | FUNCTIONAL TEST OF ELEVATOR JAM OVERRIDE MECHANISM (JAM) FOR PROPER FUNCTION | manual | 11.3min | 2019-05-15 15:09 | 2019-05-15 15:21 | 15 | AFM 1 | 0.19h |
| 17 | DETAILED VISUAL INSPECTION OF APU INLET DOOR | manual | 47min | 2019-05-15 15:21 | 2019-05-15 16:08 | 16 | AFM 1 | 0.78h |
| 18 | DETAILED VISUAL INSPECTION OF AIR INLET SCREEN FOR OBSTRUCTION AND DAMAGE | manual | 1min | 2019-05-15 16:08 | 2019-05-15 16:09 | 17 | AFM 1 | 0.02h |
| 19 | DETAILED VISUAL INSPECTION OF APU FILTER DISASSEMBLED FOR CONDITION AND OBSTRUCTION | manual | 31min | 2019-05-15 16:09 | 2019-05-15 16:40 | 18 | AFM 1 | 0.52h |
| 20 | (OPEN) ACCESS: 911D, 911F | manual | 34min | 2019-05-15 16:40 | 2019-05-16 08:14 | 19 | AFM 1 | 0.57h |
| 21 | A DETAILED VISUAL INSPECTION OF APU MOUNT FOR CORROSION AND WEAR B.AP.U. SHOCK ABSORBER DIMENSIONAL CHECK. | manual | 103min | 2019-05-16 08:14 | 2019-05-16 09:57 | 20 | AFM 1 | 1.72h |
| 22 | (CLOSE) ACCESS: 911D, 911F | manual | 34min | 2019-05-16 09:57 | 2019-05-16 10:31 | 21 | AFM 1 | 0.57h |
| 23 | DETAILED VISUAL INSPECTION FOR GENERAL CONDITION OF NOSE GEAR STEERING SYSTEM | manual | 12.2min | 2019-05-16 10:31 | 2019-05-16 10:43 | 22 | AFM 1 | 0.2h |
| 24 | GENERAL VISUAL INSPECTION OF STATIC SYSTEM NORMAL BREAKING FOR CORRECT OIL LEVEL AND LEAKAGE | manual | 18min | 2019-05-13 08:00 | 2019-05-13 08:18 |  | AFM 2 | 0.3h |
| 25 | GENERAL VISUAL INSPECTION OF COCKPIT (FR1 TO FR 7) A.AVIONICS DAMPING SUPPORT B.CREW SEAT BELT/OBSERVER SEAT BELTS AND ASSOCIATED MECHANISM C.PARKING/EMERGENCY BRAKE SYSTEM | manual | 71.2min | 2019-05-13 08:18 | 2019-05-13 09:29 | 24 | AFM 2 | 1.19h |
| 26 | GENERAL VISUAL INSPECTION OF COCKPIT (FRAME 1 TO FRAME 7) | manual | 50.2min | 2019-05-13 09:29 | 2019-05-13 10:19 | 25 | AFM 2 | 0.84h |
| 27 | DETAILED VISUAL INSPECTION OF MASK AND RELATED HOSE FOR CORROSION, DAMAGE AND CRACKS | manual | 5min | 2019-05-13 10:19 | 2019-05-13 10:24 | 26 | AFM 2 | 0.08h |
| 28 | DETAILED VISUAL INSPECTION OF SMOKE GOGGLES FOR CORROSION AND GENERAL DAMAGE | manual | 5min | 2019-05-13 10:24 | 2019-05-13 10:29 | 27 | AFM 2 | 0.08h |
| 29 | GENERAL VISUAL INSPECTION OF CREW DOOR, HINGE, SEAL AND COMPENSATION DEVICE ASSY | manual | 47min | 2019-05-13 10:29 | 2019-05-13 11:16 | 28 | AFM 2 | 0.78h |
| 30 | DETAILED VISUAL INSPECTION OF CREW ENTRY DOOR FOR CONDITION OF THE A.CREW DOOR DEVICES B.BRACING CABLES C.HINGE AND COMPENSATION MECHANISM | manual | 139min | 2019-05-13 11:16 | 2019-05-13 14:35 | 29 | AFM 2 | 2.32h |
| 31 | DETAILED VISUAL INSPECTION OF CREW ENTRY DOOR FOR CONDITION OF THE A.CREW DOOR DEVICES B.BRACING CABLES C.HINGE AND COMPENSATION MECHANISM | manual | 1min | 2019-05-13 14:35 | 2019-05-13 14:36 | 30 | AFM 2 | 0.02h |
| 32 | GENERAL VISUAL INSPECTION OF CREW ENTRANCE (FR 7 TO FR 98) | manual | 60min | 2019-05-13 14:36 | 2019-05-13 15:36 | 31 | AFM 2 | 1h |
| 33 | GENERAL VISUAL INSPECTION OF EMERGENCY EXIT DOOR, SEAL | manual | 15min | 2019-05-13 15:36 | 2019-05-13 15:51 | 32 | AFM 2 | 0.25h |
| 34 | DETAILED VISUAL INSPECTION OF EMERGENCY EXIT DOOR MECHANISM FOR CONDITION | manual | 27min | 2019-05-13 15:51 | 2019-05-13 16:18 | 33 | AFM 2 | 0.45h |
| 35 | OPERATIONAL CHECK OF EMERGENCY EXIT DOOR | manual | 2min | 2019-05-13 16:18 | 2019-05-13 16:20 | 34 | AFM 2 | 0.03h |
| 36 | GENERAL VISUAL INSPECTION OF (LH) PARATROOPS DOOR, SEAL, INTERNAL STRUCTURE AND COMPONENTS | manual | 30min | 2019-05-13 16:20 | 2019-05-13 16:50 | 35 | AFM 2 | 0.5h |
| 37 | GENERAL VISUAL INSPECTION OF (RH) PARATROOPS DOOR, SEAL, INTERNAL STRUCTURE AND COMPONENTS | manual | 30min | 2019-05-13 16:50 | 2019-05-14 08:20 | 36 | AFM 2 | 0.5h |
| 38 | FUNCTIONAL CHECK OF REAR LATERAL DOORS OPERATION | manual | 10min | 2019-05-14 08:20 | 2019-05-14 08:30 | 37 | AFM 2 | 0.17h |
| 39 | GENERAL VISUAL INSPECTION OF EMERGENCY EXIT, SEAL (UPPER FUSELAGE) | manual | 15min | 2019-05-14 08:30 | 2019-05-14 08:45 | 38 | AFM 2 | 0.25h |
| 40 | GENERAL VISUAL INSPECTION OF CARGO COMPARTMENT EMERGENCY EXIT, SEAL (UPPER FUSELAGE-FWD EXIT) | manual | 15min | 2019-05-14 08:45 | 2019-05-14 09:00 | 39 | AFM 2 | 0.25h |
| 41 | GENERAL VISUAL INSPECTION OF CARGO COMPARTMENT EMERGENCY EXIT, SEAL (UPPER FUSELAGE-AFT EXIT) | manual | 15min | 2019-05-14 09:00 | 2019-05-14 09:15 | 40 | AFM 2 | 0.25h |
| 42 | DETAILED VISUAL INSPECTION FOR CONDITION OF EMERGENCY EXIT HATCHES MECHANISM | manual | 66min | 2019-05-14 09:15 | 2019-05-14 10:21 | 41 | AFM 2 | 1.1h |
| 43 | OPERATIONAL CHECK OF EMERGENCY EXIT HATCHES | manual | 6min | 2019-05-14 10:21 | 2019-05-14 10:27 | 42 | AFM 2 | 0.1h |
| 44 | GENERAL VISUAL INSPECTION OF CARGO COMPT. (FR 23 TO FR 26) | manual | 73min | 2019-05-14 10:27 | 2019-05-14 11:40 | 43 | AFM 2 | 1.22h |
| 45 | GENERAL VISUAL INSPECTION OF CARGO COMPT. (FR 9B TO FR 16) | manual | 105min | 2019-05-14 11:40 | 2019-05-14 14:25 | 44 | AFM 2 | 1.75h |
| 46 | GENERAL VISUAL INSPECTION OF CARGO COMPT. (FR 16 TO FR 23) | manual | 80min | 2019-05-14 14:25 | 2019-05-14 15:45 | 45 | AFM 2 | 1.33h |
| 47 | DETAILED VISUAL INSPECTION OF ELEVATOR JAM OVERRIDE MECHANISM (JOM) FOR CONDITION | manual | 5min | 2019-05-14 15:45 | 2019-05-14 15:50 | 46 | AFM 2 | 0.08h |
| 48 | DETAILED VISUAL INSPECTION FOR CONDITION OF DOOR HINGE AND BAY EMERGENCY LIFERAFT | manual | 29min | 2019-05-14 15:50 | 2019-05-14 16:19 | 47 | AFM 2 | 0.48h |
| 49 | DETAILED VISUAL INSPECTION OF SERVOMOTORS DRUM AND BRACKETS FOR PRESENCE OF CORROSION, CRACKS, DETERIORATION AND GENERAL CONDITIONS | manual | 48min | 2019-05-14 16:19 | 2019-05-15 08:07 | 48 | AFM 2 | 0.8h |
| 50 | CHECK OF AILERONS CABLE FOR CORRECT TENSION INCLUDED THE AUTOPILOT ACTUATOR CABLE | manual | 109min | 2019-05-15 08:07 | 2019-05-15 09:56 | 49 | AFM 2 | 1.82h |
| 51 | DETAILED VISUAL INSPECTION FOR CONDITION OF BATTERY COMPARTMENT ACCESS HINGE AND BATTERY SUPPORT | manual | 11min | 2019-05-15 09:56 | 2019-05-15 10:07 | 50 | AFM 2 | 0.18h |
| 52 | GENERAL VISUAL INSPECTION OF CARGO COMPARTMENT UNDERFLOOR (FRAME 7 TO FRAME 29) | manual | 173min | 2019-05-15 10:07 | 2019-05-15 14:00 | 51 | AFM 2 | 2.88h |
| 53 | CHECK OF AILERONS CABLE FOR CORRECT TENSION INCLUDED THE AUTOPILOT ACTUATOR CABLE | manual | 109min | 2019-05-15 14:00 | 2019-05-15 15:49 | 52 | AFM 2 | 1.82h |
| 54 | GENERAL VISUAL INSPECTION OF CARGO RAMP, SEAL | manual | 95min | 2019-05-15 15:49 | 2019-05-16 08:24 | 53 | AFM 2 | 1.58h |
| 55 | DETAILED VISUAL INSPECTION OF RETAINING RODS AND SLIDERS OF RAMP DOOR FOR CONDITION | manual | 105min | 2019-05-16 08:24 | 2019-05-16 10:09 | 54 | AFM 2 | 1.75h |
| 56 | DETAILED VISUAL INSPECTION OF LOCKING HOOKS AND TORQUE TUBE OF RAMP DOOR FOR CONDITION | manual | 154min | 2019-05-16 10:09 | 2019-05-16 13:43 | 55 | AFM 2 | 2.57h |
| 57 | FUNCTIONAL CHECK OF PRESSURIZATION SYSTEM FOR: A.OVERPRESSURE B.NEGATIVE PRESSURE | manual | 63min | 2019-05-16 13:43 | 2019-05-16 14:46 | 56 | AFM 2 | 1.05h |
| 58 | DETAILED VISUAL INSPECTION OF OIL SYSTEM FOR LEAKS | manual | 10min | 2019-05-16 14:46 | 2019-05-16 14:56 | 57 | AFM 2 | 0.17h |
| 59 | OPERATIONAL CHECK TO VERIFY AUTOMATIC DRAIN VALVES (ADV) FAILURE | manual | 72min | 2019-05-16 14:56 | 2019-05-16 16:08 | 58 | AFM 2 | 1.2h |
| 60 | FUNCTIONAL CHECK OF FLAP FROM HYDRAULIC SYSTEM No1 & No2 | manual | 40min | 2019-05-16 16:08 | 2019-05-16 16:48 | 59 | AFM 2 | 0.67h |
| 61 | SERVICING FOR ELEVATOR HYDRAULIC ACCUMULATOR CHARGE | manual | 5min | 2019-05-16 16:48 | 2019-05-16 16:53 | 60 | AFM 2 | 0.08h |
| 62 | FUNCTIONAL CHECK OF ELEVATOR CONTROL TO VERIFY THE CORRECT ARTIFICIAL FORCE IN THE TOTAL OPERATIVE ENVELOP | manual | 34min | 2019-05-16 16:53 | 2019-05-17 08:27 | 61, 23 | AFM 2 | 0.57h |
| 63 | FUNCTIONAL CHECK TO VERIFY THE STOP FUNCTION AT THE END OF FLAP TRAVEL | manual | 10min | 2019-05-17 08:27 | 2019-05-17 08:37 | 62 | AFM 2 | 0.17h |
| 64 | FUNCTIONAL CHECK OF SPOILERS FOR CORRECT EXTENSION | manual | 20min | 2019-05-17 08:37 | 2019-05-17 08:57 | 63 | AFM 2 | 0.33h |
| 65 | CHECK OF SYSTEM SPOILER FOR: A.BY-PASS CORRECT FUNCTION B.BUNGEE AND MIXER BOX MOVEMENT FOR CORRECT OPERATION | manual | 30min | 2019-05-17 08:57 | 2019-05-17 09:27 | 64 | AFM 2 | 0.5h |
| 66 | OPERATIONAL CHECK OF FUEL PUMP WORKING | manual | 15min | 2019-05-17 09:27 | 2019-05-17 09:42 | 65 | AFM 2 | 0.25h |
| 67 | OPERATIONAL CHECK OF STALL WARNING STICK SHACKER (SWS) SYSTEM FOR CORRECT FUNCTION | manual | 5min | 2019-05-17 09:42 | 2019-05-17 09:47 | 66 | AFM 2 | 0.08h |
| 68 | FUNCTIONAL CHECK OF: A.GND / AIR RELAY OF PITOT PROBES B.CURRENT SENSOR INDICATING (PITOT, AOA) | manual | 7min | 2019-05-17 09:47 | 2019-05-17 09:54 | 67 | AFM 2 | 0.12h |
| 69 | OPERATIONAL CHECK TO VERIFY TANK FULL AUTOMATIC REFUEL CUT-OFF | manual | 16min | 2019-05-17 09:54 | 2019-05-17 10:10 | 68 | AFM 2 | 0.27h |
| 70 | OPERATIONAL CHECK OF HYDRAULIC SYSTEM No1 & No2 SHUT-OFF VALVE | manual | 14min | 2019-05-17 10:10 | 2019-05-17 10:24 | 69 | AFM 2 | 0.23h |

| ID | Task | Type | Duration | Start | Finish | Predecessors | Resources | Work |
| --- | --- | --- | --- | --- | --- | --- | --- | --- |
| 71 | CHECK OF TRIM-TAB AILERON TRAVEL | manual | 9min | 2019-05-17 10:24 | 2019-05-17 10:33 | 70 | AFM 2 | 0.15h |
| 72 | FUNCTIONAL CHECK OF FLAP ASYMMETRY CONTROL SYSTEM | manual | 24.3min | 2019-05-17 10:33 | 2019-05-17 10:57 | 71 | AFM 2 | 0.41h |
| 73 | FUNCTIONAL CHECK OF FLAP POSITION INDICATOR | manual | 41min | 2019-05-17 10:57 | 2019-05-17 11:38 | 72 | AFM 2 | 0.68h |
| 74 | FUNCTIONAL CHECK OF RUDDER CENTERING SPRING IN ORDER TO VERIFY THE RETURN TO "0" POSITION WITHOUT PILOT LINK | manual | 9min | 2019-05-17 11:38 | 2019-05-17 11:47 | 73 | AFM 2 | 0.15h |
| 75 | FUNCTIONAL CHECK OF RUDDER TRAVEL LIMITATION UNIT (RTLU) SYSTEM, RELATIVE WARNING AND OVERRIDE SWITCH FOR CORRECT OPERATION | manual | 41min | 2019-05-17 11:47 | 2019-05-17 13:28 | 74 | AFM 2 | 0.68h |
| 76 | OPERATIONAL CHECK OF TRIM-RUDDER EMERGENCY FUNCTION | manual | 13min | 2019-05-17 13:28 | 2019-05-17 13:41 | 75 | AFM 2 | 0.22h |
| 77 | FUNCTIONAL CHECK OF FLAP FROM HYDRAULIC SYSTEM No1 & No2 | manual | 7min | 2019-05-17 13:41 | 2019-05-17 13:48 | 76 | AFM 2 | 0.12h |
| 78 | OPERATIONAL CHECK OF COCKPIT PRIORITY VALVE | manual | 8min | 2019-05-17 13:48 | 2019-05-17 13:56 | 77 | AFM 2 | 0.13h |
| 79 | OPERATIONAL CHECK OF RAM AIR EMERGENCY VENTILATION VALVE | manual | 4min | 2019-05-17 13:56 | 2019-05-17 14:00 | 78 | AFM 2 | 0.07h |
| 80 | FUNCTIONAL CHECK OF HEATING ELEMENT OF PROBE TOTAL AIR TEMPERATURE (TAT) | manual | 6min | 2019-05-17 14:00 | 2019-05-17 14:06 | 79 | AFM 2 | 0.1h |
| 81 | OPERATIONAL CHECK OF TRIANGULAR WINDOWS AND SLIDING WINDOW HEATING | manual | 9min | 2019-05-17 14:06 | 2019-05-17 14:15 | 80 | AFM 2 | 0.15h |
| 82 | FUNCTIONAL CHECK OF JETTISON SYSTEM | manual | 16min | 2019-05-17 14:15 | 2019-05-17 14:31 | 81 | AFM 2 | 0.27h |
| 83 | DETAILED VISUAL INSPECTION OF GROUNDING STRAPS | manual | 60min | 2019-05-14 10:44 | 2019-05-14 11:44 | 6 | ENG | 1h |
| 84 | DETAILED VISUAL INSPECTION OF REAR TURBINE BEARING OIL SCAVENGE TUBE FOR ANY SIGN OF OIL LEAKAGE | manual | 30min | 2019-05-14 11:44 | 2019-05-14 13:14 | 83 | ENG | 0.5h |
| 85 | DETAILED VISUAL INSPECTION OF EXTERNAL PORTION OF REAR TURBINE BEARING SUPPORT FOR SECURITY AND GENERAL CONDITION | manual | 30min | 2019-05-14 13:14 | 2019-05-14 13:44 | 84 | ENG | 0.5h |
| 86 | DETAILED VISUAL INSPECTION OF EXTERNAL PORTION OF THE REAR TURBINE BEARING SUPPORT FOR OIL LEAKAGE | manual | 30min | 2019-05-14 13:44 | 2019-05-14 14:14 | 85 | ENG | 0.5h |
| 87 | GENERAL VISUAL INSPECTION OF TUBES AND HOSES ASSEMBLY FOR SECURITY AND CONDITION | manual | 47min | 2019-05-14 14:14 | 2019-05-14 15:01 | 86 | ENG | 0.78h |
| 88 | DETAILED VISUAL INSPECTION OF INLET GUIDE VANES AND COMPRESSOR BLADES | manual | 64min | 2019-05-14 15:01 | 2019-05-14 16:05 | 87 | ENG | 1.07h |
| 89 | DETAILED VISUAL INSPECTION OF COMBUSTION LINER AND DIFFUSER CASE | manual | 64min | 2019-05-14 16:05 | 2019-05-15 08:09 | 88 | ENG | 1.07h |
| 90 | DETAILED VISUAL INSPECTION OF OIL SYSTEM FOR LEAKS | manual | 10min | 2019-05-15 08:09 | 2019-05-15 08:19 | 89 | ENG | 0.17h |
| 91 | FUNCTIONAL CHECK OF ENGINE AND PROPELLER ANTI-ICE SYSTEMS | manual | 10min | 2019-05-17 14:31 | 2019-05-17 14:41 | 82 | ENG | 0.17h |
| 92 | OPERATIONAL CHECK OF APU REMOTE FIRE EXTINGUISH SWITCH AND ASSOCIATED CIRCUIT | manual | 42min | 2019-05-17 14:41 | 2019-05-17 15:23 | 91 | ELC | 0.7h |
| 93 | FUNCTIONAL CHECK OF VISUAL ICE DETECTOR | manual | 5min | 2019-05-17 15:23 | 2019-05-17 15:28 | 92 | ELC | 0.08h |
| 94 | FUNCTIONAL CHECK OF OVERBOARD VALVE | manual | 6min | 2019-05-17 15:28 | 2019-05-17 15:34 | 93 | ELC | 0.1h |
| 95 | OPERATIONAL CHECK OF APU REMOTE FIRE EXTINGUISH SWITCH AND ASSOCIATED CIRCUIT | manual | 42min | 2019-05-17 15:34 | 2019-05-17 16:16 | 94 | ELC | 0.7h |
| 96 | OPERATIONAL CHECK OF APU T-HANDLE AND FIRE EXTINGUISHER CIRCUIT FOR PROPER FUNCTION | manual | 41min | 2019-05-17 16:16 | 2019-05-17 16:57 | 95 | ELC | 0.68h |
| 97 | OPERATIONAL CHECK OF OVRD FUNCTION | manual | 1min | 2019-05-17 16:57 | 2019-05-17 16:58 | 96 | ELC | 0.02h |
| 98 | OPERATIONAL CHECK OF BUS TIE CONTACTOR (BTC) | manual | 1min | 2019-05-17 16:58 | 2019-05-17 16:59 | 97 | ELC | 0.02h |
| 99 | OPERATIONAL CHECK OF POSITION LIGHT SYSTEM | manual | 1min | 2019-05-17 16:59 | 2019-05-20 08:00 | 98 | ELC | 0.02h |
| 100 | FUNCTIONAL CHECK OF CARGO SMOKE DETECTORS FOR PROPER FUNCTION | manual | 10min | 2019-05-20 08:00 | 2019-05-20 08:10 | 99 | ELC | 0.17h |
| 101 | FUNCTIONAL CHECK OF LAVATORY SMOKE DETECTOR FOR PROPER FUNCTION | manual | 1min | 2019-05-20 08:10 | 2019-05-20 08:11 | 100 | ELC | 0.02h |
| 102 | FUNCTIONAL TEST OF STBY TRANSFORMER RECTIFIER UNITS (TRU) SUPPLY CHECK | manual | 5min | 2019-05-20 08:11 | 2019-05-20 08:16 | 101 | ELC | 0.08h |
| 103 | FUNCTIONAL CHECK OF CARGO OXYGEN SYSTEM FOR PROPER FUNCTION | manual | 32.2min | 2019-05-20 08:16 | 2019-05-20 08:48 | 102 | OXY | 0.54h |
