# 5-6 HS1

Schedule from MS Project, 2019-04-18 to 2019-04-18, 7 hours a day.

## Calendars

- Standard: Mon-Fri 08:00-12:00, 13:00-17:00; Sat-Sun off.

## Resources

| Resource |
| --- |
| ENG |
| AFM 1 |
| ELC |
| OXY |
| AVI |

## Schedule

| ID | Task | Type | Duration | Start | Finish | Resources | Work |
| --- | --- | --- | --- | --- | --- | --- | --- |
| 1 | GENERAL VISUAL INSPECTION OF (LH) ENGINE FWD SECTION | manual | 9min | 2019-04-18 08:00 | 2019-04-18 08:09 | ENG | 0.15h |
| 2 | GENERAL VISUAL INSPECTION OF (RH) ENGINE FWD SECTION | manual | 9min | 2019-04-18 08:00 | 2019-04-18 08:09 | ENG | 0.15h |
| 3 | GENERAL VISUAL INSPECTION OF (LH) PROPELLER | manual | 2min | 2019-04-18 08:00 | 2019-04-18 08:02 | ENG | 0.03h |
| 4 | GENERAL VISUAL INSPECTION OF (RH) PROPELLER | manual | 2min | 2019-04-18 08:00 | 2019-04-18 08:02 | ENG | 0.03h |
| 5 | GENERAL VISUAL INSPECTION OF EXTERNAL ZONE A.CREW,PARATROOP DOOR. B.EMERGENCY EXITS C.RAMP AND CARGO DOOR | manual | 3min | 2019-04-18 08:00 | 2019-04-18 08:03 | AFM 1 | 0.05h |
| 6 | GENERAL VISUAL INSPECTION OF A.P.U. COMPARTMENT. | manual | 2min | 2019-04-18 08:00 | 2019-04-18 08:02 | AFM 1 | 0.03h |
| 7 | DETAIL VISUAL INSPECTION OF LIFE RAFT ACCESS PANEL LOCKING FOR CONDITION, CORROSIO, CRACKS & WEAR | manual | 30min | 2019-04-18 08:00 | 2019-04-18 08:30 | AFM 1 | 0.5h |
| 8 | FUNCTIONAL CHECK OF EMERGENCY EXTENSION MECHANICAL LINKAGE | manual | 48min | 2019-04-18 08:00 | 2019-04-18 08:48 | AFM 1 | 0.8h |
| 9 | LUBRICATION OF ALL MECHANICAL LINKAGE AND CABLE | manual | 251min | 2019-04-18 08:00 | 2019-04-18 13:11 | AFM 1 | 4.18h |
| 10 | LUBRICATION OF AILERON MECHANICAL 10 LINKAGE IN WING (RODS, BELL CRANKS, LEVERS, HINGES) | manual | 58min | 2019-04-18 08:00 | 2019-04-18 08:58 | AFM 1 | 0.97h |
| 11 | LUBRICATION OF RUDDER INTERCONNECTION RODS. | manual | 118min | 2019-04-18 08:00 | 2019-04-18 09:58 | AFM 1 | 1.97h |
| 12 | LUBRICATION OF TRIM-RUDDER MECHANISM. | manual | 22min | 2019-04-18 08:00 | 2019-04-18 08:22 | AFM 1 | 0.37h |
| 13 | UBRICATION OF FLAPS MECHANICAL LINKAGE AND ROLLER /GUIDE | manual | 91min | 2019-04-18 08:00 | 2019-04-18 09:31 | AFM 1 | 1.52h |
| 14 | LUBRICATION OF GUST LOCK MECHANICAL LINKAGE | manual | 43.2min | 2019-04-18 08:00 | 2019-04-18 08:43 | AFM 1 | 0.72h |
| 15 | REPLACEMENT OIL OF A.P.U | manual | 95min | 2019-04-18 08:00 | 2019-04-18 09:35 | ENG | 1.58h |
| 16 | OPERATION CHECK OF:1.GENERATOR CONTROL UNIT (G.C.U.)BITE TEST 2.BUS POWER CONTROL UNIT (B.P.C.U.) BITE TEST | manual | 2min | 2019-04-18 08:00 | 2019-04-18 08:02 | ELC | 0.03h |
| 17 | OPERATIONAL CHECK OF P.D.U (POWER DISTRIBUTION UNIT) BITE TEST | manual | 2min | 2019-04-18 08:00 | 2019-04-18 08:02 | ELC | 0.03h |
| 18 | A.TEST THE DEMAND-FLOW OXYGEN REGULATOR AND MASKS B.TEST LIQUID OXYGEN QUANTITY INDICATOR | manual | 13.3min | 2019-04-18 08:00 | 2019-04-18 08:13 | ELC | 0.22h |
| 19 | PERFORM THE LEAK TEST OF PORTABLE OXYGEN BOTTLES | manual | 5min | 2019-04-18 08:00 | 2019-04-18 08:05 | OXY | 0.08h |
| 20 | FUNCTIONAL CHECK OF LIFE-RAFT DOOR UNLOCKING | manual | 31min | 2019-04-18 08:00 | 2019-04-18 08:31 | AFM 1 | 0.52h |
| 21 | FUNCTIONAL CHECK OF EMERGENCY LOCATOR TRANSMITTER (E.L.T.) SYSTEM | manual | 2min | 2019-04-18 08:00 | 2019-04-18 08:02 | AVI | 0.03h |
| 22 | FUNCTIONAL CHECK OF EMERGENCY LOCATOR TRANSMITTER (E.L.T.) SYSTEM | manual | 87min | 2019-04-18 08:00 | 2019-04-18 09:27 | ELC | 1.45h |
| 23 | FUNCTIONAL TEST OF ENGINE TEMPERATURE COMPENSATED PRESSURE SWITCH (T.C.P.S.). | manual | 29min | 2019-04-18 08:00 | 2019-04-18 08:29 | ELC | 0.48h |
| 24 | FUNCTIONAL TEST OF A.P.U. TEMPERATURE COMPENSATED PRESSURE SWITCH (T.C.P.S.) | manual | 29min | 2019-04-18 08:00 | 2019-04-18 08:29 | ELC | 0.48h |
