# 5-7 HS1

Schedule from MS Project, 2019-04-18 to 2019-04-19.

## Calendars

- Standard: Mon-Fri 08:00-12:00, 13:00-17:00; Sat-Sun off.

## Resources

| Resource |
| --- |
| AFM 1 |
| OXY |
| ENG |
| AVI |
| ELC |

## Schedule

| ID | Task | Type | Duration | Start | Finish | Predecessors | Total slack | Resources | Work |
| --- | --- | --- | --- | --- | --- | --- | --- | --- | --- |
| 1 | GENERAL VISUAL INSPECTION OF EXTERNAL ZONE A.CREW,PARATROOP DOOR. B.EMERGENCY EXITS C.RAMP AND CARGO DOOR | manual | 3min | 2019-04-18 08:00 | 2019-04-18 08:03 |  |  | AFM 1 | 0.05h |
| 2 | GENERAL VISUAL INSPECTION OF A.P.U. COMPARTMENT. | manual | 2min | 2019-04-18 08:03 | 2019-04-18 08:05 | 1 |  | AFM 1 | 0.03h |
| 3 | DETAIL VISUAL INSPECTION OF LIFE RAFT ACCESS PANEL LOCKING FOR CONDITION, CORROSIO, CRACKS & WEAR | manual | 30min | 2019-04-18 08:05 | 2019-04-18 08:35 | 2 |  | AFM 1 | 0.5h |
| 4 | FUNCTIONAL CHECK OF LIFE-RAFT DOOR UNLOCKING | manual | 31min | 2019-04-18 08:35 | 2019-04-18 09:06 | 3 |  | AFM 1 | 0.52h |
| 5 | LUBRICATION OF AILERON MECHANICAL 10 LINKAGE IN WING (RODS, BELL CRANKS, LEVERS, HINGES) | manual | 58min | 2019-04-18 09:06 | 2019-04-18 10:04 | 4, 18 |  | AFM 1 | 0.97h |
| 6 | LUBRICATION OF FLAPS MECHANICAL LINKAGE AND ROLLER /GUIDE | manual | 91min | 2019-04-18 10:04 | 2019-04-18 11:35 | 5 |  | AFM 1 | 1.52h |
| 7 | LUBRICATION OF ALL MECHANICAL LINKAGE AND CABLE | manual | 251min | 2019-04-18 11:35 | 2019-04-18 16:46 | 6 |  | AFM 1 | 4.18h |
| 8 | LUBRICATION OF GUST LOCK MECHANICAL LINKAGE | manual | 43min | 2019-04-18 16:46 | 2019-04-19 08:29 | 7 |  | AFM 1 | 0.72h |
| 9 | LUBRICATION OF RUDDER INTERCONNECTION RODS. | manual | 118min | 2019-04-19 08:29 | 2019-04-19 10:27 | 8 |  | AFM 1 | 1.97h |
| 10 | LUBRICATION OF TRIM-RUDDER MECHANISM. | manual | 22min | 2019-04-19 10:27 | 2019-04-19 10:49 | 9 |  | AFM 1 | 0.37h |
| 11 | REPLACEMENT OIL OF A.P.U | manual | 95min | 2019-04-19 10:49 | 2019-04-19 13:24 | 10 |  | AFM 1 | 1.58h |
| 12 | FUNCTIONAL CHECK OF EMERGENCY EXTENSION MECHANICAL LINKAGE |  | 48min | 2019-04-19 16:08 | 2019-04-19 16:56 | 19 | 0d | AFM 1 | 0.8h |
| 13 | PERFORM THE LEAK TEST OF PORTABLE OXYGEN BOTTLES | manual | 5min | 2019-04-18 08:00 | 2019-04-18 08:05 |  |  | OXY | 0.08h |
| 14 | A.TEST THE DEMAND-FLOW OXYGEN REGULATOR AND MASKS B.TEST LIQUID OXYGEN QUANTITY INDICATOR | manual | 13min | 2019-04-19 15:53 | 2019-04-19 16:06 | 24 |  | OXY | 0.22h |
| 15 | GENERAL VISUAL INSPECTION OF (LH) ENGINE FWD SECTION | manual | 9min | 2019-04-18 08:05 | 2019-04-18 08:14 | 13 |  | ENG | 0.15h |
| 16 | GENERAL VISUAL INSPECTION OF (LH) PROPELLER | manual | 2min | 2019-04-18 08:14 | 2019-04-18 08:16 | 15 |  | ENG | 0.03h |
| 17 | GENERAL VISUAL INSPECTION OF (RH) ENGINE FWD SECTION | manual | 9min | 2019-04-18 08:16 | 2019-04-18 08:25 | 16 |  | ENG | 0.15h |
| 18 | GENERAL VISUAL INSPECTION OF (RH) PROPELLER | manual | 2min | 2019-04-18 08:25 | 2019-04-18 08:27 | 17 |  | ENG | 0.03h |
| 19 | FUNCTIONAL CHECK OF EMERGENCY LOCATOR TRANSMITTER (E.L.T.) SYSTEM | manual | 2min | 2019-04-19 16:06 | 2019-04-19 16:08 | 14 |  | AVI | 0.03h |
| 20 | FUNCTIONAL CHECK OF ENGINE FIRE HANDLES AND ASSOSIATED CIRCUITS (PRIMARY AND SECONDARY FIREX) | manual | 87min | 2019-04-19 13:24 | 2019-04-19 14:51 | 11 |  | ELC | 1.45h |
| 21 | FUNCTIONAL TEST OF ENGINE TEMPERATURE COMPENSATED PRESSURE SWITCH (T.C.P.S.). | manual | 29min | 2019-04-19 14:51 | 2019-04-19 15:20 | 20 |  | ELC | 0.48h |
| 22 | FUNCTIONAL TEST OF A.P.U. TEMPERATURE COMPENSATED PRESSURE SWITCH (T.C.P.S.) | manual | 29min | 2019-04-19 15:20 | 2019-04-19 15:49 | 21 |  | ELC | 0.48h |
| 23 | OPERATION CHECK OF:1.GENERATOR CONTROL UNIT (G.C.U.)BITE TEST 2.BUS POWER CONTROL UNIT (B.P.C.U.) BITE TEST | manual | 2min | 2019-04-19 15:49 | 2019-04-19 15:51 | 22 |  | ELC | 0.03h |
| 24 | OPERATIONAL CHECK OF P.D.U (POWER DISTRIBUTION UNIT) BITE TEST | manual | 2min | 2019-04-19 15:51 | 2019-04-19 15:53 | 23 |  | ELC | 0.03h |
