# 5-9 HS2

Schedule from MS Project, 2019-04-18 to 2019-04-18, 7 hours a day.

## Calendars

- Standard: Mon-Fri 08:00-12:00, 13:00-17:00; Sat-Sun off.

## Resources

| Resource |
| --- |
| AFM 1 |
| ELC |
| OXY |

## Schedule

| ID | Task | Type | Duration | Start | Finish | Resources | Work |
| --- | --- | --- | --- | --- | --- | --- | --- |
| 1 | GENERAL VISUAL INSPECTION OF COCKPIT (FR1 TO FR 7) A.AVIONICS DAMPING SUPPORT B.CREW SEAT BELT/OBSERVER SEAT BELTS AND ASSOCIATED MECHANISM C.PARKING/EMERGENCY BRAKE SYSTEM | manual | 71.2min | 2019-04-18 08:00 | 2019-04-18 09:11 | AFM 1 | 1.19h |
| 2 | GENERAL VISUAL INSPECTION OF CREW ENTRANCE (FR 7 TO FR 98) | manual | 60min | 2019-04-18 08:00 | 2019-04-18 09:00 | AFM 1 | 1h |
| 3 | GENERAL VISUAL INSPECTION OF CARGO COMPT. (FR 9B TO FR 16) | manual | 105min | 2019-04-18 08:00 | 2019-04-18 09:45 | AFM 1 | 1.75h |
| 4 | GENERAL VISUAL INSPECTION OF CARGO COMPT. (FR 16 TO FR 23) | manual | 80min | 2019-04-18 08:00 | 2019-04-18 09:20 | AFM 1 | 1.33h |
| 5 | GENERAL VISUAL INSPECTION OF CARGO COMPT. (FR 23 TO FR 26) | manual | 73min | 2019-04-18 08:00 | 2019-04-18 09:13 | AFM 1 | 1.22h |
| 6 | GENERAL VISUAL INSPECTION OF AFT FUSELAGE SECTION (FR 29 TO FR 47) | manual | 100min | 2019-04-18 08:00 | 2019-04-18 09:40 | AFM 1 | 1.67h |
| 7 | GENERAL VISUAL INSPECTION OF ENGINE FWD SECTION. | manual | 83min | 2019-04-18 08:00 | 2019-04-18 09:23 | AFM 1 | 1.38h |
| 8 | GENERAL VISUAL INSPECTION OF ENGINE NACELLES FWD SECTION | manual | 83min | 2019-04-18 08:00 | 2019-04-18 09:23 | AFM 1 | 1.38h |
| 9 | GENERAL VISUAL INSPECTION OF STATIC SYSTEM NORMAL BREAKING FOR CORRECT OIL LEVEL AND LEAKAGE | manual | 18min | 2019-04-18 08:00 | 2019-04-18 08:18 | AFM 1 | 0.3h |
| 10 | DETAILED VISUAL INSPECTION FOR CORRECT PRE-CHARGE VALUE OF EMERGENCY BRAKE ACCUMULATOR | manual | 6min | 2019-04-18 08:00 | 2019-04-18 08:06 | AFM 1 | 0.1h |
| 11 | CHECK OF AILERONS CABLE FOR CORRECT TENSION INCLUDED THE AUTOPILOT ACTUATOR CABLE | manual | 109min | 2019-04-18 08:00 | 2019-04-18 09:49 | AFM 1 | 1.82h |
| 12 | CHECK OF TRIM-TAB AILERON TRAVEL | manual | 9min | 2019-04-18 08:00 | 2019-04-18 08:09 | AFM 1 | 0.15h |
| 13 | FUNCTIONAL CHECK OF RUDDER CENTERING SPRING IN ORDER TO VERIFY THE RETURN TO "0" POSITION WITHOUT PILOT LINK | manual | 9min | 2019-04-18 08:00 | 2019-04-18 08:09 | AFM 1 | 0.15h |
| 14 | FUNCTIONAL CHECK OF RUDDER TRAVEL LIMITATION UNIT (RTLU) SYSTEM, RELATIVE WARNING AND OVERRIDE SWITCH FOR CORRECT OPERATION | manual | 41min | 2019-04-18 08:00 | 2019-04-18 08:41 | AFM 1 | 0.68h |
| 15 | OPERATIONAL CHECK OF TRIM-RUDDER EMERGENCY FUNCTION | manual | 13min | 2019-04-18 08:00 | 2019-04-18 08:13 | AFM 1 | 0.22h |
| 16 | DETAILED VISUAL INSPECTION OF ELEVATOR JAM OVERRIDE MECHANISM (JOM) FOR CONDITION | manual | 5min | 2019-04-18 08:00 | 2019-04-18 08:05 | AFM 1 | 0.08h |
| 17 | CHECK OF ELEVATOR HYDRAULIC ACCUMULATOR SHUT-OFF VALVE | manual | 7min | 2019-04-18 08:00 | 2019-04-18 08:07 | AFM 1 | 0.12h |
| 18 | FUNCTIONAL TEST OF ELEVATOR JAM OVERRIDE MECHANISM (JAM) FOR PROPER FUNCTION | manual | 11.3min | 2019-04-18 08:00 | 2019-04-18 08:11 | AFM 1 | 0.19h |
| 19 | OPERATIONAL CHECK OF STALL WARNING STICK SHACKER (SWS) SYSTEM FOR CORRECT FUNCTION | manual | 5min | 2019-04-18 08:00 | 2019-04-18 08:05 | AFM 1 | 0.08h |
| 20 | FUNCTIONAL CHECK OF FLAP ASYMMETRY CONTROL SYSTEM | manual | 24.3min | 2019-04-18 08:00 | 2019-04-18 08:24 | AFM 1 | 0.41h |
| 21 | FUNCTIONAL CHECK OF FLAP FROM HYDRAULIC SYSTEM No1 & No2 | manual | 7min | 2019-04-18 08:00 | 2019-04-18 08:07 | AFM 1 | 0.12h |
| 22 | FUNCTIONAL CHECK OF FLAP POSITION INDICATOR | manual | 41min | 2019-04-18 08:00 | 2019-04-18 08:41 | AFM 1 | 0.68h |
| 23 | DETAILED VISUAL INSPECTION OF FIREWALL SEAL FOR CONDITION AND SECURITY | manual | 55min | 2019-04-18 08:00 | 2019-04-18 08:55 | AFM 1 | 0.92h |
| 24 | FUNCTIONAL CHECK OF V-BAND CLAMP BOLT TORQUE | manual | 32min | 2019-04-18 08:00 | 2019-04-18 08:32 | AFM 1 | 0.53h |
| 25 | A DETAILED VISUAL INSPECTION OF APU MOUNT FOR CORROSION AND WEAR B.AP.U. SHOCK ABSORBER DIMENSIONAL CHECK. | manual | 103min | 2019-04-18 08:00 | 2019-04-18 09:43 | AFM 1 | 1.72h |
| 26 | DETAILED VISUAL INSPECTION OF APU INLET DOOR | manual | 47min | 2019-04-18 08:00 | 2019-04-18 08:47 | AFM 1 | 0.78h |
| 27 | DETAILED VISUAL INSPECTION OF AIR INLET SCREEN FOR OBSTRUCTION AND DAMAGE | manual | 1min | 2019-04-18 08:00 | 2019-04-18 08:01 | AFM 1 | 0.02h |
| 28 | OPERATIONAL CHECK OF COCKPIT PRIORITY VALVE | manual | 8min | 2019-04-18 08:00 | 2019-04-18 08:08 | AFM 1 | 0.13h |
| 29 | OPERATIONAL CHECK OF RAM AIR EMERGENCY VENTILATION VALVE | manual | 4min | 2019-04-18 08:00 | 2019-04-18 08:04 | AFM 1 | 0.07h |
| 30 | FUNCTIONAL CHECK OF HEATING ELEMENT OF PROBE TOTAL AIR TEMPERATURE (TAT) | manual | 6min | 2019-04-18 08:00 | 2019-04-18 08:06 | AFM 1 | 0.1h |
| 31 | FUNCTIONAL CHECK OF: A.GND / AIR RELAY OF PITOT PROBES B.CURRENT SENSOR INDICATING (PITOT, AOA) | manual | 7min | 2019-04-18 08:00 | 2019-04-18 08:07 | AFM 1 | 0.12h |
| 32 | OPERATIONAL CHECK OF TRIANGULAR WINDOWS AND SLIDING WINDOW HEATING | manual | 9min | 2019-04-18 08:00 | 2019-04-18 08:09 | AFM 1 | 0.15h |
| 33 | FUNCTIONAL TEST OF STBY TRANSFORMER RECTIFIER UNITS (TRU) SUPPLY CHECK | manual | 5min | 2019-04-18 08:00 | 2019-04-18 08:05 | ELC | 0.08h |
| 34 | OPERATIONAL CHECK OF OVRD FUNCTION | manual | 1min | 2019-04-18 08:00 | 2019-04-18 08:01 | ELC | 0.02h |
| 35 | OPERATIONAL CHECK OF BUS TIE CONTACTOR (BTC) | manual | 1min | 2019-04-18 08:00 | 2019-04-18 08:01 | ELC | 0.02h |
| 36 | OPERATIONAL CHECK OF HYDRAULIC SYSTEM No1 & No2 SHUT-OFF VALVE | manual | 14min | 2019-04-18 08:00 | 2019-04-18 08:14 | AFM 1 | 0.23h |
| 37 | DRAINING OF HYDRAULIC FLUID FOR SAMPLING PROSEDURE (SOAP) | manual | 188min | 2019-04-18 08:00 | 2019-04-18 11:08 | AFM 1 | 3.13h |
| 38 | DETAILED VISUAL INSPECTION OF APU FILTER DISASSEMBLED FOR CONDITION AND OBSTRUCTION | manual | 31min | 2019-04-18 08:00 | 2019-04-18 08:31 | AFM 1 | 0.52h |
| 39 | FUNCTIONAL CHECK OF JETTISON SYSTEM | manual | 16min | 2019-04-18 08:00 | 2019-04-18 08:16 | AFM 1 | 0.27h |
| 40 | FUNCTIONAL CHECK OF CARGO OXYGEN SYSTEM FOR PROPER FUNCTION | manual | 32.2min | 2019-04-18 08:00 | 2019-04-18 08:32 | OXY | 0.54h |
